# Programa de Fortalecimiento de la Gestión Institucional del Contraloría General de la República de Colombia

Schedule from MS Project, 2015-02-15 to 2021-01-25.
Toshiba
Recomendaciones para la utilizacion de la Plantilla: / 1. La informacion contenida es de caracter general y es suceptible de ser modificada (agregar o suprimir actividades) de acuerdo a las necesidades del proyecto y a la estructura organizacional del equipo del proyecto (Banco/Ejecutor). / 2. La plantilla ha sido desarrollada sobre la base del ciclo del proyecto (inicio, planificacion, ejecucion, seguimiento y cierre), utilizando el calendario para Colombia que incluye todos los feriados en el periodo 2014-2018, con el supuesto de un proyecto cuya preparacion incio el 2 de enero de 2014 y cuenta con un plazo de ejecucion de 5 anos. / 3. Es importante precisar que el MSproject utiliza por naturaleza "dias habiles", por tanto, si se requieren dias calendario se deben identificar con "edays". / 4. Si bien en el Msprojecto el proyecto incia con la mision de identificacion y termina con el plazo final de desembolso para el proyectos, esta plantilla incluyo los tiempos adicionales antes y despues del periodo anteriomente mencionado, teniendo en cuenta las gestiones presupuestales para el primer ano de ejecucion del programa y los 120 dias calendario para la presentacion de los estados financieros finales. / 5. Las duraciones/tiempos son estimadas. Para las adquisiciones con la excepcion de los tiempos minimos requeridos por el Banco para recibo de expresiones de interes (consutoria) y para la preparacion de ofertas y/o propuestas, deben ser validadas por cada ejecutor con tiempos reales. / 6. Se ha tomado como plazo para alcanzar la elegibilidad del proyecto 121 dias que corresponde al promedio de dias para Colombia, sin embargo, el plazo contractual es de 180 dias. / 7. Con excepcion de las actividades correspondientes a las clausulas contractuales que tiene fechas fijas de cumplimiento (POA, informes semestrales, informes financieros auditados, evaluaciones intermedia y final), todas las demas actividades cuentan con actividades predecesoras por lo cual sus fechas se ajustaran de acuerdo a las duraciones reales de cada actividad. / 8. Se han creado algunos "Hitos", sin embargo, en cada proyecto es factible la creacion de los "hitos" necesarios para faciliat su seguimiento. / 9. La plantilla contiene para cada actividad las columnas de inicio, fin y duracion estimados. Para realizar el seguimiento del proyecto se han adicionado las columnas de incio, fin y duracion actuales, asi como tambien las de costo (planificacion) y costo actual (contratado). / 10. Para realizar el seguimiento se debe iniciar con la inclusion de las fechas reales para cada actividad en las columnas anteriormente mencionadas y automaticamente el MSproject indicara el procentaje completado de las actividades del cronograma (columna incluida). / 11. Para realizar seguimiento de un determinado periodo de ejecucion, se puede utiizar la siguiente ruta: View/No Highlight/Date Range

## Calendars

- Calendario Project Colombia 2014 - 2018: Mon-Fri 09:00-13:00, 14:00-18:00; Sat-Sun off. Exceptions (off unless hours are given): 2015-03-23 (feriado), 2015-04-02 to 2015-04-03 (feriado), 2015-05-01 (feriado), 2015-05-18 (feriado), 2015-06-08 (feriado), 2015-06-15 (feriado), 2015-06-29 (feriado), 2015-07-20 (feriado), 2015-08-07 (feriado), 2015-08-17 (feriado), 2015-10-12 (feriado), 2015-11-02 (feriado), 2015-11-16 (feriado), 2015-12-08 (feriado), 2015-12-25 (feriado), 2016-01-01 (feriado), 2016-01-11 (feriado), 2016-03-21 (feriado), 2016-03-24 to 2016-03-25 (feriados), 2016-05-09 (feriado), 2016-05-30 (feriado), 2016-06-06 (feriado), 2016-07-04 (feriado), 2016-07-20 (feriado), 2016-08-15 (feriado), 2016-10-17 (feriado), 2016-11-07 (feriado), 2016-11-14 (feriado), 2016-12-08 (feriado), 2017-01-09 (feriado), 2017-03-20 (feriado), 2017-04-13 to 2017-04-14 (feriados), 2017-05-01 (feriado), 2017-05-29 (feriado), 2017-06-19 (feriado), 2017-06-26 (feriado), 2017-07-03 (feriado), 2017-07-20 (feriado), 2017-08-07 (feriado), 2017-08-21 (feriado), 2017-10-16 (feriado), 2017-11-06 (feriado), 2017-11-13 (feriado), 2017-12-08 (feriado), 2017-12-25 (feriado), 2018-01-01 (feriado), 2018-01-08 (feriado), 2018-03-19 (feriado), 2018-03-29 to 2018-03-30 (feriados), 2018-05-01 (feriado), 2018-05-14 (feriado), 2018-06-04 (feriado), 2018-06-11 (feriado), 2018-07-02 (feriado), 2018-07-20 (feriado), 2018-08-07 (feriado), 2018-08-20 (feriado), 2018-10-15 (feriado), 2018-11-05 (feriado), 2018-11-12 (feriado), 2018-12-25 (feriado).

## Resources

| Resource |
| --- |
| Unidad de Planeación - Sala Administrativa |
| DNP |
| Unidad de Planeación - Unidad Ejecutora |
| Unidad de Planeación del Ejecutor |
| BID |
| GdC |
| BID - GdC |
| BID-GdC |
| OE |
| BID-OE |
| SGFTrib |
| SGRFin |
| UEP |
| GdC (DNP y Ejecutor) |
| GdC (MHCP |
| DNP y Ejecutor) |
| BID y GdC (MHCP |
| GdC (MHCP) |
| GdC (MHCP y Ejecutor) |
| GdC (Ejecutor) |
| BID - GdC (Ejecutor) |
| GdC ( Ejecutor y MHCP) |
| G \dC (Ejecutor) |
| BID-GdC (Ejecutor) |
| Ejecutor |

## Schedule

| ID | WBS | Task | Type | Duration | Start | Finish | Predecessors | Baseline 1 start | Baseline 1 finish | Total slack | Free slack | Resources | Work |
| --- | --- | --- | --- | --- | --- | --- | --- | --- | --- | --- | --- | --- | --- |
| 1 | 1 | **INICIO** |  | 120d | 2015-02-15 | 2015-08-14 |  | 2015-02-15 | 2015-08-14 | 0d |  |  | 1328h |
| 2 | 1.1 | **Preparacion y Aprobación** |  | 86d | 2015-02-15 | 2015-06-24 |  | 2015-02-15 | 2015-06-24 | 0d |  |  | 928h |
| 3 | 1.1.1 | PP en ERM aprobado | milestone | 0d | 2015-02-15 | 2015-02-15 |  | 2015-02-15 | 2015-02-15 | 0d |  |  |  |
| 4 | 1.1.2 | Aprobar PP por Vicepresidencia de Sectores VPS y Representante de País |  | 1w | 2015-02-16 | 2015-02-20 | 3 | 2015-02-16 | 2015-02-20 | 1481d |  | BID | 40h |
| 5 | 1.1.3 | Realizar Misión de Orientación |  | 1w | 2015-02-16 | 2015-02-20 | 3 | 2015-02-16 | 2015-02-20 | 0d |  | BID - GdC | 40h |
| 6 | 1.1.4 | Elaborar la Propuesta de Desarrollo de la Operación (POD) |  | 5w | 2015-02-23 | 2015-03-30 | 5 | 2015-02-23 | 2015-03-30 | 0d |  | BID | 200h |
| 7 | 1.1.5 | Elaborar documento para obtener concepto favorable en el Consejo Nacional de Política Económica y Social (CONPES) |  | 1w | 2015-03-31 | 2015-04-08 | 6 | 2015-03-31 | 2015-04-08 | 1436d | 0d | GdC (DNP y Ejecutor) | 40h |
| 8 | 1.1.6 | Aprobar documento CONPES en la Sesion del Consejo de Ministros |  | 1w | 2015-04-09 | 2015-04-15 | 7 | 2015-04-09 | 2015-04-15 | 1436d | 0d | GdC (DNP y Ejecutor) | 40h |
| 9 | 1.1.7 | Concepto favorable previo de la Comision Interparlamentaria de Credito Publico para continuar el tramite el prestamo |  | 2w | 2015-04-16 | 2015-04-29 | 8 | 2015-04-16 | 2015-04-29 | 1436d |  | GdC (MHCP; DNP y Ejecutor) | 160h |
| 10 | 1.1.8 | Distribuir el POD para Aprobacion en Reunion de Presentacion ante QRR |  | 2w | 2015-03-31 | 2015-04-15 | 6 | 2015-03-31 | 2015-04-15 | 0d |  | BID | 80h |
| 11 | 1.1.9 | Aprobar POD por OPC |  | 2w | 2015-04-16 | 2015-04-29 | 10 | 2015-04-16 | 2015-04-29 | 0d |  |  |  |
| 12 | 1.1.10 | Elaborar documento Proyecto de Propuesta de Préstamo (DPL) |  | 2w | 2015-04-30 | 2015-05-14 | 11 | 2015-04-30 | 2015-05-14 | 0d |  | BID | 80h |
| 13 | 1.1.11 | Negociar Propuesta de Prestamo |  | 1w | 2015-05-15 | 2015-05-22 | 12 | 2015-05-15 | 2015-05-22 | 0d |  | BID y GdC (MHCP; DNP y Ejecutor) | 80h |
| 14 | 1.1.12 | Acta de Negociacion | milestone | 0d | 2015-05-22 | 2015-05-22 | 13 | 2015-05-22 | 2015-05-22 | 0d |  |  |  |
| 15 | 1.1.13 | Entrega Propuesta de Préstamo a Secretaria del Banco (SEC) |  | 4w | 2015-05-25 | 2015-06-23 | 14 | 2015-05-25 | 2015-06-23 | 0d |  | BID | 160h |
| 16 | 1.1.14 | Operación aprobada por el Directorio del Banco |  | 1d | 2015-06-24 | 2015-06-24 | 15 | 2015-06-24 | 2015-06-24 | 0d |  | BID | 8h |
| 17 | 1.2 | **Firma Contrato de Préstamo** |  | 34d | 2015-06-25 | 2015-08-14 |  | 2015-06-25 | 2015-08-14 | 0d |  |  | 400h |
| 18 | 1.2.1 | Concepto favorable definitivo de la Comision Interparlamentaria de Credito Publico para suscribir prestamo |  | 4w | 2015-06-25 | 2015-07-24 | 16 | 2015-06-25 | 2015-07-24 | 0d |  | GdC (MHCP; DNP y Ejecutor) | 320h |
| 19 | 1.2.2 | Obtener la Resolucion Juridica del MHCP |  | 1w | 2015-07-27 | 2015-07-31 | 18 | 2015-07-27 | 2015-07-31 | 9d |  | GdC (MHCP) | 40h |
| 20 | 1.2.3 | Oficio de autorizacion de firmas por parte del GdC para suscribir el Contrato de Prestamo |  | 1w | 2015-08-10 | 2015-08-14 | 18 | 2015-08-10 | 2015-08-14 | 0d |  | GdC (MHCP) | 40h |
| 21 | 1.2.4 | Contrato de Préstamo firmado | milestone | 0d | 2015-08-14 | 2015-08-14 | 16, 19, 20 | 2015-08-14 | 2015-08-14 | 0d |  | BID - GdC |  |
| 22 | 2 | **PLANIFICACION** |  | 1341d | 2015-02-15 | 2020-07-06 |  | 2015-02-15 | 2020-07-06 | 120d |  |  | 15392h |
| 23 | 2.1 | **Herramientas de Gestion de Proyectos** |  | 90d | 2015-04-30 | 2015-09-14 |  | 2015-04-30 | 2015-09-14 | 1346d |  |  | 800h |
| 24 | 2.1.1 | Verificar/Ajustar metas de la Matriz de Resultados |  | 4w | 2015-08-18 | 2015-09-14 | 11, 21 | 2015-08-18 | 2015-09-14 | 1346d |  | BID-GdC | 160h |
| 25 | 2.1.2 | Elaborar/Actualizar el Programa de Ejecución Plurianual -PEP |  | 4w | 2015-08-18 | 2015-09-14 | 11, 21 | 2015-08-18 | 2015-09-14 | 1346d |  | GdC (Ejecutor) | 160h |
| 26 | 2.1.3 | Elaborar/Actualizar el Programa Operativo de Ejecución (18 meses) - POA |  | 4w | 2015-04-30 | 2015-05-29 | 11 | 2015-04-30 | 2015-05-29 | 1416d |  | GdC (Ejecutor) | 160h |
| 27 | 2.1.4 | Elaborar/Actualizar Plan de Adquisiciones (18 meses) |  | 4w | 2015-04-30 | 2015-05-29 | 11 | 2015-04-30 | 2015-05-29 | 1416d |  | GdC (Ejecutor) | 160h |
| 28 | 2.1.5 | Elaborar/Actualizar el Flujo de Inversiones y el Plan de Desembolsos |  | 4w | 2015-04-30 | 2015-05-29 | 11 | 2015-04-30 | 2015-05-29 | 1416d |  | GdC (Ejecutor) | 160h |

| ID | WBS | Task | Type | Duration | Start | Finish | Predecessors | Baseline 1 start | Baseline 1 finish | Total slack | Free slack | Resources | Work |
| --- | --- | --- | --- | --- | --- | --- | --- | --- | --- | --- | --- | --- | --- |
| 29 | 2.2 | **Elaborar/Actualizar Gestión de Riesgos del Proyecto -GRP** |  | 1002d | 2015-04-30 | 2019-05-28 |  | 2015-04-30 | 2019-05-28 | 407d |  | BID-GdC (Ejecutor) | 8016h |
| 30 | 2.2.1 | Elaboracion del GRP Inicial |  | 4w | 2015-04-30 | 2015-05-29 | 11 | 2015-04-30 | 2015-05-29 | 407d | 0d |  |  |
| 31 | 2.2.2 | **Actualizacion Anual del GRP (Taller y Plan de Accion)** |  | 739d | 2016-05-28 | 2019-05-28 |  | 2016-05-28 | 2019-05-28 | 407d |  |  |  |
| 32 | 2.2.2.1 | Taller GRP2015 | milestone | 0d | 2016-05-28 | 2016-05-28 | 30FS+365ed | 2016-05-28 | 2016-05-28 | 407d | 0d |  |  |
| 33 | 2.2.2.2 | Taller GRP 2016 | milestone | 0d | 2017-05-28 | 2017-05-28 | 32FS+365ed | 2017-05-28 | 2017-05-28 | 406d | 0d |  |  |
| 34 | 2.2.2.3 | Taller GRP 2017 | milestone | 0d | 2018-05-28 | 2018-05-28 | 33FS+365ed | 2018-05-28 | 2018-05-28 | 424d | 0d |  |  |
| 35 | 2.2.2.4 | Taller GRP 2018 | milestone | 0d | 2019-05-28 | 2019-05-28 | 34FS+365ed | 2019-05-28 | 2019-05-28 | 434d |  |  |  |
| 36 | 2.3 | **Elegibilidad** |  | 5d | 2015-08-18 | 2015-08-24 |  | 2015-08-18 | 2015-08-24 | 0d |  |  | 280h |
| 37 | 2.3.1 | **Condiciones previas al primer desembolso** |  | 5d | 2015-08-18 | 2015-08-24 |  | 2015-08-18 | 2015-08-24 | 1361d |  |  | 200h |
| 38 | 2.3.1.1 | (a) Que el Banco haya recibido uno o más informes jurídicos |  | 1w | 2015-08-18 | 2015-08-24 | 21 | 2015-08-18 | 2015-08-24 | 1361d |  | GdC (MHCP y Ejecutor) | 40h |
| 39 | 2.3.1.2 | (b) Que el Prestatario, por sí o por medio del Organismo Ejecutor, en su caso, haya designado uno o más funcionarios como representantes ante el BID para la ejecucion del prestamo |  | 1w | 2015-08-18 | 2015-08-24 | 21 | 2015-08-18 | 2015-08-24 | 1361d |  | GdC (Ejecutor) | 40h |
| 40 | 2.3.1.3 | © Que el Prestatario, por sí o por medio del Organismo Ejecutor, en su caso, haya demostrado al Banco que se han asignado los recursos suficientes para atender, por lo menos durante el primer año calendario, la ejecución del Proyecto |  | 1w | 2015-08-18 | 2015-08-24 | 21 | 2015-08-18 | 2015-08-24 | 1361d |  | GdC (Ejecutor) | 40h |
| 41 | 2.3.1.4 | (d) Que el Prestatario, por sí o por medio del Organismo Ejecutor, en su caso, haya presentado al Banco un informe inicial |  | 1w | 2015-08-18 | 2015-08-24 | 21 | 2015-08-18 | 2015-08-24 | 1361d |  | GdC (Ejecutor) | 40h |
| 42 | 2.3.1.5 | e) Que el Prestatario o el Organismo Ejecutor haya demostrado al Banco que cuenta con un sistema de información financiera y una estructura de control interno adecuados para los propósitos indicados en este Contrato. |  | 1w | 2015-08-18 | 2015-08-24 | 21 | 2015-08-18 | 2015-08-24 | 1361d |  | GdC (Ejecutor) | 40h |
| 43 | 2.3.2 | **Condiciones especiales previas al primer desembolso (Adaptar a cada contrato de prestamo)** |  | 5d | 2015-08-18 | 2015-08-24 |  | 2015-08-18 | 2015-08-24 | 0d |  |  | 80h |
| 44 | 2.3.2.1 | (a) Que el Organismo Ejecutor haya constituido un Equipo de implementación del Programa (EIP) y se haya designado al Coordinador y al personal mínimo necesario para la adecuada ejecución del Programa, de conformidad con TdeRef debidamente aprobados |  | 1w | 2015-08-18 | 2015-08-24 | 21 | 2015-08-18 | 2015-08-24 | 1361d |  | GdC (Ejecutor) | 40h |
| 45 | 2.3.2.2 | (b) Que se haya aprobado el Manual Operativo del Programa, de conformidad con los términos previamente acordados con el Banco |  | 1w | 2015-08-18 | 2015-08-24 | 21 | 2015-08-18 | 2015-08-24 | 0d |  | GdC (Ejecutor) | 40h |
| 46 | 2.3.3 | Elegibilidad Total para Desembolsos cumplida | milestone | 0ed | 2015-08-24 | 2015-08-24 | 45 | 2015-08-24 | 2015-08-24 | 1.88d | 0d | BID - GdC (Ejecutor) |  |
| 47 | 2.4 | **Gestion Presupuestal y de Desembolsos** |  | 1341d | 2015-02-15 | 2020-07-06 |  | 2015-02-15 | 2020-07-06 | 145d |  |  | 6296h |
| 48 | 2.4.1 | **Trámite Presupuestal** |  | 894d | 2015-02-15 | 2018-10-12 |  | 2015-02-15 | 2018-10-12 | 569d |  |  | 5416h |
| 49 | 2.4.1.1 | **Presupuesto 2015** |  | 2d | 2015-08-25 | 2015-08-26 |  | 2015-08-25 | 2015-08-26 | 1359d |  |  |  |
| 50 | 2.4.1.1.1 | Solicitar Certificado de Disponibilidad Presupuestal |  | 2d | 2015-08-25 | 2015-08-26 | 46 | 2015-08-25 | 2015-08-26 | 1359d |  |  |  |
| 51 | 2.4.1.2 | **Presupuesto 2016** |  | 162d | 2015-02-15 | 2015-10-15 |  | 2015-02-15 | 2015-10-15 | 569d |  |  | 1240h |
| 52 | 2.4.1.2.1 | Anteproyecto de Presupuesto (Unidad de Planeación del Ejecutor) | milestone | 0d | 2015-02-15 | 2015-02-15 |  | 2015-02-15 | 2015-02-15 | 569d | 0d | OE |  |
| 53 | 2.4.1.2.2 | Consolidación anteproyecto de presupuesto (DNP) |  | 4w | 2015-02-16 | 2015-03-13 | 52 | 2015-02-16 | 2015-03-13 | 1324d | 0d | GdC | 160h |
| 54 | 2.4.1.2.3 | Generación cuota de inversión (DNP) |  | 2w | 2015-03-16 | 2015-03-30 | 53 | 2015-03-16 | 2015-03-30 | 1324d | 0d | GdC | 80h |
| 55 | 2.4.1.2.4 | Acuerdo de Presupuesto (Unidad de Planeación del Ejecutor) |  | 4mo | 2015-03-31 | 2015-07-30 | 54 | 2015-03-31 | 2015-07-30 | 1324d | 0d | OE | 640h |
| 56 | 2.4.1.2.5 | Negociar Marco de Gasto de Mediano Plazo - MGMP (Unidad de Planeación del Ejecutor) |  | 2mo | 2015-07-31 | 2015-09-28 | 55 | 2015-07-31 | 2015-09-28 | 1324d | 0d | OE | 320h |
| 57 | 2.4.1.2.6 | Realizar desagregacion presupuestal del prestamo y solicitar desagregación en el SIIF al MHCP |  | 7d | 2015-09-29 | 2015-10-07 | 56 | 2015-09-29 | 2015-10-07 | 1324d | 0d |  |  |
| 58 | 2.4.1.2.7 | Solicitar del Certificado de Disponibilidad Presupuestal |  | 5d | 2015-10-08 | 2015-10-15 | 57 | 2015-10-08 | 2015-10-15 | 1324d |  | BID | 40h |

Notes:
- 37: La CGN se debe comprometer a cumplir condiciones previas en la semana siguiente a la firma del contrato de prestamo.
- 43: La CGN se debe comprometer a cumplir las condiciones esepciales en la semana siguiente a la firma del contrato.

| ID | WBS | Task | Type | Duration | Start | Finish | Predecessors | Baseline 1 start | Baseline 1 finish | Total slack | Free slack | Resources | Work |
| --- | --- | --- | --- | --- | --- | --- | --- | --- | --- | --- | --- | --- | --- |
| 59 | 2.4.1.3 | **Presupuesto 2017** |  | 162d | 2016-02-15 | 2016-10-10 |  | 2016-02-15 | 2016-10-10 | 568d |  |  | 1392h |
| 60 | 2.4.1.3.1 | Anteproyecto de Presupuesto (Unidad de Planeación del Ejecutor) | milestone | 0d | 2016-02-15 | 2016-02-15 | 52FS+365ed | 2016-02-15 | 2016-02-15 | 568d | 0d | OE |  |
| 61 | 2.4.1.3.2 | Consolidación anteproyecto de presupuesto (DNP) |  | 4w | 2016-02-15 | 2016-03-11 | 60 | 2016-02-15 | 2016-03-11 | 1082d | 0d | GdC | 160h |
| 62 | 2.4.1.3.3 | Generación cuota de inversión (DNP) |  | 2w | 2016-03-14 | 2016-03-30 | 61 | 2016-03-14 | 2016-03-30 | 1082d | 0d | GdC | 80h |
| 63 | 2.4.1.3.4 | Acuerdo de Presupuesto (Unidad de Planeación del Ejecutor) |  | 4mo | 2016-03-31 | 2016-07-27 | 62 | 2016-03-31 | 2016-07-27 | 1082d | 0d | OE | 640h |
| 64 | 2.4.1.3.5 | Marco de Gasto de Mediano Plazo - MGMP (Unidad de Planeación del Ejecutor) |  | 2mo | 2016-07-28 | 2016-09-22 | 63 | 2016-07-28 | 2016-09-22 | 1082d | 0d | OE | 320h |
| 65 | 2.4.1.3.6 | Realizar desagregacion presupuestal del prestamo y solicitar desagregación en el SIIF al MHCP |  | 7d | 2016-09-23 | 2016-10-03 | 64 | 2016-09-23 | 2016-10-03 | 1082d | 0d | SGFTrib; SGRFin | 112h |
| 66 | 2.4.1.3.7 | Solicitar del Certificado de Disponibilidad Presupuestal |  | 5d | 2016-10-04 | 2016-10-10 | 65 | 2016-10-04 | 2016-10-10 | 1082d |  | SGFTrib; SGRFin | 80h |
| 67 | 2.4.1.4 | **Presupuesto 2018** |  | 162d | 2017-02-14 | 2017-10-12 |  | 2017-02-14 | 2017-10-12 | 574d |  |  | 1392h |
| 68 | 2.4.1.4.1 | Anteproyecto de Presupuesto (Unidad de Planeación del Ejecutor) | milestone | 0d | 2017-02-14 | 2017-02-14 | 60FS+365ed | 2017-02-14 | 2017-02-14 | 574d | 0d | OE |  |
| 69 | 2.4.1.4.2 | Consolidación anteproyecto de presupuesto (DNP) |  | 4w | 2017-02-14 | 2017-03-13 | 68 | 2017-02-14 | 2017-03-13 | 835d | 0d | GdC | 160h |
| 70 | 2.4.1.4.3 | Generación cuota de inversión (DNP) |  | 2w | 2017-03-14 | 2017-03-28 | 69 | 2017-03-14 | 2017-03-28 | 835d | 0d | GdC | 80h |
| 71 | 2.4.1.4.4 | Acuerdo de Presupuesto (Unidad de Planeación del Ejecutor) |  | 4mo | 2017-03-29 | 2017-07-28 | 70 | 2017-03-29 | 2017-07-28 | 835d | 0d | OE | 640h |
| 72 | 2.4.1.4.5 | Marco de Gasto de Mediano Plazo - MGMP (Unidad de Planeación del Ejecutor) |  | 2mo | 2017-07-31 | 2017-09-26 | 71 | 2017-07-31 | 2017-09-26 | 835d | 0d | OE | 320h |
| 73 | 2.4.1.4.6 | Realizar desagregacion presupuestal del prestamo y solicitar desagregación en el SIIF al MHCP |  | 7d | 2017-09-27 | 2017-10-05 | 72 | 2017-09-27 | 2017-10-05 | 835d | 0d | SGFTrib; SGRFin | 112h |
| 74 | 2.4.1.4.7 | Solicitar del Certificado de Disponibilidad Presupuestal |  | 5d | 2017-10-06 | 2017-10-12 | 73 | 2017-10-06 | 2017-10-12 | 835d |  | SGFTrib; SGRFin | 80h |
| 75 | 2.4.1.5 | **Presupuesto 2019** |  | 162d | 2018-02-14 | 2018-10-12 |  | 2018-02-14 | 2018-10-12 | 592d |  |  | 1392h |
| 76 | 2.4.1.5.1 | Anteproyecto de Presupuesto (Unidad de Planeación del Ejecutor) | milestone | 0d | 2018-02-14 | 2018-02-14 | 68FS+365ed | 2018-02-14 | 2018-02-14 | 592d | 0d | OE |  |
| 77 | 2.4.1.5.2 | Consolidación anteproyecto de presupuesto (DNP) |  | 4w | 2018-02-14 | 2018-03-13 | 76 | 2018-02-14 | 2018-03-13 | 592d | 0d | GdC | 160h |
| 78 | 2.4.1.5.3 | Generación cuota de inversión (DNP) |  | 2w | 2018-03-14 | 2018-03-28 | 77 | 2018-03-14 | 2018-03-28 | 592d | 0d | GdC | 80h |
| 79 | 2.4.1.5.4 | Acuerdo de Presupuesto (Unidad de Planeación del Ejecutor) |  | 4mo | 2018-04-02 | 2018-07-30 | 78 | 2018-04-02 | 2018-07-30 | 592d | 0d | OE | 640h |
| 80 | 2.4.1.5.5 | Marco de Gasto de Mediano Plazo - MGMP (Unidad de Planeación del Ejecutor) |  | 2mo | 2018-07-31 | 2018-09-26 | 79 | 2018-07-31 | 2018-09-26 | 592d | 0d | OE | 320h |
| 81 | 2.4.1.5.6 | Realizar desagregacion presupuestal del prestamo y solicitar desagregación en el SIIF al MHCP |  | 7d | 2018-09-27 | 2018-10-05 | 80 | 2018-09-27 | 2018-10-05 | 592d | 0d | SGFTrib; SGRFin | 112h |
| 82 | 2.4.1.5.7 | Solicitar del Certificado de Disponibilidad Presupuestal |  | 5d | 2018-10-08 | 2018-10-12 | 81 | 2018-10-08 | 2018-10-12 | 592d |  | SGFTrib; SGRFin | 80h |

| ID | WBS | Task | Type | Duration | Start | Finish | Predecessors | Baseline 1 start | Baseline 1 finish | Total slack | Free slack | Constraint | Resources | Work |
| --- | --- | --- | --- | --- | --- | --- | --- | --- | --- | --- | --- | --- | --- | --- |
| 83 | 2.4.2 | **Flujo y solicitud de desembolsos** |  | 1216d | 2015-08-25 | 2020-07-06 |  | 2015-08-25 | 2020-07-06 | 139d |  |  |  | 880h |
| 84 | 2.4.2.1 | Solicitud y Primer desembolso 2015 |  | 4w | 2015-08-25 | 2015-09-21 | 46 | 2015-08-25 | 2015-09-21 | 139d | 0d |  | GdC ( Ejecutor y MHCP) | 160h |
| 85 | 2.4.2.2 | Primer Desembolso realizado | milestone | 0d | 2015-09-21 | 2015-09-21 | 84 | 2015-09-21 | 2015-09-21 | 1341d |  |  |  |  |
| 86 | 2.4.2.3 | Justificacion primer desembolso 2015, solicitud y segundo desembolso 2015 |  | 2w | 2016-03-22 | 2016-04-06 | 84FS+180ed | 2016-03-22 | 2016-04-06 | 139d | 0d |  | GdC ( Ejecutor y MHCP) | 80h |
| 87 | 2.4.2.4 | Justificacion Segundo desembolso 2015, solicitud y primer desembolso 2016 |  | 2w | 2016-10-04 | 2016-10-18 | 86FS+180ed | 2016-10-04 | 2016-10-18 | 138d | 0d |  | GdC ( Ejecutor y MHCP) | 80h |
| 88 | 2.4.2.5 | Justificacion primer desembolso 2016, solicitud y segundo desembolso 2016 |  | 2w | 2017-04-17 | 2017-04-28 | 87FS+180ed | 2017-04-17 | 2017-04-28 | 136d | 0d |  | GdC ( Ejecutor y MHCP) | 80h |
| 89 | 2.4.2.6 | Justificacion segundo desembolso 2016, solicitud y primer desembolso 2017 |  | 2w | 2017-10-26 | 2017-11-09 | 88FS+180ed | 2017-10-26 | 2017-11-09 | 136d | 0d |  | GdC ( Ejecutor y MHCP) | 80h |
| 90 | 2.4.2.7 | Justificacion primer desembolso 2017, solicitud y segundo desembolso 2017 |  | 2w | 2018-05-09 | 2018-05-23 | 89FS+180ed | 2018-05-09 | 2018-05-23 | 137d | 0d |  | GdC ( Ejecutor y MHCP) | 80h |
| 91 | 2.4.2.8 | Justificacion segundo desembolso 2017, solicitud y primer desembolso 2018 |  | 2w | 2018-11-20 | 2018-12-03 | 90FS+180ed | 2018-11-20 | 2018-12-03 | 145d | 1d |  | GdC ( Ejecutor y MHCP) | 80h |
| 92 | 2.4.2.9 | Justificacion primer desembolso 2018, solicitud y segundo desembolso 2018 |  | 2w | 2019-06-03 | 2019-06-14 | 91FS+180ed | 2019-06-03 | 2019-06-14 | 145d | 0d |  | GdC ( Ejecutor y MHCP) | 80h |
| 93 | 2.4.2.10 | Justificacion segundo desembolso 2018, solicitud y primer desembolso 2019 |  | 2w | 2019-12-12 | 2019-12-25 | 92FS+180ed | 2019-12-12 | 2019-12-25 | 145d | 0d |  | GdC ( Ejecutor y MHCP) | 80h |
| 94 | 2.4.2.11 | Justificacion primer desembolso 2019 |  | 2w | 2020-06-23 | 2020-07-06 | 93FS+180ed | 2020-06-23 | 2020-07-06 | 145d |  |  | GdC ( Ejecutor y MHCP) | 80h |
| 95 | 3 | **EJECUCIÓN** |  | 1486d? | 2015-02-16 | 2021-01-25 |  | 2014-04-02 | 2020-05-07 | 0d |  |  |  | 160h |
| 96 | 3.1 | **Condiciones especiales de ejecución (Colocar las que correspondan en cada caso 1, 2, 3, …., n)** |  | 5d | 2015-08-18 | 2015-08-24 |  | 2015-08-18 | 2015-08-24 | 1361d |  |  |  | 160h |
| 97 | 3.1.1 | 1. |  | 1w | 2015-08-18 | 2015-08-24 | 21 | 2015-08-18 | 2015-08-24 | 1361d |  |  | Ejecutor | 40h |
| 98 | 3.1.2 | 2. |  | 1w | 2015-08-18 | 2015-08-24 | 21 | 2015-08-18 | 2015-08-24 | 1361d |  |  | Ejecutor | 40h |
| 99 | 3.1.3 | 3. |  | 1w | 2015-08-18 | 2015-08-24 | 21 | 2015-08-18 | 2015-08-24 | 1361d |  |  | Ejecutor | 40h |
| 100 | 3.1.4 | n. |  | 1w | 2015-08-18 | 2015-08-24 | 21 | 2015-08-18 | 2015-08-24 | 1361d |  |  | Ejecutor | 40h |
| 101 | 3.2 | Plazo para Desembolsos (4 anos) |  | 1820ed | 2015-08-14 | 2020-08-07 | 21 | 2015-08-14 | 2019-08-13 | 153d | 0d |  |  |  |
| 102 | 3.3 | Reunión de inicio de ejecución (Taller de Arranque) |  | 2d | 2015-08-25 | 2015-08-26 | 46 | 2015-08-25 | 2015-08-26 | 1359d |  |  |  |  |
| 103 | 3.4 | **Auditoría Financiera Contable** |  | 1361d | 2015-08-25 | 2021-01-25 |  | 2014-04-02 | 2020-05-07 | 0d |  |  |  |  |
| 104 | 3.4.1 | **Contratacion Metodo Seleccion Basada en Calidad y Costo - SBCC** |  | 1361d | 2015-08-25 | 2021-01-25 |  | 2014-04-02 | 2020-05-07 | 0d |  |  |  |  |
| 105 | 3.4.1.1 | **Precontractual** |  | 101d | 2015-08-25 | 2016-01-21 |  | 2014-04-02 | 2014-09-01 | 0d |  |  |  |  |
| 106 | 3.4.1.1.1 | Elaborar TdR |  | 15d | 2015-08-25 | 2015-09-14 | 46 | 2014-04-02 | 2014-04-24 | 0d |  | start no earlier than 2014-04-02 |  |  |
| 107 | 3.4.1.1.2 | Preparar documento de solicitud de propuestas |  | 10d | 2015-09-15 | 2015-09-28 | 106 | 2014-04-25 | 2014-05-09 | 0d |  |  |  |  |
| 108 | 3.4.1.1.3 | No objeción del BID a TdR y documento de SP |  | 5d | 2015-09-29 | 2015-10-05 | 107 | 2014-05-12 | 2014-05-16 | 0d |  |  |  |  |
| 109 | 3.4.1.1.4 | Enviar invitación a presentar propuesta |  | 2d | 2015-10-06 | 2015-10-07 | 108 | 2014-05-19 | 2014-05-20 | 0d |  |  |  |  |
| 110 | 3.4.1.1.5 | Frimas auditoras elaboran propuestas |  | 4w | 2015-10-08 | 2015-11-06 | 109 | 2014-05-21 | 2014-06-18 | 0d |  |  |  |  |
| 111 | 3.4.1.1.6 | Evaluación Técnica |  | 10d | 2015-11-09 | 2015-11-23 | 110 | 2014-06-19 | 2014-07-04 | 0d |  |  |  |  |
| 112 | 3.4.1.1.7 | No objeción del BID a evaluación técnica |  | 5d | 2015-11-24 | 2015-11-30 | 111 | 2014-07-07 | 2014-07-11 | 0d |  |  |  |  |
| 113 | 3.4.1.1.8 | Notificación firmas resultados evaluación técnica |  | 2d | 2015-12-01 | 2015-12-02 | 112 | 2014-07-14 | 2014-07-15 | 1292d |  |  |  |  |
| 114 | 3.4.1.1.9 | Elaboración evaluación Combinada (técnica y precio) |  | 2d | 2015-12-01 | 2015-12-02 | 112 | 2014-07-14 | 2014-07-15 | 0d |  |  |  |  |
| 115 | 3.4.1.1.10 | No objeción del BID evaluación combinada |  | 5d | 2015-12-03 | 2015-12-10 | 114 | 2014-07-16 | 2014-07-22 | 0d |  |  |  |  |
| 116 | 3.4.1.1.11 | Notificación de adjudicación |  | 2d | 2015-12-11 | 2015-12-14 | 115 | 2014-07-23 | 2014-07-24 | 0d |  |  |  |  |
| 117 | 3.4.1.1.12 | Negociación del contrato |  | 10d | 2015-12-15 | 2015-12-29 | 116 | 2014-07-25 | 2014-08-08 | 0d |  |  |  |  |
| 118 | 3.4.1.1.13 | No objeción del BID al borrador de contrato negociado |  | 5d | 2015-12-30 | 2016-01-06 | 117 | 2014-08-11 | 2014-08-15 | 0d |  |  |  |  |
| 119 | 3.4.1.1.14 | Firma del contrato |  | 10d | 2016-01-07 | 2016-01-21 | 118 | 2014-08-19 | 2014-09-01 | 0d |  |  |  |  |

| ID | WBS | Task | Type | Duration | Start | Finish | Predecessors | Baseline 1 start | Baseline 1 finish | Total slack | Free slack |
| --- | --- | --- | --- | --- | --- | --- | --- | --- | --- | --- | --- |
| 120 | 3.4.1.2 | **Contractual** |  | 1217d | 2016-01-26 | 2020-11-30 |  | 2014-09-06 | 2020-03-12 | 0d |  |
| 121 | 3.4.1.2.1 | Acta de inicio | milestone | 0d | 2016-01-26 | 2016-01-26 | 119FS+5ed | 2014-09-06 | 2014-09-06 | 0d |  |
| 122 | 3.4.1.2.2 | Ejecucion (No. dias calendario del plazo de ejecucion incluye 120 dias calendario despues de ultimo desembolso) |  | 1770ed | 2016-01-26 | 2020-11-30 | 121 | 2014-09-06 | 2020-03-12 | 1.88d |  |
| 123 | 3.4.1.3 | **Cierre** |  | 40d | 2020-12-01 | 2021-01-25 |  | 2020-03-13 | 2020-05-07 | 0d |  |
| 124 | 3.4.1.3.1 | Liquidacion del contrato |  | 2mo | 2020-12-01 | 2021-01-25 | 122 | 2020-03-13 | 2020-05-07 | 0d |  |
| 125 | 3.5 | **COMPONENTE 1 - Fortalecimiento de la planeación, ejecución y seguimiento de las acciones de control** |  | 1260d? | 2015-02-16 | 2020-03-13 |  | 2015-02-16 | 2019-09-27 | 226d |  |
| 126 | 3.5.1 | **Producto 1 - Sistema Estratégico de Vigilancia y Control Fiscal de Mediano Plazo Implementado** |  | 496d | 2015-02-16 | 2017-02-22 |  | 2015-02-16 | 2017-02-22 | 956d |  |
| 127 | 3.5.1.1 | **Consultoria: Disenar el Sistema Estrategico de Vigilancia y Control Fiscal (SECVF) de mediano plazo. SCC** |  | 211d | 2015-02-16 | 2015-12-29 |  | 2015-02-16 | 2015-12-29 | 956d |  |
| 128 | 3.5.1.1.1 | **Precontractual** |  | 64d | 2015-06-25 | 2015-09-28 |  | 2015-06-25 | 2015-09-28 | 870d |  |
| 129 | 3.5.1.1.1.1 | Elaboración de los TR |  | 1d | 2015-06-25 | 2015-06-25 | 16 | 2015-06-25 | 2015-06-25 | 870d | 0d |
| 130 | 3.5.1.1.1.2 | Estimado de costos y presupuesto |  | 1d | 2015-06-26 | 2015-06-26 | 129 | 2015-06-26 | 2015-06-26 | 870d | 0d |
| 131 | 3.5.1.1.1.3 | No objeción del Banco a los TR |  | 5d | 2015-06-30 | 2015-07-06 | 130 | 2015-06-30 | 2015-07-06 | 870d | 0d |
| 132 | 3.5.1.1.1.4 | Elaboración del Aviso Específico de Adquisiciones (AEA) solicitando Expresiones de Interés (EI) |  | 2d | 2015-07-07 | 2015-07-08 | 131 | 2015-07-07 | 2015-07-08 | 870d | 0d |
| 133 | 3.5.1.1.1.5 | No Objeción del Banco al AEA |  | 5d | 2015-07-09 | 2015-07-15 | 132 | 2015-07-09 | 2015-07-15 | 870d | 0d |
| 134 | 3.5.1.1.1.6 | Publicación del AEA en SECOP |  | 2d | 2015-07-16 | 2015-07-17 | 133 | 2015-07-16 | 2015-07-17 | 870d | 0d |
| 135 | 3.5.1.1.1.7 | Recepción de Expresiones de Interés | milestone | 0d | 2015-07-31 | 2015-07-31 | 134FS+14ed | 2015-07-31 | 2015-07-31 | 871d | 0d |
| 136 | 3.5.1.1.1.8 | Evaluación de EI recibidas y conformación de lista corta ordenada por Orden de Merito |  | 5d | 2015-08-03 | 2015-08-10 | 135 | 2015-08-03 | 2015-08-10 | 871d | 0d |
| 137 | 3.5.1.1.1.9 | Elaboracion de la Solicitud de Propuestas (SP) |  | 5d | 2015-08-03 | 2015-08-10 | 135 | 2015-08-03 | 2015-08-10 | 871d | 0d |
| 138 | 3.5.1.1.1.10 | No Objeción del Banco a la lista corta rankeada y SP |  | 5d | 2015-08-11 | 2015-08-18 | 136, 137 | 2015-08-11 | 2015-08-18 | 871d | 0d |
| 139 | 3.5.1.1.1.11 | Invitación a presentar propuesta tecnica y economica solo a la Firma Consultora (FC) rankeada en 1º lugar |  | 2d | 2015-08-19 | 2015-08-20 | 138 | 2015-08-19 | 2015-08-20 | 871d | 0d |
| 140 | 3.5.1.1.1.12 | Recepción de propuesta de la FC invitada | milestone | 0d | 2015-09-03 | 2015-09-03 | 139FS+2w | 2015-09-03 | 2015-09-03 | 871d | 0d |
| 141 | 3.5.1.1.1.13 | Evaluación de la propuesta y negociación del contrato |  | 5d | 2015-09-04 | 2015-09-10 | 140 | 2015-09-04 | 2015-09-10 | 871d | 0d |
| 142 | 3.5.1.1.1.14 | No Objeción del Banco al contrato negociado y rubricado |  | 5d | 2015-09-11 | 2015-09-17 | 141 | 2015-09-11 | 2015-09-17 | 871d | 0d |
| 143 | 3.5.1.1.1.15 | Publicar el nombre del consultor al cual se le adjudicó el contrato, |  | 2d | 2015-09-18 | 2015-09-21 | 142 | 2015-09-18 | 2015-09-21 | 871d | 0d |
| 144 | 3.5.1.1.1.16 | Firma del contrato y envío del contrato al Banco para registro |  | 5d | 2015-09-22 | 2015-09-28 | 143 | 2015-09-22 | 2015-09-28 | 871d | 0d |

Notes:
- 137: Modelo Base SP bajo la modalidad SCC

| ID | WBS | Task | Type | Duration | Start | Finish | Predecessors | Baseline 1 start | Baseline 1 finish | Total slack | Free slack |
| --- | --- | --- | --- | --- | --- | --- | --- | --- | --- | --- | --- |
| 145 | 3.2.4.47 | **Contractual** |  | 61d | 2015-09-29 | 2015-12-29 |  | 2015-09-29 | 2015-12-29 | 871d |  |
| 146 | 3.2.3.3.2.1 | Acta de inicio |  | 1d | 2015-09-29 | 2015-09-29 | 144 | 2015-09-29 | 2015-09-29 | 871d | 0d |
| 147 | 3.5.1.1.2.2 | Definición del alcance del SECVF (metodologia, objetivos, metas, líneas de acción, riesgos y mecanismos de divulgacion) |  | 2mo | 2015-09-30 | 2015-11-27 | 146 | 2015-09-30 | 2015-11-27 | 871d | 0d |
| 148 | 3.5.1.1.2.3 | Definición del plan de implementacion del SEVCF |  | 1mo | 2015-11-30 | 2015-12-29 | 147 | 2015-11-30 | 2015-12-29 | 990d | 0d |
| 149 | 3.5.1.1.3 | **Cierre** |  | 80d | 2015-02-16 | 2015-06-16 |  | 2015-02-16 | 2015-06-16 | 1406d |  |
| 150 | 3.5.1.1.3.1 | Liquidacion de contrato |  | 4mo | 2015-02-16 | 2015-06-16 |  | 2015-02-16 | 2015-06-16 | 1406d |  |
| 151 | 3.5.1.2 | **Consultoria: Implementacion y divulgacion del SEVCF. SCC** |  | 285d | 2015-12-30 | 2017-02-22 |  | 2015-12-30 | 2017-02-22 | 990d |  |
| 152 | 3.5.1.2.1 | **Precontractual** |  | 83d | 2015-12-30 | 2016-04-29 |  | 2015-12-30 | 2016-04-29 | 990d |  |
| 153 | 3.5.1.2.1.1 | Elaboración de los TR |  | 10d | 2015-12-30 | 2016-01-14 | 148 | 2015-12-30 | 2016-01-14 | 990d | 0d |
| 154 | 3.5.1.2.1.2 | Estimado de costos y presupuesto |  | 5d | 2016-01-15 | 2016-01-21 | 153 | 2016-01-15 | 2016-01-21 | 990d | 0d |
| 155 | 3.5.1.2.1.3 | No objeción del Banco a los TR |  | 5d | 2016-01-22 | 2016-01-28 | 154 | 2016-01-22 | 2016-01-28 | 990d | 0d |
| 156 | 3.5.1.2.1.4 | Elaboración del Aviso Específico de Adquisiciones (AEA) solicitando Expresiones de Interés (EI) |  | 2d | 2016-01-29 | 2016-02-01 | 155 | 2016-01-29 | 2016-02-01 | 990d | 0d |
| 157 | 3.5.1.2.1.5 | No Objeción del Banco al AEA |  | 5d | 2016-02-02 | 2016-02-08 | 156 | 2016-02-02 | 2016-02-08 | 990d | 0d |
| 158 | 3.5.1.2.1.6 | Publicación del AEA en SECOP |  | 2d | 2016-02-09 | 2016-02-10 | 157 | 2016-02-09 | 2016-02-10 | 990d | 0d |
| 159 | 3.5.1.2.1.7 | Recepción de Expresiones de Interés | milestone | 0d | 2016-02-24 | 2016-02-24 | 158FS+14ed | 2016-02-24 | 2016-02-24 | 990d | 0d |
| 160 | 3.5.1.2.1.8 | Evaluación de EI recibidas y conformación de lista corta ordenada por Orden de Merito |  | 5d | 2016-02-25 | 2016-03-02 | 159 | 2016-02-25 | 2016-03-02 | 990d | 0d |
| 161 | 3.5.1.2.1.9 | Elaboracion de la Solicitud de Propuestas (SP) |  | 5d | 2016-02-25 | 2016-03-02 | 159 | 2016-02-25 | 2016-03-02 | 990d | 0d |
| 162 | 3.5.1.2.1.10 | No Objeción del Banco a la lista corta rankeada y SP |  | 5d | 2016-03-03 | 2016-03-09 | 160, 161 | 2016-03-03 | 2016-03-09 | 990d | 0d |
| 163 | 3.5.1.2.1.11 | Invitación a presentar propuesta tecnica y economica solo a la Firma Consultora (FC) rankeada en 1º lugar |  | 2d | 2016-03-10 | 2016-03-11 | 162 | 2016-03-10 | 2016-03-11 | 990d | 0d |
| 164 | 3.5.1.2.1.12 | Recepción de propuesta de la FC invitada | milestone | 0d | 2016-03-30 | 2016-03-30 | 163FS+2w | 2016-03-30 | 2016-03-30 | 990d | 0d |
| 165 | 3.5.1.2.1.13 | Evaluación de la propuesta y negociación del contrato |  | 10d | 2016-03-31 | 2016-04-13 | 164 | 2016-03-31 | 2016-04-13 | 990d | 0d |
| 166 | 3.5.1.2.1.14 | No Objeción del Banco al contrato negociado y rubricado |  | 5d | 2016-04-14 | 2016-04-20 | 165 | 2016-04-14 | 2016-04-20 | 990d | 0d |
| 167 | 3.5.1.2.1.15 | Publicar el nombre del consultor al cual se le adjudicó el contrato, |  | 2d | 2016-04-21 | 2016-04-22 | 166 | 2016-04-21 | 2016-04-22 | 990d | 0d |
| 168 | 3.5.1.2.1.16 | Firma del contrato y envío del contrato al Banco para registro |  | 5d | 2016-04-25 | 2016-04-29 | 167 | 2016-04-25 | 2016-04-29 | 990d | 0d |

| ID | WBS | Task | Type | Duration | Start | Finish | Predecessors | Baseline 1 start | Baseline 1 finish | Total slack | Free slack |
| --- | --- | --- | --- | --- | --- | --- | --- | --- | --- | --- | --- |
| 169 | 3.2.4.47 | **Contractual** |  | 122d | 2016-05-02 | 2016-10-27 |  | 2016-05-02 | 2016-10-27 | 990d |  |
| 170 | 3.5.1.2.2.1 | Acta de inicio |  | 2d | 2016-05-02 | 2016-05-03 | 168 | 2016-05-02 | 2016-05-03 | 990d | 0d |
| 171 | 3.5.1.2.2.2 | Implementación y divulgacion del SECVF |  | 6mo | 2016-05-04 | 2016-10-27 | 170 | 2016-05-04 | 2016-10-27 | 990d | 0d |
| 172 | 3.5.1.2.3 | **Cierre** |  | 80d | 2016-10-28 | 2017-02-22 |  | 2016-10-28 | 2017-02-22 | 990d |  |
| 173 | 3.5.1.2.3.1 | Liquidacion de contrato |  | 4mo | 2016-10-28 | 2017-02-22 | 171 | 2016-10-28 | 2017-02-22 | 990d |  |
| 174 | 3.5.2 | **Producto 2 - Procesos misionales (4) de la CGR fortalecidos (1. Control fiscal micro, 2. Responsabilidad fiscal y gestion coactiva, 3. Control fiscal macro y 4. Enlaces clientes y partes interesadas - participacion y servicio al ciudadano)** |  | 785d | 2015-08-25 | 2018-11-07 |  | 2015-08-25 | 2018-11-07 | 576d |  |
| 175 | 3.5.2.1 | **Consultoría: Adquirir, y configurar la herramienta de soporte al proceso de arquitectura empresarial. CP** |  | 97d | 2015-08-25 | 2016-01-15 |  | 2015-08-25 | 2016-01-15 | 1028d |  |
| 176 | 3.5.2.1.1 | **Precontractual** |  | 54d | 2015-08-25 | 2015-11-10 |  | 2015-08-25 | 2015-11-10 | 1028d |  |
| 177 | 3.5.2.1.1.1 | Elaboracion de Especificaciones Tecnicas |  | 10d | 2015-08-25 | 2015-09-07 | 46 | 2015-08-25 | 2015-09-07 | 1028d | 0d |
| 178 | 3.5.2.1.1.2 | Elaboracion de la Solicitud de Cotizacion de Precios |  | 5d | 2015-09-08 | 2015-09-14 | 177 | 2015-09-08 | 2015-09-14 | 1028d | 0d |
| 179 | 3.5.2.1.1.3 | No Objecion del Banco a las especificaciones tecnicas y Solicitud de Cotizacion de Precios |  | 5d | 2015-09-15 | 2015-09-21 | 178 | 2015-09-15 | 2015-09-21 | 1028d | 0d |
| 180 | 3.5.2.1.1.4 | Invitacion a cotizar a diversos proveedores (minimo 3) |  | 2d | 2015-09-22 | 2015-09-23 | 179 | 2015-09-22 | 2015-09-23 | 1028d | 0d |
| 181 | 3.5.2.1.1.5 | Recibo de cotizaciones |  | 3w | 2015-09-24 | 2015-10-15 | 180 | 2015-09-24 | 2015-10-15 | 1028d | 0d |
| 182 | 3.5.2.1.1.6 | Evaluacion de cotizaciones recibidas |  | 5d | 2015-10-16 | 2015-10-22 | 181 | 2015-10-16 | 2015-10-22 | 1028d | 0d |
| 183 | 3.5.2.1.1.7 | Solicitud de no objecion al Banco con recomendacion de adjudicacion |  | 2d | 2015-10-23 | 2015-10-26 | 182 | 2015-10-23 | 2015-10-26 | 1028d | 0d |
| 184 | 3.5.2.1.1.8 | No objecion al Banco con recomendacion de adjudicacion |  | 5d | 2015-10-27 | 2015-11-03 | 183 | 2015-10-27 | 2015-11-03 | 1028d | 0d |
| 185 | 3.5.2.1.1.9 | Firma de orden de compra o un contrato simplificado |  | 5d | 2015-11-04 | 2015-11-10 | 184 | 2015-11-04 | 2015-11-10 | 1028d | 0d |
| 186 | 3.5.2.1.2 | **Contractual** |  | 33d | 2015-11-11 | 2015-12-30 |  | 2015-11-11 | 2015-12-30 | 1028d |  |
| 187 | 3.5.2.1.2.1 | Acta de Inicio |  | 3d | 2015-11-11 | 2015-11-13 | 185 | 2015-11-11 | 2015-11-13 | 1028d | 0d |
| 188 | 3.5.2.1.2.2 | Entrega de los bienes |  | 1mo | 2015-11-17 | 2015-12-15 | 187 | 2015-11-17 | 2015-12-15 | 1028d | 0d |
| 189 | 3.5.2.1.2.3 | Ingreso a almacen y registro por la CGR |  | 2w | 2015-12-16 | 2015-12-30 | 188 | 2015-12-16 | 2015-12-30 | 1274d |  |
| 190 | 3.5.2.1.3 | **Cierre** |  | 20d | 2015-12-16 | 2016-01-15 |  | 2015-12-16 | 2016-01-15 | 1264d |  |
| 191 | 3.5.2.1.3.1 | Liquidacion del contrato |  | 4w | 2015-12-16 | 2016-01-15 | 188 | 2015-12-16 | 2016-01-15 | 1264d |  |
| 192 | 3.5.2.2 | **Consultoria: Diseno del proyecto de arquitectura empresarial que incluya un diagnostico de cuatro procesos misionales (Micro/Macro/ RF/ Part Ciudadana) e instrumentos tecnologicos de soporte. SBCC** |  | 274d | 2015-11-20 | 2016-12-30 |  | 2015-11-20 | 2016-12-30 | 575d |  |
| 193 | 3.2.3.3.1 | **Precontractual** |  | 130d | 2015-11-20 | 2016-06-01 |  | 2015-11-20 | 2016-06-01 | 575d |  |
| 194 | 3.2.3.3.1.1 | Elaboración de los términos de referencia (TR) |  | 10d | 2015-11-20 | 2015-12-03 | 46FS+3mo | 2015-11-20 | 2015-12-03 | 575d | 0d |
| 195 | 3.2.3.3.1.3 | Preparación de la estimación de costos y presupuesto (Estudio de mercado) |  | 10d | 2015-12-04 | 2015-12-18 | 194 | 2015-12-04 | 2015-12-18 | 575d | 0d |
| 196 | 3.2.3.3.1.4 | Elaboración del Aviso Específico de Adquisiciones (AEA) solicitando expresiones de interés y solicitud de No Objeción al Banco |  | 1d | 2015-12-21 | 2015-12-21 | 195 | 2015-12-21 | 2015-12-21 | 575d | 0d |
| 197 | 3.2.3.3.1.5 | No Objeción del Banco al AEA |  | 5d | 2015-12-22 | 2015-12-29 | 196 | 2015-12-22 | 2015-12-29 | 575d | 0d |
| 198 | 3.2.3.3.1.6 | Publicación del AEA en SECOP (los contratos de valor mayor al equivalente de US $200.000 se deben anunciar ademas en los sitios de Internet del UNDB online y del Banco) |  | 2d | 2015-12-30 | 2015-12-31 | 197 | 2015-12-30 | 2015-12-31 | 575d | 0d |
| 199 | 3.2.3.3.1.7 | Recepción de expresiones de interés | milestone | 0d | 2016-01-14 | 2016-01-14 | 198FS+14ed | 2016-01-14 | 2016-01-14 | 576d | 0d |
| 200 | 3.2.3.3.1.8 | Evaluación de Expresiones de Interés recibidas y conformación de lista corta |  | 10d | 2016-01-15 | 2016-01-28 | 199 | 2016-01-15 | 2016-01-28 | 1255d |  |
| 201 | 3.2.3.3.1.9 | Elaboración de la Solicitud de Propuesta (SP) que incluye: (a) la Carta de Invitación a las firmas de la lista corta; (b) las Instrucciones a los Consultores; © los TR; y (d) el contrato propuesto; y solicitud de No Objeción al Banco |  | 15d | 2016-01-15 | 2016-02-04 | 199 | 2016-01-15 | 2016-02-04 | 576d | 0d |
| 202 | 3.2.3.3.1.10 | No Objeción del Banco a la SP y conformacion Lista Corta |  | 5d | 2016-02-05 | 2016-02-11 | 201 | 2016-02-05 | 2016-02-11 | 576d | 0d |
| 203 | 3.2.3.3.1.11 | Envio de Solicitud de Propuestas (SP) a los integrantes de la lista corta (Invitación a presentar propuestas) |  | 2d | 2016-02-12 | 2016-02-15 | 202 | 2016-02-12 | 2016-02-15 | 576d | 0d |
| 204 | 3.2.3.3.1.12 | Reunión aclaratoria (eventual a los diez días de la invitación) | milestone | 0d | 2016-02-29 | 2016-02-29 | 203FS+10d | 2016-02-29 | 2016-02-29 | 576d | 0d |
| 205 | 3.2.3.3.1.13 | Preparación de respuestas a las solicitudes de aclaraciones de los oferentes y solicitud de No Objeción al Banco |  | 3d | 2016-03-01 | 2016-03-03 | 204 | 2016-03-01 | 2016-03-03 | 576d | 0d |
| 206 | 3.2.3.3.1.14 | No objeción del Banco a las respuestas de aclaraciones |  | 5d | 2016-03-04 | 2016-03-10 | 205 | 2016-03-04 | 2016-03-10 | 576d | 0d |
| 207 | 3.2.3.3.1.15 | Respuesta a las solicitudes de aclaración antes de la recepción de propuestas |  | 1d | 2016-03-11 | 2016-03-11 | 206 | 2016-03-11 | 2016-03-11 | 576d | 0d |
| 208 | 3.2.3.3.1.17 | Designación del Comité de Evaluación |  | 1d | 2016-03-14 | 2016-03-14 | 207 | 2016-03-14 | 2016-03-14 | 576d | 0d |
| 209 | 3.2.3.3.1.18 | Recepción de las Propuestas técnicas y de precio y Apertura de propuestas técnicas | milestone | 0d | 2016-03-14 | 2016-03-14 | 203FS+4w | 2016-03-14 | 2016-03-14 | 576d | 0d |
| 210 | 3.2.3.3.1.19 | Envío de propuestas al Comité de Evaluación y al Especialista en Adquisiciones | milestone | 0d | 2016-03-14 | 2016-03-14 | 208, 209 | 2016-03-14 | 2016-03-14 | 576d | 0d |
| 211 | 3.2.3.3.1.20 | Evaluación de propuestas técnicas y elaboración borrador del Informe de Evaluación Técnica (IET) |  | 10d | 2016-03-15 | 2016-03-31 | 210 | 2016-03-15 | 2016-03-31 | 576d | 0d |
| 212 | 3.2.3.3.1.16 | Reunion Comité de Evaluación |  | 1d | 2016-04-01 | 2016-04-01 | 211 | 2016-04-01 | 2016-04-01 | 576d | 0d |
| 213 | 3.2.3.3.1.21 | Solicitud de No Objeción del Banco al Informe de Evaluación Técnica (IET) de las propuestas |  | 1d | 2016-04-04 | 2016-04-04 | 212 | 2016-04-04 | 2016-04-04 | 576d | 0d |
| 214 | 3.2.3.3.1.22 | No Objeción del Banco al IET |  | 5d | 2016-04-05 | 2016-04-11 | 213 | 2016-04-05 | 2016-04-11 | 576d | 0d |
| 215 | 3.2.3.3.1.23 | Notificación del puntaje de la evaluación técnica a los proponentes y notificar simultáneamente a los que obtuvieron la calificación mínima necesaria e indicar la fecha, lugar y hora fijada para abrir las propuestas de precio. |  | 1d | 2016-04-12 | 2016-04-12 | 214 | 2016-04-12 | 2016-04-12 | 576d | 0d |
| 216 | 3.2.3.3.1.24 | Apertura de propuesta de precio en Audiencia Pública | milestone | 0d | 2016-04-19 | 2016-04-19 | 215FS+5d | 2016-04-19 | 2016-04-19 | 576d | 0d |
| 217 | 3.2.3.3.1.25 | Evaluación del Costo y Evaluación Combinada de la Calidad y el Costo |  | 1d | 2016-04-20 | 2016-04-20 | 216 | 2016-04-20 | 2016-04-20 | 576d | 0d |
| 218 | 3.2.3.3.1.26 | Notificación y negociación del contrato con el proponente seleccionado, elaboración del borrador del contrato negociado y solicitud de No Objeción Banco |  | 10d | 2016-04-21 | 2016-05-04 | 217 | 2016-04-21 | 2016-05-04 | 576d | 0d |
| 219 | 3.2.3.3.1.27 | No Objeción del Banco al borrador del contrato negociado y envio acta de apertura de sobres y evaluacion combinada |  | 5d | 2016-05-05 | 2016-05-12 | 218 | 2016-05-05 | 2016-05-12 | 576d | 0d |
| 220 | 3.2.3.3.1.28 | Notificación a las demás firmas incluidas en la lista corta que sus propuestas no fueron seleccionadas |  | 1d | 2016-05-13 | 2016-05-13 | 219 | 2016-05-13 | 2016-05-13 | 576d | 0d |
| 221 | 3.2.3.3.1.29 | Publicación de la Adjudicación del Contrato |  | 1d | 2016-05-16 | 2016-05-16 | 220 | 2016-05-16 | 2016-05-16 | 576d | 0d |
| 222 | 3.2.3.3.1.30 | Legalización y Firma del Contrato |  | 10d | 2016-05-17 | 2016-05-31 | 221 | 2016-05-17 | 2016-05-31 | 576d | 0d |
| 223 | 3.2.3.3.1.31 | Envio al Banco de una copia firmada del contrato |  | 1d | 2016-06-01 | 2016-06-01 | 222 | 2016-06-01 | 2016-06-01 | 1171d |  |

| ID | WBS | Task | Type | Duration | Start | Finish | Predecessors | Baseline 1 start | Baseline 1 finish | Total slack | Free slack |
| --- | --- | --- | --- | --- | --- | --- | --- | --- | --- | --- | --- |
| 224 | 3.2.4.47 | **Contractual** |  | 85d | 2016-06-01 | 2016-10-03 |  | 2016-06-01 | 2016-10-03 | 576d |  |
| 225 | 3.2.3.3.2.1 | Acta de inicio |  | 5d | 2016-06-01 | 2016-06-08 | 222 | 2016-06-01 | 2016-06-08 | 576d | 0d |
| 226 | 3.5.2.2.2.2 | Diagnóstico de la situación actual de los cuatro procesos misionales |  | 3mo | 2016-06-09 | 2016-09-05 | 225 | 2016-06-09 | 2016-09-05 | 576d | 0d |
| 227 | 3.5.2.2.2.3 | Definición de un Plan de acción y recomendaciones para el cierre de brechas y optimización de los cuatro procesos misionales estableciendo recomendaciones para mejorar su funcionamiento individual y su vinculacion al SGC de la entidad. |  | 1mo | 2016-09-06 | 2016-10-03 | 226 | 2016-09-06 | 2016-10-03 | 576d | 0d |
| 228 | 3.5.2.2.2.4 | Realizar el proyecto de Arquitectura Empresarial con alcance en los cuatro procesos misionales |  | 3mo | 2016-06-09 | 2016-09-05 | 225 | 2016-06-09 | 2016-09-05 | 1027d | 0d |
| 229 | 3.5.2.2.3 | **Cierre** |  | 80d | 2016-09-06 | 2016-12-30 |  | 2016-09-06 | 2016-12-30 | 1027d |  |
| 230 | 3.5.2.2.3.1 | Liquidación del contrato |  | 4mo | 2016-09-06 | 2016-12-30 | 228 | 2016-09-06 | 2016-12-30 | 1027d |  |
| 231 | 3.5.2.3 | **Consultoria: Diagnostico para determinar el modelo de compentencias requerido para los RRHH asociados a los 4 procesos misionales. SBCC** |  | 511d | 2016-10-04 | 2018-11-07 |  | 2016-10-04 | 2018-11-07 | 576d |  |
| 232 | 3.2.3.3.1 | **Precontractual** |  | 127d | 2016-10-04 | 2017-04-06 |  | 2016-10-04 | 2017-04-06 | 576d |  |
| 233 | 3.2.3.3.1.1 | Elaboración de los términos de referencia (TR) |  | 10d | 2016-10-04 | 2016-10-18 | 227 | 2016-10-04 | 2016-10-18 | 576d | 0d |
| 234 | 3.2.3.3.1.3 | Preparación de la estimación de costos y presupuesto (Estudio de mercado) |  | 10d | 2016-10-19 | 2016-11-01 | 233 | 2016-10-19 | 2016-11-01 | 576d | 0d |
| 235 | 3.5.2.3.1.3 | Solicitud de Vigencias Futuras | milestone | 0d | 2016-11-01 | 2016-11-01 | 234 | 2016-11-01 | 2016-11-01 | 609d | 33d |
| 236 | 3.2.3.3.1.4 | Elaboración del Aviso Específico de Adquisiciones (AEA) solicitando expresiones de interés y solicitud de No Objeción al Banco |  | 1d | 2016-11-02 | 2016-11-02 | 234 | 2016-11-02 | 2016-11-02 | 576d | 0d |
| 237 | 3.2.3.3.1.5 | No Objeción del Banco al AEA |  | 5d | 2016-11-03 | 2016-11-10 | 236 | 2016-11-03 | 2016-11-10 | 576d | 0d |
| 238 | 3.2.3.3.1.6 | Publicación del AEA en SECOP (los contratos de valor mayor al equivalente de US $200.000 se deben anunciar ademas en los sitios de Internet del UNDB online y del Banco) |  | 2d | 2016-11-11 | 2016-11-15 | 237 | 2016-11-11 | 2016-11-15 | 576d | 0d |
| 239 | 3.2.3.3.1.7 | Recepción de expresiones de interés | milestone | 0d | 2016-11-29 | 2016-11-29 | 238FS+14ed | 2016-11-29 | 2016-11-29 | 576d | 0d |
| 240 | 3.2.3.3.1.8 | Evaluación de Expresiones de Interés recibidas y conformación de lista corta |  | 10d | 2016-11-30 | 2016-12-14 | 239 | 2016-11-30 | 2016-12-14 | 1039d |  |
| 241 | 3.2.3.3.1.9 | Elaboración de la Solicitud de Propuesta (SP) que incluye: (a) la Carta de Invitación a las firmas de la lista corta; (b) las Instrucciones a los Consultores; © los TR; y (d) el contrato propuesto; y solicitud de No Objeción al Banco |  | 15d | 2016-11-30 | 2016-12-21 | 239 | 2016-11-30 | 2016-12-21 | 576d | 0d |
| 242 | 3.2.3.3.1.10 | No Objeción del Banco a la SP y conformacion Lista Corta |  | 5d | 2016-12-22 | 2016-12-28 | 241 | 2016-12-22 | 2016-12-28 | 1029d |  |
| 243 | 3.2.3.3.1.11 | Envio de Solicitud de Propuestas (SP) a los integrantes de la lista corta (Invitación a presentar propuestas) |  | 2d | 2016-12-22 | 2016-12-23 | 235, 241 | 2016-12-22 | 2016-12-23 | 576d | 0d |
| 244 | 3.2.3.3.1.12 | Reunión aclaratoria (eventual a los diez días de la invitación) | milestone | 0d | 2017-01-06 | 2017-01-06 | 243FS+10d | 2017-01-06 | 2017-01-06 | 576d | 0d |
| 245 | 3.2.3.3.1.13 | Preparación de respuestas a las solicitudes de aclaraciones de los oferentes y solicitud de No Objeción al Banco |  | 3d | 2017-01-10 | 2017-01-12 | 244 | 2017-01-10 | 2017-01-12 | 576d | 0d |
| 246 | 3.2.3.3.1.14 | No objeción del Banco a las respuestas de aclaraciones |  | 5d | 2017-01-13 | 2017-01-19 | 245 | 2017-01-13 | 2017-01-19 | 576d | 0d |
| 247 | 3.2.3.3.1.15 | Respuesta a las solicitudes de aclaración antes de la recepción de propuestas |  | 1d | 2017-01-20 | 2017-01-20 | 246 | 2017-01-20 | 2017-01-20 | 576d | 0d |
| 248 | 3.2.3.3.1.17 | Designación del Comité de Evaluación |  | 1d | 2017-01-23 | 2017-01-23 | 247 | 2017-01-23 | 2017-01-23 | 576d | 0d |
| 249 | 3.2.3.3.1.18 | Recepción de las Propuestas técnicas y de precio y Apertura de propuestas técnicas | milestone | 0d | 2017-01-23 | 2017-01-23 | 243FS+4w | 2017-01-23 | 2017-01-23 | 576d | 0d |
| 250 | 3.2.3.3.1.19 | Envío de propuestas al Comité de Evaluación y al Especialista en Adquisiciones | milestone | 0d | 2017-01-23 | 2017-01-23 | 248, 249 | 2017-01-23 | 2017-01-23 | 576d | 0d |
| 251 | 3.2.3.3.1.20 | Evaluación de propuestas técnicas y elaboración borrador del Informe de Evaluación Técnica (IET) |  | 10d | 2017-01-24 | 2017-02-06 | 250 | 2017-01-24 | 2017-02-06 | 576d | 0d |
| 252 | 3.2.3.3.1.16 | Reunion Comité de Evaluación |  | 1d | 2017-02-07 | 2017-02-07 | 251 | 2017-02-07 | 2017-02-07 | 576d | 0d |
| 253 | 3.2.3.3.1.21 | Solicitud de No Objeción del Banco al Informe de Evaluación Técnica (IET) de las propuestas |  | 1d | 2017-02-08 | 2017-02-08 | 252 | 2017-02-08 | 2017-02-08 | 576d | 0d |
| 254 | 3.2.3.3.1.22 | No Objeción del Banco al IET |  | 5d | 2017-02-09 | 2017-02-15 | 253 | 2017-02-09 | 2017-02-15 | 576d | 0d |
| 255 | 3.2.3.3.1.23 | Notificación del puntaje de la evaluación técnica a los proponentes y notificar simultáneamente a los que obtuvieron la calificación mínima necesaria e indicar la fecha, lugar y hora fijada para abrir las propuestas de precio. |  | 1d | 2017-02-16 | 2017-02-16 | 254 | 2017-02-16 | 2017-02-16 | 576d | 0d |
| 256 | 3.2.3.3.1.24 | Apertura de propuesta de precio en Audiencia Pública | milestone | 0d | 2017-02-23 | 2017-02-23 | 255FS+5d | 2017-02-23 | 2017-02-23 | 576d | 0d |
| 257 | 3.2.3.3.1.25 | Evaluación del Costo y Evaluación Combinada de la Calidad y el Costo |  | 1d | 2017-02-24 | 2017-02-24 | 256 | 2017-02-24 | 2017-02-24 | 576d | 0d |
| 258 | 3.2.3.3.1.26 | Notificación y negociación del contrato con el proponente seleccionado, elaboración del borrador del contrato negociado y solicitud de No Objeción Banco |  | 10d | 2017-02-27 | 2017-03-10 | 257 | 2017-02-27 | 2017-03-10 | 576d | 0d |
| 259 | 3.2.3.3.1.27 | No Objeción del Banco al borrador del contrato negociado y envio acta de apertura de sobres y evaluacion combinada |  | 5d | 2017-03-13 | 2017-03-17 | 258 | 2017-03-13 | 2017-03-17 | 576d | 0d |
| 260 | 3.2.3.3.1.28 | Notificación a las demás firmas incluidas en la lista corta que sus propuestas no fueron seleccionadas |  | 1d | 2017-03-21 | 2017-03-21 | 259 | 2017-03-21 | 2017-03-21 | 576d | 0d |
| 261 | 3.2.3.3.1.29 | Publicación de la Adjudicación del Contrato |  | 1d | 2017-03-22 | 2017-03-22 | 260 | 2017-03-22 | 2017-03-22 | 576d | 0d |
| 262 | 3.2.3.3.1.30 | Legalización y Firma del Contrato |  | 10d | 2017-03-23 | 2017-04-05 | 261 | 2017-03-23 | 2017-04-05 | 576d | 0d |
| 263 | 3.2.3.3.1.31 | Envio al Banco de una copia firmada del contrato |  | 1d | 2017-04-06 | 2017-04-06 | 262 | 2017-04-06 | 2017-04-06 | 960d |  |

| ID | WBS | Task | Type | Duration | Start | Finish | Predecessors | Baseline 1 start | Baseline 1 finish | Total slack | Free slack |
| --- | --- | --- | --- | --- | --- | --- | --- | --- | --- | --- | --- |
| 264 | 3.2.4.47 | **Contractual** |  | 305d | 2017-04-06 | 2018-07-11 |  | 2017-04-06 | 2018-07-11 | 576d |  |
| 265 | 3.2.3.3.2.1 | Acta de inicio |  | 5d | 2017-04-06 | 2017-04-12 | 262 | 2017-04-06 | 2017-04-12 | 576d | 0d |
| 266 | 3.5.2.3.2.2 | Elaboración de un diagnóstico para determinar las brechas de competencias de los funcionarios que participan en los cuatro procesos misionales mejorados. |  | 3mo | 2017-04-17 | 2017-07-14 | 265 | 2017-04-17 | 2017-07-14 | 576d | 0d |
| 267 | 3.5.2.3.2.3 | Diseño y ejecución de planes de formación por competencias requeridos para el cierre de brechas identificados en los cuatro procesos misionales Control Fiscal Micro y Responsabilidad Fiscal a partir del diagnóstico realizado mejorados. |  | 6mo | 2017-07-17 | 2018-01-12 | 266 | 2017-07-17 | 2018-01-12 | 576d | 0d |
| 268 | 3.5.2.3.2.4 | Fortalecimiento de la Oficina de Capacitacion para definir un modelo de Gestion por Competencias para el Programa de Fortalecimiento. |  | 6mo | 2018-01-15 | 2018-07-11 | 267 | 2018-01-15 | 2018-07-11 | 576d | 0d |
| 269 | 3.5.2.3.3 | **Cierre** |  | 80d | 2018-07-12 | 2018-11-07 |  | 2018-07-12 | 2018-11-07 | 576d |  |
| 270 | 3.5.2.3.3.1 | Liquidación del contrato |  | 4mo | 2018-07-12 | 2018-11-07 | 268 | 2018-07-12 | 2018-11-07 | 576d |  |
| 271 | 3.5.3 | **Producto 3. Modelo de Gobierno de TICS de la CGR definido** |  | 309d | 2016-10-12 | 2018-01-18 |  | 2015-02-16 | 2016-08-29 | 772d |  |
| 272 | 3.5.3.1 | **Consultoria: Modelo de Gobierno de TICS de la CGR definido** |  | 309d | 2016-10-12 | 2018-01-18 |  | 2015-02-16 | 2016-08-29 | 772d |  |
| 273 | 3.2.3.3.1 | **Precontractual** |  | 145d | 2016-10-12 | 2017-05-15 |  | 2015-09-22 | 2016-04-25 | 772d |  |
| 274 | 3.2.3.3.1.1 | Elaboración de los términos de referencia (TR) |  | 1mo | 2016-10-12 | 2016-11-10 | 46FS+14mo | 2015-09-22 | 2015-10-20 | 772d | 0d |
| 275 | 3.2.3.3.1.3 | Preparación de la estimación de costos y presupuesto (Estudio de mercado) |  | 10d | 2016-11-11 | 2016-11-25 | 274 | 2015-10-21 | 2015-11-04 | 772d | 0d |
| 276 | 3.2.3.3.1.4 | Elaboración del Aviso Específico de Adquisiciones (AEA) solicitando expresiones de interés y solicitud de No Objeción al Banco |  | 2d | 2016-11-28 | 2016-11-29 | 275 | 2015-11-05 | 2015-11-06 | 772d | 0d |
| 277 | 3.2.3.3.1.5 | No Objeción del Banco al AEA |  | 5d | 2016-11-30 | 2016-12-06 | 276 | 2015-11-09 | 2015-11-13 | 772d | 0d |
| 278 | 3.2.3.3.1.6 | Publicación del AEA en SECOP (los contratos de valor mayor al equivalente de US $200.000 se deben anunciar ademas en los sitios de Internet del UNDB online y del Banco) |  | 2d | 2016-12-07 | 2016-12-09 | 277 | 2015-11-17 | 2015-11-18 | 772d | 0d |
| 279 | 3.2.3.3.1.7 | Recepción de expresiones de interés | milestone | 0d | 2016-12-23 | 2016-12-23 | 278FS+14ed | 2015-12-02 | 2015-12-02 | 772d | 0d |
| 280 | 3.2.3.3.1.8 | Evaluación de Expresiones de Interés recibidas y conformación de lista corta |  | 10d | 2016-12-26 | 2017-01-06 | 279 | 2015-12-03 | 2015-12-17 | 1022d |  |
| 281 | 3.2.3.3.1.9 | Elaboración de la Solicitud de Propuesta (SP) que incluye: (a) la Carta de Invitación a las firmas de la lista corta; (b) las Instrucciones a los Consultores; © los TR; y (d) el contrato propuesto; y solicitud de No Objeción al Banco |  | 15d | 2016-12-26 | 2017-01-16 | 279 | 2015-12-03 | 2015-12-24 | 772d | 0d |
| 282 | 3.2.3.3.1.10 | No Objeción del Banco a la SP y conformacion Lista Corta |  | 5d | 2017-01-17 | 2017-01-23 | 281 | 2015-12-28 | 2016-01-04 | 772d | 0d |
| 283 | 3.2.3.3.1.11 | Envio de Solicitud de Propuestas (SP) a los integrantes de la lista corta (Invitación a presentar propuestas) |  | 2d | 2017-01-24 | 2017-01-25 | 282 | 2016-01-05 | 2016-01-06 | 772d | 0d |
| 284 | 3.2.3.3.1.12 | Reunión aclaratoria (eventual a los diez días de la invitación) | milestone | 0d | 2017-02-08 | 2017-02-08 | 283FS+10d | 2016-01-21 | 2016-01-21 | 772d | 0d |
| 285 | 3.2.3.3.1.13 | Preparación de respuestas a las solicitudes de aclaraciones de los oferentes y solicitud de No Objeción al Banco |  | 3d | 2017-02-09 | 2017-02-13 | 284 | 2016-01-22 | 2016-01-26 | 772d | 0d |
| 286 | 3.2.3.3.1.14 | No objeción del Banco a las respuestas de aclaraciones |  | 5d | 2017-02-14 | 2017-02-20 | 285 | 2016-01-27 | 2016-02-02 | 772d | 0d |
| 287 | 3.2.3.3.1.15 | Respuesta a las solicitudes de aclaración antes de la recepción de propuestas |  | 3d | 2017-02-21 | 2017-02-23 | 286 | 2016-02-03 | 2016-02-05 | 772d | 0d |
| 288 | 3.2.3.3.1.17 | Designación del Comité de Evaluación |  | 1d | 2017-02-24 | 2017-02-24 | 287 | 2016-02-08 | 2016-02-08 | 772d | 0d |
| 289 | 3.2.3.3.1.18 | Recepción de las Propuestas técnicas y de precio y Apertura de propuestas técnicas | milestone | 0d | 2017-02-22 | 2017-02-22 | 283FS+4w | 2016-02-04 | 2016-02-04 | 774d | 2d |
| 290 | 3.2.3.3.1.19 | Envío de propuestas al Comité de Evaluación y al Especialista en Adquisiciones | milestone | 0d | 2017-02-24 | 2017-02-24 | 288, 289 | 2016-02-08 | 2016-02-08 | 772d | 0d |
| 291 | 3.2.3.3.1.20 | Evaluación de propuestas técnicas y elaboración borrador del Informe de Evaluación Técnica (IET) |  | 10d | 2017-02-27 | 2017-03-10 | 290 | 2016-02-09 | 2016-02-22 | 772d | 0d |
| 292 | 3.2.3.3.1.16 | Reunion Comité de Evaluación |  | 1d | 2017-03-13 | 2017-03-13 | 291 | 2016-02-23 | 2016-02-23 | 772d | 0d |
| 293 | 3.2.3.3.1.21 | Solicitud de No Objeción del Banco al Informe de Evaluación Técnica (IET) de las propuestas |  | 1d | 2017-03-14 | 2017-03-14 | 292 | 2016-02-24 | 2016-02-24 | 772d | 0d |
| 294 | 3.2.3.3.1.22 | No Objeción del Banco al IET |  | 5d | 2017-03-15 | 2017-03-22 | 293 | 2016-02-25 | 2016-03-02 | 772d | 0d |
| 295 | 3.2.3.3.1.23 | Notificación del puntaje de la evaluación técnica a los proponentes y notificar simultáneamente a los que obtuvieron la calificación mínima necesaria e indicar la fecha, lugar y hora fijada para abrir las propuestas de precio. |  | 1d | 2017-03-23 | 2017-03-23 | 294 | 2016-03-03 | 2016-03-03 | 772d | 0d |
| 296 | 3.2.3.3.1.24 | Apertura de propuesta de precio en Audiencia Pública | milestone | 0d | 2017-03-30 | 2017-03-30 | 295FS+5d | 2016-03-10 | 2016-03-10 | 772d | 0d |
| 297 | 3.2.3.3.1.25 | Evaluación del Costo y Evaluación Combinada de la Calidad y el Costo |  | 1d | 2017-03-31 | 2017-03-31 | 296 | 2016-03-11 | 2016-03-11 | 772d | 0d |
| 298 | 3.2.3.3.1.26 | Notificación y negociación del contrato con el proponente seleccionado, elaboración del borrador del contrato negociado y solicitud de No Objeción Banco |  | 10d | 2017-04-03 | 2017-04-18 | 297 | 2016-03-14 | 2016-03-30 | 772d | 0d |
| 299 | 3.2.3.3.1.27 | No Objeción del Banco al borrador del contrato negociado y envio acta de apertura de sobres y evaluacion combinada |  | 5d | 2017-04-19 | 2017-04-25 | 298 | 2016-03-31 | 2016-04-06 | 772d | 0d |
| 300 | 3.2.3.3.1.28 | Notificación a las demás firmas incluidas en la lista corta que sus propuestas no fueron seleccionadas |  | 1d | 2017-04-26 | 2017-04-26 | 299 | 2016-04-07 | 2016-04-07 | 772d | 0d |
| 301 | 3.2.3.3.1.29 | Publicación de la Adjudicación del Contrato |  | 1d | 2017-04-27 | 2017-04-27 | 300 | 2016-04-08 | 2016-04-08 | 772d | 0d |
| 302 | 3.2.3.3.1.30 | Legalización y Firma del Contrato |  | 10d | 2017-04-28 | 2017-05-12 | 301 | 2016-04-11 | 2016-04-22 | 772d | 0d |
| 303 | 3.2.3.3.1.31 | Envio al Banco de una copia firmada del contrato |  | 1d | 2017-05-15 | 2017-05-15 | 302 | 2016-04-25 | 2016-04-25 | 936d |  |

| ID | WBS | Task | Type | Duration | Start | Finish | Predecessors | Baseline 1 start | Baseline 1 finish | Total slack | Free slack |
| --- | --- | --- | --- | --- | --- | --- | --- | --- | --- | --- | --- |
| 304 | 3.2.4.47 | **Contractual** |  | 165d | 2017-05-15 | 2018-01-18 |  | 2015-02-16 | 2016-08-29 | 772d |  |
| 305 | 3.2.3.3.2.1 | Acta de inicio |  | 5d | 2017-05-15 | 2017-05-19 | 302 | 2016-04-25 | 2016-04-29 | 772d | 0d |
| 306 | 3.5.3.1.2.2 | Definicion del Modelo de Gobierno de TICS de la CGR |  | 4mo | 2017-05-22 | 2017-09-19 | 305 | 2016-05-02 | 2016-08-29 | 772d | 0d |
| 307 | 3.5.3.1.2.3 | Liquidación del contrato |  | 4mo | 2017-09-20 | 2018-01-18 | 306 | 2015-06-17 | 2015-10-13 | 772d |  |
| 308 | 3.5.4 | **Producto 4 - Estrategia de Gestión del Cambio y del conocimiento disenada e implementada** |  | 1260d? | 2015-02-16 | 2020-03-13 |  | 2015-02-16 | 2019-09-27 | 226d |  |
| 309 | 3.5.4.1 | **Consultoria: Diseño e implementacion de la estrategia general de gestión del cambio para apoyar el proceso de fortalecimiento institucional. SCC** |  | 331d | 2015-02-16 | 2016-06-24 |  | 2015-02-16 | 2015-12-29 | 412d |  |
| 310 | 3.5.4.1.1 | **Precontractual** |  | 84d | 2015-11-23 | 2016-03-28 |  | 2015-06-25 | 2015-09-28 | 226d |  |
| 311 | 3.5.4.1.1.1 | Elaboración de los TR |  | 1d | 2015-11-23 | 2015-11-23 | 16FS+5mo | 2015-06-25 | 2015-06-25 | 226d | 0d |
| 312 | 3.5.4.1.1.2 | Estimado de costos y presupuesto |  | 1d | 2015-11-24 | 2015-11-24 | 311 | 2015-06-26 | 2015-06-26 | 226d | 0d |
| 313 | 3.5.4.1.1.3 | No objeción del Banco a los TR |  | 5d | 2015-11-25 | 2015-12-01 | 312 | 2015-06-30 | 2015-07-06 | 226d | 0d |
| 314 | 3.5.4.1.1.4 | Elaboración del Aviso Específico de Adquisiciones (AEA) solicitando Expresiones de Interés (EI) |  | 2d | 2015-12-02 | 2015-12-03 | 313 | 2015-07-07 | 2015-07-08 | 226d | 0d |
| 315 | 3.5.4.1.1.5 | No Objeción del Banco al AEA |  | 5d | 2015-12-04 | 2015-12-11 | 314 | 2015-07-09 | 2015-07-15 | 226d | 0d |
| 316 | 3.5.4.1.1.6 | Publicación del AEA en SECOP |  | 2d | 2015-12-14 | 2015-12-15 | 315 | 2015-07-16 | 2015-07-17 | 226d | 0d |
| 317 | 3.5.4.1.1.7 | Recepción de Expresiones de Interés | milestone | 0d | 2015-12-29 | 2015-12-29 | 316FS+14ed | 2015-07-31 | 2015-07-31 | 227d | 0d |
| 318 | 3.5.4.1.1.8 | Evaluación de EI recibidas y conformación de lista corta ordenada por Orden de Merito |  | 5d | 2015-12-30 | 2016-01-06 | 317 | 2015-08-03 | 2015-08-10 | 227d | 0d |
| 319 | 3.5.4.1.1.9 | Elaboracion de la Solicitud de Propuestas (SP) |  | 5d | 2015-12-30 | 2016-01-06 | 317 | 2015-08-03 | 2015-08-10 | 227d | 0d |
| 320 | 3.5.4.1.1.10 | No Objeción del Banco a la lista corta rankeada y SP |  | 5d | 2016-01-07 | 2016-01-14 | 318, 319 | 2015-08-11 | 2015-08-18 | 227d | 0d |
| 321 | 3.5.4.1.1.11 | Invitación a presentar propuesta tecnica y economica solo a la Firma Consultora (FC) rankeada en 1º lugar |  | 2d | 2016-02-12 | 2016-02-15 | 320FS+20d | 2015-08-19 | 2015-08-20 | 227d | 0d |
| 322 | 3.5.4.1.1.12 | Recepción de propuesta de la FC invitada | milestone | 0d | 2016-02-29 | 2016-02-29 | 321FS+2w | 2015-09-03 | 2015-09-03 | 227d | 0d |
| 323 | 3.5.4.1.1.13 | Evaluación de la propuesta y negociación del contrato |  | 5d | 2016-03-01 | 2016-03-07 | 322 | 2015-09-04 | 2015-09-10 | 227d | 0d |
| 324 | 3.5.4.1.1.14 | No Objeción del Banco al contrato negociado y rubricado |  | 5d | 2016-03-08 | 2016-03-14 | 323 | 2015-09-11 | 2015-09-17 | 227d | 0d |
| 325 | 3.5.4.1.1.15 | Publicar el nombre del consultor al cual se le adjudicó el contrato, |  | 2d | 2016-03-15 | 2016-03-16 | 324 | 2015-09-18 | 2015-09-21 | 227d | 0d |
| 326 | 3.5.4.1.1.16 | Firma del contrato y envío del contrato al Banco para registro |  | 5d | 2016-03-17 | 2016-03-28 | 325 | 2015-09-22 | 2015-09-28 | 227d | 0d |
| 327 | 3.2.4.47 | **Contractual** |  | 61d | 2016-03-29 | 2016-06-24 |  | 2015-09-29 | 2015-12-29 | 227d |  |
| 328 | 3.2.3.3.2.1 | Acta de inicio |  | 1d | 2016-03-29 | 2016-03-29 | 326 | 2015-09-29 | 2015-09-29 | 227d | 0d |
| 329 | 3.5.4.1.2.2 | Diseno de la estrategia general de gestion del cambio e incio de implementacion |  | 3mo | 2016-03-30 | 2016-06-24 | 328 | 2015-09-30 | 2015-12-29 | 227d | 0d |

Notes:
- 319: Modelo Base SP bajo la modalidad SCC

| ID | WBS | Task | Type | Duration | Start | Finish | Predecessors | Baseline 1 start | Baseline 1 finish | Total slack | Free slack |
| --- | --- | --- | --- | --- | --- | --- | --- | --- | --- | --- | --- |
| 330 | 3.5.4.1.3 | **Cierre** |  | 80d | 2015-02-16 | 2015-06-16 |  | 2015-02-16 | 2015-06-16 | 1406d |  |
| 331 | 3.5.4.1.3.1 | Liquidacion de contrato |  | 4mo | 2015-02-16 | 2015-06-16 |  | 2015-02-16 | 2015-06-16 | 1406d |  |
| 332 | 3.5.4.2 | **Consultoria: Diseno e implementacion de estrategias especificas de gestion del cambio para cada uno de los proyectos derivados del proceso de fortalecimiento institucional. SBCC** |  | 929d? | 2016-06-27 | 2020-03-13 |  | 2015-12-30 | 2019-09-27 | 226d |  |
| 333 | 3.2.3.3.1 | **Precontractual** |  | 125d? | 2016-06-27 | 2016-12-27 |  | 2015-12-30 | 2016-07-01 | 227d |  |
| 334 | 3.2.3.3.1.1 | Elaboración de los términos de referencia (TR) |  | 10d | 2016-06-27 | 2016-07-11 | 329 | 2015-12-30 | 2016-01-14 | 1145d |  |
| 335 | 3.2.3.3.1.3 | Preparación de la estimación de costos y presupuesto (Estudio de mercado) |  | 10d | 2016-06-27 | 2016-07-11 | 329 | 2015-12-30 | 2016-01-14 | 227d | 0d |
| 336 | 3.2.3.3.1.4 | Elaboración del Aviso Específico de Adquisiciones (AEA) solicitando expresiones de interés y solicitud de No Objeción al Banco |  | 2d | 2016-07-12 | 2016-07-13 | 335 | 2016-01-15 | 2016-01-18 | 227d | 0d |
| 337 | 3.2.3.3.1.5 | No Objeción del Banco al AEA |  | 5d | 2016-07-14 | 2016-07-21 | 336 | 2016-01-19 | 2016-01-25 | 227d | 0d |
| 338 | 3.2.3.3.1.6 | Publicación del AEA en SECOP (los contratos de valor mayor al equivalente de US $200.000 se deben anunciar ademas en los sitios de Internet del UNDB online y del Banco) |  | 2d | 2016-07-22 | 2016-07-25 | 337 | 2016-01-26 | 2016-01-27 | 227d | 0d |
| 339 | 3.2.3.3.1.7 | Recepción de expresiones de interés | milestone | 0d | 2016-08-08 | 2016-08-08 | 338FS+14ed | 2016-02-10 | 2016-02-10 | 226d | 0d |
| 340 | 3.2.3.3.1.8 | Evaluación de Expresiones de Interés recibidas y conformación de lista corta |  | 10d | 2016-08-09 | 2016-08-23 | 339 | 2016-02-11 | 2016-02-24 | 1116d |  |
| 341 | 3.2.3.3.1.9 | Elaboración de la Solicitud de Propuesta (SP) que incluye: (a) la Carta de Invitación a las firmas de la lista corta; (b) las Instrucciones a los Consultores; © los TR; y (d) el contrato propuesto; y solicitud de No Objeción al Banco |  | 15d | 2016-08-09 | 2016-08-30 | 339 | 2016-02-11 | 2016-03-02 | 226d | 0d |
| 342 | 3.2.3.3.1.10 | No Objeción del Banco a la SP y conformacion Lista Corta |  | 5d | 2016-08-31 | 2016-09-06 | 341 | 2016-03-03 | 2016-03-09 | 226d | 0d |
| 343 | 3.5.4.2.1.10 | Solicitud vigencias futuras 2018 y 2019 |  | 1d? | 2016-10-27 | 2016-10-27 | 341FS+2mo |  |  | 1070d |  |
| 344 | 3.2.3.3.1.11 | Envio de Solicitud de Propuestas (SP) a los integrantes de la lista corta (Invitación a presentar propuestas) |  | 2d | 2016-09-07 | 2016-09-08 | 342 | 2016-03-10 | 2016-03-11 | 226d | 0d |
| 345 | 3.2.3.3.1.12 | Reunión aclaratoria (eventual a los diez días de la invitación) | milestone | 0d | 2016-09-22 | 2016-09-22 | 344FS+10d | 2016-03-30 | 2016-03-30 | 226d | 0d |
| 346 | 3.2.3.3.1.13 | Preparación de respuestas a las solicitudes de aclaraciones de los oferentes y solicitud de No Objeción al Banco |  | 3d | 2016-09-23 | 2016-09-27 | 345 | 2016-03-31 | 2016-04-04 | 226d | 0d |
| 347 | 3.2.3.3.1.14 | No objeción del Banco a las respuestas de aclaraciones |  | 5d | 2016-09-28 | 2016-10-04 | 346 | 2016-04-05 | 2016-04-11 | 226d | 0d |
| 348 | 3.2.3.3.1.15 | Respuesta a las solicitudes de aclaración antes de la recepción de propuestas |  | 3d | 2016-10-05 | 2016-10-07 | 347 | 2016-04-12 | 2016-04-14 | 226d | 0d |
| 349 | 3.2.3.3.1.17 | Designación del Comité de Evaluación |  | 1d | 2016-10-10 | 2016-10-10 | 348 | 2016-04-15 | 2016-04-15 | 226d | 0d |
| 350 | 3.2.3.3.1.18 | Recepción de las Propuestas técnicas y de precio y Apertura de propuestas técnicas | milestone | 0d | 2016-10-06 | 2016-10-06 | 344FS+4w | 2016-04-13 | 2016-04-13 | 228d | 2d |
| 351 | 3.2.3.3.1.19 | Envío de propuestas al Comité de Evaluación y al Especialista en Adquisiciones | milestone | 0d | 2016-10-10 | 2016-10-10 | 349, 350 | 2016-04-15 | 2016-04-15 | 226d | 0d |
| 352 | 3.2.3.3.1.20 | Evaluación de propuestas técnicas y elaboración borrador del Informe de Evaluación Técnica (IET) |  | 10d | 2016-10-11 | 2016-10-25 | 351 | 2016-04-18 | 2016-04-29 | 226d | 0d |
| 353 | 3.2.3.3.1.16 | Reunion Comité de Evaluación |  | 1d | 2016-10-26 | 2016-10-26 | 352 | 2016-05-02 | 2016-05-02 | 226d | 0d |
| 354 | 3.2.3.3.1.21 | Solicitud de No Objeción del Banco al Informe de Evaluación Técnica (IET) de las propuestas |  | 1d | 2016-10-27 | 2016-10-27 | 353 | 2016-05-03 | 2016-05-03 | 226d | 0d |
| 355 | 3.2.3.3.1.22 | No Objeción del Banco al IET |  | 5d | 2016-10-28 | 2016-11-03 | 354 | 2016-05-04 | 2016-05-11 | 226d | 0d |
| 356 | 3.2.3.3.1.23 | Notificación del puntaje de la evaluación técnica a los proponentes y notificar simultáneamente a los que obtuvieron la calificación mínima necesaria e indicar la fecha, lugar y hora fijada para abrir las propuestas de precio. |  | 1d | 2016-11-04 | 2016-11-04 | 355 | 2016-05-12 | 2016-05-12 | 226d | 0d |
| 357 | 3.2.3.3.1.24 | Apertura de propuesta de precio en Audiencia Pública | milestone | 0d | 2016-11-15 | 2016-11-15 | 356FS+5d | 2016-05-19 | 2016-05-19 | 226d | 0d |
| 358 | 3.2.3.3.1.25 | Evaluación del Costo y Evaluación Combinada de la Calidad y el Costo |  | 1d | 2016-11-16 | 2016-11-16 | 357 | 2016-05-20 | 2016-05-20 | 226d | 0d |
| 359 | 3.2.3.3.1.26 | Notificación y negociación del contrato con el proponente seleccionado, elaboración del borrador del contrato negociado y solicitud de No Objeción Banco |  | 10d | 2016-11-17 | 2016-11-30 | 358 | 2016-05-23 | 2016-06-07 | 226d | 0d |
| 360 | 3.2.3.3.1.27 | No Objeción del Banco al borrador del contrato negociado y envio acta de apertura de sobres y evaluacion combinada |  | 5d | 2016-12-01 | 2016-12-07 | 359 | 2016-06-08 | 2016-06-14 | 226d | 0d |
| 361 | 3.2.3.3.1.28 | Notificación a las demás firmas incluidas en la lista corta que sus propuestas no fueron seleccionadas |  | 1d | 2016-12-09 | 2016-12-09 | 360 | 2016-06-15 | 2016-06-15 | 226d | 0d |
| 362 | 3.2.3.3.1.29 | Publicación de la Adjudicación del Contrato |  | 1d | 2016-12-12 | 2016-12-12 | 361 | 2016-06-16 | 2016-06-16 | 226d | 0d |
| 363 | 3.2.3.3.1.30 | Legalización y Firma del Contrato |  | 10d | 2016-12-13 | 2016-12-26 | 362 | 2016-06-17 | 2016-06-30 | 226d | 0d |
| 364 | 3.2.3.3.1.31 | Envio al Banco de una copia firmada del contrato |  | 1d | 2016-12-27 | 2016-12-27 | 363 | 2016-07-01 | 2016-07-01 | 1030d |  |

| ID | WBS | Task | Type | Duration | Start | Finish | Predecessors | Baseline 1 start | Baseline 1 finish | Total slack | Free slack |
| --- | --- | --- | --- | --- | --- | --- | --- | --- | --- | --- | --- |
| 365 | 3.2.4.47 | **Contractual** |  | 725d | 2016-12-27 | 2019-11-22 |  | 2016-07-01 | 2019-06-07 | 226d |  |
| 366 | 3.2.3.3.2.1 | Acta de inicio |  | 5d | 2016-12-27 | 2017-01-02 | 363 | 2016-07-01 | 2016-07-08 | 226d | 0d |
| 367 | 3.5.4.2.2.2 | Diseno e implementacion de las estrategias especificas de gestion del cambio. SBCC |  | 36mo | 2017-01-03 | 2019-11-22 | 366 | 2016-07-11 | 2019-06-07 | 226d | 0d |
| 368 | 3.5.4.2.3 | **Cierre** |  | 80d | 2019-11-25 | 2020-03-13 |  | 2019-06-10 | 2019-09-27 | 226d |  |
| 369 | 3.5.4.2.3.1 | Liquidación del contrato |  | 4mo | 2019-11-25 | 2020-03-13 | 367 | 2019-06-10 | 2019-09-27 | 226d |  |
| 370 | 3.5.4.3 | **Consultoria: Diseno e implementacion de un modelo de gestion del conocimiento a partir de los 4 procesos misionales definidos. SBCC** |  | 348d | 2017-11-03 | 2019-04-03 |  | 2016-11-11 | 2018-04-03 | 471d |  |
| 371 | 3.2.3.3.1 | **Precontractual** |  | 144d | 2017-11-03 | 2018-06-08 |  | 2016-11-11 | 2017-05-30 | 471d |  |
| 372 | 3.2.3.3.1.1 | Elaboración de los términos de referencia (TR) |  | 10d | 2017-11-03 | 2017-11-20 | 46FS+27mo | 2016-11-11 | 2016-11-25 | 471d | 0d |
| 373 | 3.2.3.3.1.3 | Preparación de la estimación de costos y presupuesto (Estudio de mercado) |  | 10d | 2017-11-21 | 2017-12-04 | 372 | 2016-11-28 | 2016-12-12 | 471d | 0d |
| 374 | 3.2.3.3.1.4 | Elaboración del Aviso Específico de Adquisiciones (AEA) solicitando expresiones de interés y solicitud de No Objeción al Banco |  | 2d | 2017-12-05 | 2017-12-06 | 373 | 2016-12-13 | 2016-12-14 | 471d | 0d |
| 375 | 3.2.3.3.1.5 | No Objeción del Banco al AEA |  | 5d | 2017-12-07 | 2017-12-14 | 374 | 2016-12-15 | 2016-12-21 | 471d | 0d |
| 376 | 3.2.3.3.1.6 | Publicación del AEA en SECOP (los contratos de valor mayor al equivalente de US $200.000 se deben anunciar ademas en los sitios de Internet del UNDB online y del Banco) |  | 2d | 2017-12-15 | 2017-12-18 | 375 | 2016-12-22 | 2016-12-23 | 471d | 0d |
| 377 | 3.2.3.3.1.7 | Recepción de expresiones de interés | milestone | 0d | 2018-01-17 | 2018-01-17 | 376FS+30ed | 2017-01-06 | 2017-01-06 | 473d | 0d |
| 378 | 3.2.3.3.1.8 | Evaluación de Expresiones de Interés recibidas y conformación de lista corta |  | 10d | 2018-01-18 | 2018-01-31 | 377 | 2017-01-10 | 2017-01-23 | 763d |  |
| 379 | 3.2.3.3.1.9 | Elaboración de la Solicitud de Propuesta (SP) que incluye: (a) la Carta de Invitación a las firmas de la lista corta; (b) las Instrucciones a los Consultores; © los TR; y (d) el contrato propuesto; y solicitud de No Objeción al Banco |  | 15d | 2018-01-18 | 2018-02-07 | 377 | 2017-01-10 | 2017-01-30 | 473d | 0d |
| 380 | 3.2.3.3.1.10 | No Objeción del Banco a la SP y conformacion Lista Corta |  | 5d | 2018-02-08 | 2018-02-14 | 379 | 2017-01-31 | 2017-02-06 | 473d | 0d |
| 381 | 3.2.3.3.1.11 | Envio de Solicitud de Propuestas (SP) a los integrantes de la lista corta (Invitación a presentar propuestas) |  | 2d | 2018-02-15 | 2018-02-16 | 380 | 2017-02-07 | 2017-02-08 | 473d | 0d |
| 382 | 3.2.3.3.1.12 | Reunión aclaratoria (eventual a los diez días de la invitación) | milestone | 0d | 2018-03-02 | 2018-03-02 | 381FS+10d | 2017-02-22 | 2017-02-22 | 473d | 0d |
| 383 | 3.2.3.3.1.13 | Preparación de respuestas a las solicitudes de aclaraciones de los oferentes y solicitud de No Objeción al Banco |  | 3d | 2018-03-05 | 2018-03-07 | 382 | 2017-02-23 | 2017-02-27 | 473d | 0d |
| 384 | 3.2.3.3.1.14 | No objeción del Banco a las respuestas de aclaraciones |  | 5d | 2018-03-08 | 2018-03-14 | 383 | 2017-02-28 | 2017-03-06 | 473d | 0d |
| 385 | 3.2.3.3.1.15 | Respuesta a las solicitudes de aclaración antes de la recepción de propuestas |  | 3d | 2018-03-15 | 2018-03-20 | 384 | 2017-03-07 | 2017-03-09 | 473d | 0d |
| 386 | 3.2.3.3.1.17 | Designación del Comité de Evaluación |  | 1d | 2018-03-21 | 2018-03-21 | 385 | 2017-03-10 | 2017-03-10 | 473d | 0d |
| 387 | 3.2.3.3.1.18 | Recepción de las Propuestas técnicas y de precio y Apertura de propuestas técnicas | milestone | 0d | 2018-03-16 | 2018-03-16 | 381FS+4w | 2017-03-08 | 2017-03-08 | 475d | 2d |
| 388 | 3.2.3.3.1.19 | Envío de propuestas al Comité de Evaluación y al Especialista en Adquisiciones | milestone | 0d | 2018-03-21 | 2018-03-21 | 386, 387 | 2017-03-10 | 2017-03-10 | 473d | 0d |
| 389 | 3.2.3.3.1.20 | Evaluación de propuestas técnicas y elaboración borrador del Informe de Evaluación Técnica (IET) |  | 10d | 2018-03-22 | 2018-04-06 | 388 | 2017-03-13 | 2017-03-27 | 473d | 0d |
| 390 | 3.2.3.3.1.16 | Reunion Comité de Evaluación |  | 1d | 2018-04-09 | 2018-04-09 | 389 | 2017-03-28 | 2017-03-28 | 473d | 0d |
| 391 | 3.2.3.3.1.21 | Solicitud de No Objeción del Banco al Informe de Evaluación Técnica (IET) de las propuestas |  | 1d | 2018-04-10 | 2018-04-10 | 390 | 2017-03-29 | 2017-03-29 | 473d | 0d |
| 392 | 3.2.3.3.1.22 | No Objeción del Banco al IET |  | 5d | 2018-04-11 | 2018-04-17 | 391 | 2017-03-30 | 2017-04-05 | 473d | 0d |
| 393 | 3.2.3.3.1.23 | Notificación del puntaje de la evaluación técnica a los proponentes y notificar simultáneamente a los que obtuvieron la calificación mínima necesaria e indicar la fecha, lugar y hora fijada para abrir las propuestas de precio. |  | 1d | 2018-04-18 | 2018-04-18 | 392 | 2017-04-06 | 2017-04-06 | 473d | 0d |
| 394 | 3.2.3.3.1.24 | Apertura de propuesta de precio en Audiencia Pública | milestone | 0d | 2018-04-25 | 2018-04-25 | 393FS+5d | 2017-04-17 | 2017-04-17 | 473d | 0d |
| 395 | 3.2.3.3.1.25 | Evaluación del Costo y Evaluación Combinada de la Calidad y el Costo |  | 1d | 2018-04-26 | 2018-04-26 | 394 | 2017-04-18 | 2017-04-18 | 473d | 0d |
| 396 | 3.2.3.3.1.26 | Notificación y negociación del contrato con el proponente seleccionado, elaboración del borrador del contrato negociado y solicitud de No Objeción Banco |  | 10d | 2018-04-27 | 2018-05-11 | 395 | 2017-04-19 | 2017-05-03 | 473d | 0d |
| 397 | 3.2.3.3.1.27 | No Objeción del Banco al borrador del contrato negociado y envio acta de apertura de sobres y evaluacion combinada |  | 5d | 2018-05-15 | 2018-05-21 | 396 | 2017-05-04 | 2017-05-10 | 473d | 0d |
| 398 | 3.2.3.3.1.28 | Notificación a las demás firmas incluidas en la lista corta que sus propuestas no fueron seleccionadas |  | 1d | 2018-05-22 | 2018-05-22 | 397 | 2017-05-11 | 2017-05-11 | 473d | 0d |
| 399 | 3.2.3.3.1.29 | Publicación de la Adjudicación del Contrato |  | 1d | 2018-05-23 | 2018-05-23 | 398 | 2017-05-12 | 2017-05-12 | 473d | 0d |
| 400 | 3.2.3.3.1.30 | Legalización y Firma del Contrato |  | 10d | 2018-05-24 | 2018-06-07 | 399 | 2017-05-15 | 2017-05-26 | 473d | 0d |
| 401 | 3.2.3.3.1.31 | Envio al Banco de una copia firmada del contrato |  | 1d | 2018-06-08 | 2018-06-08 | 400 | 2017-05-30 | 2017-05-30 | 677d |  |

| ID | WBS | Task | Type | Duration | Start | Finish | Predecessors | Baseline 1 start | Baseline 1 finish | Total slack | Free slack |
| --- | --- | --- | --- | --- | --- | --- | --- | --- | --- | --- | --- |
| 402 | 3.2.4.47 | **Contractual** |  | 125d | 2018-06-08 | 2018-12-11 |  | 2017-05-30 | 2017-12-01 | 473d |  |
| 403 | 3.2.3.3.2.1 | Acta de inicio |  | 5d | 2018-06-08 | 2018-06-15 | 400 | 2017-05-30 | 2017-06-05 | 473d | 0d |
| 404 | 3.5.4.3.2.2 | Diseno e implementacion del modelo de gestion del conocimiento. |  | 6mo | 2018-06-18 | 2018-12-11 | 403 | 2017-06-06 | 2017-12-01 | 473d | 0d |
| 405 | 3.5.4.3.3 | **Cierre** |  | 80d | 2018-12-12 | 2019-04-03 |  | 2017-12-04 | 2018-04-03 | 473d |  |
| 406 | 3.5.4.3.3.1 | Liquidación del contrato |  | 4mo | 2018-12-12 | 2019-04-03 | 404 | 2017-12-04 | 2018-04-03 | 473d |  |
| 407 | 3.5.5 | **Producto 5 - Observatorio de Gasto Público disenado e implementado** |  | 627d | 2015-02-16 | 2017-09-08 |  | 2015-02-16 | 2017-09-08 | 859d |  |
| 408 | 3.5.5.1 | **Consultoria: Diseño conceptual y metodologico del Observatorio de Gasto Público. SCC** |  | 225d | 2015-10-22 | 2016-09-21 |  | 2015-06-25 | 2016-04-26 | 1094d |  |
| 409 | 3.5.5.1.1 | **Precontractual** |  | 84d | 2015-10-22 | 2016-02-24 |  | 2015-06-25 | 2015-09-28 | 1094d |  |
| 410 | 3.5.5.1.1.1 | Elaboración de los TR |  | 1d | 2015-10-22 | 2015-10-22 | 16FS+4mo | 2015-06-25 | 2015-06-25 | 1094d | 0d |
| 411 | 3.5.5.1.1.2 | Estimado de costos y presupuesto |  | 1d | 2015-10-23 | 2015-10-23 | 410 | 2015-06-26 | 2015-06-26 | 1094d | 0d |
| 412 | 3.5.5.1.1.3 | No objeción del Banco a los TR |  | 5d | 2015-10-26 | 2015-10-30 | 411 | 2015-06-30 | 2015-07-06 | 1094d | 0d |
| 413 | 3.5.5.1.1.4 | Elaboración del Aviso Específico de Adquisiciones (AEA) solicitando Expresiones de Interés (EI) |  | 2d | 2015-11-03 | 2015-11-04 | 412 | 2015-07-07 | 2015-07-08 | 1094d | 0d |
| 414 | 3.5.5.1.1.5 | No Objeción del Banco al AEA |  | 5d | 2015-11-05 | 2015-11-11 | 413 | 2015-07-09 | 2015-07-15 | 1094d | 0d |
| 415 | 3.5.5.1.1.6 | Publicación del AEA en SECOP |  | 2d | 2015-11-12 | 2015-11-13 | 414 | 2015-07-16 | 2015-07-17 | 1094d | 0d |
| 416 | 3.5.5.1.1.7 | Recepción de Expresiones de Interés | milestone | 0d | 2015-11-27 | 2015-11-27 | 415FS+14ed | 2015-07-31 | 2015-07-31 | 1095d | 0d |
| 417 | 3.5.5.1.1.8 | Evaluación de EI recibidas y conformación de lista corta ordenada por Orden de Merito |  | 5d | 2015-11-30 | 2015-12-04 | 416 | 2015-08-03 | 2015-08-10 | 1095d | 0d |
| 418 | 3.5.5.1.1.9 | Elaboracion de la Solicitud de Propuestas (SP) |  | 5d | 2015-11-30 | 2015-12-04 | 416 | 2015-08-03 | 2015-08-10 | 1095d | 0d |
| 419 | 3.5.5.1.1.10 | No Objeción del Banco a la lista corta rankeada y SP |  | 5d | 2015-12-07 | 2015-12-14 | 417, 418 | 2015-08-11 | 2015-08-18 | 1095d | 0d |
| 420 | 3.5.5.1.1.11 | Invitación a presentar propuesta tecnica y economica solo a la Firma Consultora (FC) rankeada en 1º lugar |  | 2d | 2016-01-15 | 2016-01-18 | 419FS+20d | 2015-08-19 | 2015-08-20 | 1095d | 0d |
| 421 | 3.5.5.1.1.12 | Recepción de propuesta de la FC invitada | milestone | 0d | 2016-02-01 | 2016-02-01 | 420FS+2w | 2015-09-03 | 2015-09-03 | 1095d | 0d |
| 422 | 3.5.5.1.1.13 | Evaluación de la propuesta y negociación del contrato |  | 5d | 2016-02-02 | 2016-02-08 | 421 | 2015-09-04 | 2015-09-10 | 1095d | 0d |
| 423 | 3.5.5.1.1.14 | No Objeción del Banco al contrato negociado y rubricado |  | 5d | 2016-02-09 | 2016-02-15 | 422 | 2015-09-11 | 2015-09-17 | 1095d | 0d |
| 424 | 3.5.5.1.1.15 | Publicar el nombre del consultor al cual se le adjudicó el contrato, |  | 2d | 2016-02-16 | 2016-02-17 | 423 | 2015-09-18 | 2015-09-21 | 1095d | 0d |
| 425 | 3.5.5.1.1.16 | Firma del contrato y envío del contrato al Banco para registro |  | 5d | 2016-02-18 | 2016-02-24 | 424 | 2015-09-22 | 2015-09-28 | 1095d | 0d |

Notes:
- 418: Modelo Base SP bajo la modalidad SCC

| ID | WBS | Task | Type | Duration | Start | Finish | Predecessors | Baseline 1 start | Baseline 1 finish | Total slack | Free slack |
| --- | --- | --- | --- | --- | --- | --- | --- | --- | --- | --- | --- |
| 426 | 3.2.4.47 | **Contractual** |  | 61d | 2016-02-25 | 2016-05-25 |  | 2015-09-29 | 2015-12-29 | 1095d |  |
| 427 | 3.2.3.3.2.1 | Acta de inicio |  | 1d | 2016-02-25 | 2016-02-25 | 425 | 2015-09-29 | 2015-09-29 | 1095d | 0d |
| 428 | 3.5.5.1.2.2 | Diseño conceptual y metodologico del Observatorio de Gasto Público. |  | 3mo | 2016-02-26 | 2016-05-25 | 427 | 2015-09-30 | 2015-12-29 | 1095d | 0d |
| 429 | 3.5.5.1.3 | **Cierre** |  | 80d | 2016-05-26 | 2016-09-21 |  | 2015-12-30 | 2016-04-26 | 1095d |  |
| 430 | 3.5.5.1.3.1 | Liquidacion de contrato |  | 4mo | 2016-05-26 | 2016-09-21 | 428 | 2015-12-30 | 2016-04-26 | 1095d |  |
| 431 | 3.5.5.2 | **Consultoria: Diseno e implementacion de un piloto de Regalias para el OGP. SBCC** |  | 458d | 2015-02-16 | 2016-12-29 |  | 2015-02-16 | 2016-12-29 | 1028d |  |
| 432 | 3.2.3.3.1 | **Precontractual** |  | 132d | 2015-12-16 | 2016-06-29 |  | 2015-12-16 | 2016-06-29 | 1028d |  |
| 433 | 3.2.3.3.1.1 | Elaboración de los términos de referencia (TR) |  | 15d | 2015-12-16 | 2016-01-07 | 188 | 2015-12-16 | 2016-01-07 | 1028d | 0d |
| 434 | 3.2.3.3.1.3 | Preparación de la estimación de costos y presupuesto (Estudio de mercado) |  | 5d | 2016-01-08 | 2016-01-15 | 433 | 2016-01-08 | 2016-01-15 | 1028d | 0d |
| 435 | 3.2.3.3.1.4 | Elaboración del Aviso Específico de Adquisiciones (AEA) solicitando expresiones de interés y solicitud de No Objeción al Banco |  | 1d | 2016-01-18 | 2016-01-18 | 434 | 2016-01-18 | 2016-01-18 | 1028d | 0d |
| 436 | 3.2.3.3.1.5 | No Objeción del Banco al AEA |  | 5d | 2016-01-19 | 2016-01-25 | 435 | 2016-01-19 | 2016-01-25 | 1028d | 0d |
| 437 | 3.2.3.3.1.6 | Publicación del AEA en SECOP (los contratos de valor mayor al equivalente de US $200.000 se deben anunciar ademas en los sitios de Internet del UNDB online y del Banco) |  | 2d | 2016-01-26 | 2016-01-27 | 436 | 2016-01-26 | 2016-01-27 | 1028d | 0d |
| 438 | 3.2.3.3.1.7 | Recepción de expresiones de interés | milestone | 0d | 2016-02-10 | 2016-02-10 | 437FS+14ed | 2016-02-10 | 2016-02-10 | 1028d | 0d |
| 439 | 3.2.3.3.1.8 | Evaluación de Expresiones de Interés recibidas y conformación de lista corta |  | 10d | 2016-02-11 | 2016-02-24 | 438 | 2016-02-11 | 2016-02-24 | 1236d |  |
| 440 | 3.2.3.3.1.9 | Elaboración de la Solicitud de Propuesta (SP) que incluye: (a) la Carta de Invitación a las firmas de la lista corta; (b) las Instrucciones a los Consultores; © los TR; y (d) el contrato propuesto; y solicitud de No Objeción al Banco |  | 15d | 2016-02-11 | 2016-03-02 | 438 | 2016-02-11 | 2016-03-02 | 1028d | 0d |
| 441 | 3.2.3.3.1.10 | No Objeción del Banco a la SP y conformacion Lista Corta |  | 5d | 2016-03-03 | 2016-03-09 | 440 | 2016-03-03 | 2016-03-09 | 1028d | 0d |
| 442 | 3.2.3.3.1.11 | Envio de Solicitud de Propuestas (SP) a los integrantes de la lista corta (Invitación a presentar propuestas) |  | 2d | 2016-03-10 | 2016-03-11 | 441 | 2016-03-10 | 2016-03-11 | 1028d | 0d |
| 443 | 3.2.3.3.1.12 | Reunión aclaratoria (eventual a los diez días de la invitación) | milestone | 0d | 2016-03-30 | 2016-03-30 | 442FS+10d | 2016-03-30 | 2016-03-30 | 1028d | 0d |
| 444 | 3.2.3.3.1.13 | Preparación de respuestas a las solicitudes de aclaraciones de los oferentes y solicitud de No Objeción al Banco |  | 3d | 2016-03-31 | 2016-04-04 | 443 | 2016-03-31 | 2016-04-04 | 1028d | 0d |
| 445 | 3.2.3.3.1.14 | No objeción del Banco a las respuestas de aclaraciones |  | 5d | 2016-04-05 | 2016-04-11 | 444 | 2016-04-05 | 2016-04-11 | 1028d | 0d |
| 446 | 3.2.3.3.1.15 | Respuesta a las solicitudes de aclaración antes de la recepción de propuestas |  | 1d | 2016-04-12 | 2016-04-12 | 445 | 2016-04-12 | 2016-04-12 | 1028d | 0d |
| 447 | 3.2.3.3.1.17 | Designación del Comité de Evaluación |  | 1d | 2016-04-13 | 2016-04-13 | 446 | 2016-04-13 | 2016-04-13 | 1028d | 0d |
| 448 | 3.2.3.3.1.18 | Recepción de las Propuestas técnicas y de precio y Apertura de propuestas técnicas | milestone | 0d | 2016-04-13 | 2016-04-13 | 442FS+4w | 2016-04-13 | 2016-04-13 | 1028d | 0d |
| 449 | 3.2.3.3.1.19 | Envío de propuestas al Comité de Evaluación y al Especialista en Adquisiciones | milestone | 0d | 2016-04-13 | 2016-04-13 | 447, 448 | 2016-04-13 | 2016-04-13 | 1028d | 0d |
| 450 | 3.2.3.3.1.20 | Evaluación de propuestas técnicas y elaboración borrador del Informe de Evaluación Técnica (IET) |  | 10d | 2016-04-14 | 2016-04-27 | 449 | 2016-04-14 | 2016-04-27 | 1028d | 0d |
| 451 | 3.2.3.3.1.16 | Reunion Comité de Evaluación |  | 1d | 2016-04-28 | 2016-04-28 | 450 | 2016-04-28 | 2016-04-28 | 1028d | 0d |
| 452 | 3.2.3.3.1.21 | Solicitud de No Objeción del Banco al Informe de Evaluación Técnica (IET) de las propuestas |  | 1d | 2016-04-29 | 2016-04-29 | 451 | 2016-04-29 | 2016-04-29 | 1028d | 0d |
| 453 | 3.2.3.3.1.22 | No Objeción del Banco al IET |  | 5d | 2016-05-02 | 2016-05-06 | 452 | 2016-05-02 | 2016-05-06 | 1028d | 0d |
| 454 | 3.2.3.3.1.23 | Notificación del puntaje de la evaluación técnica a los proponentes y notificar simultáneamente a los que obtuvieron la calificación mínima necesaria e indicar la fecha, lugar y hora fijada para abrir las propuestas de precio. |  | 1d | 2016-05-10 | 2016-05-10 | 453 | 2016-05-10 | 2016-05-10 | 1028d | 0d |
| 455 | 3.2.3.3.1.24 | Apertura de propuesta de precio en Audiencia Pública | milestone | 0d | 2016-05-17 | 2016-05-17 | 454FS+5d | 2016-05-17 | 2016-05-17 | 1028d | 0d |
| 456 | 3.2.3.3.1.25 | Evaluación del Costo y Evaluación Combinada de la Calidad y el Costo |  | 1d | 2016-05-18 | 2016-05-18 | 455 | 2016-05-18 | 2016-05-18 | 1028d | 0d |
| 457 | 3.2.3.3.1.26 | Notificación y negociación del contrato con el proponente seleccionado, elaboración del borrador del contrato negociado y solicitud de No Objeción Banco |  | 10d | 2016-05-19 | 2016-06-02 | 456 | 2016-05-19 | 2016-06-02 | 1028d | 0d |
| 458 | 3.2.3.3.1.27 | No Objeción del Banco al borrador del contrato negociado y envio acta de apertura de sobres y evaluacion combinada |  | 5d | 2016-06-03 | 2016-06-10 | 457 | 2016-06-03 | 2016-06-10 | 1028d | 0d |
| 459 | 3.2.3.3.1.28 | Notificación a las demás firmas incluidas en la lista corta que sus propuestas no fueron seleccionadas |  | 1d | 2016-06-13 | 2016-06-13 | 458 | 2016-06-13 | 2016-06-13 | 1028d | 0d |
| 460 | 3.2.3.3.1.29 | Publicación de la Adjudicación del Contrato |  | 1d | 2016-06-14 | 2016-06-14 | 459 | 2016-06-14 | 2016-06-14 | 1028d | 0d |
| 461 | 3.2.3.3.1.30 | Legalización y Firma del Contrato |  | 10d | 2016-06-15 | 2016-06-28 | 460 | 2016-06-15 | 2016-06-28 | 1028d | 0d |
| 462 | 3.2.3.3.1.31 | Envio al Banco de una copia firmada del contrato |  | 1d | 2016-06-29 | 2016-06-29 | 461 | 2016-06-29 | 2016-06-29 | 1152d |  |

| ID | WBS | Task | Type | Duration | Start | Finish | Predecessors | Baseline 1 start | Baseline 1 finish | Total slack | Free slack |
| --- | --- | --- | --- | --- | --- | --- | --- | --- | --- | --- | --- |
| 463 | 3.2.4.47 | **Contractual** |  | 125d | 2016-06-29 | 2016-12-29 |  | 2016-06-29 | 2016-12-29 | 1028d |  |
| 464 | 3.2.3.3.2.1 | Acta de inicio |  | 5d | 2016-06-29 | 2016-07-06 | 461 | 2016-06-29 | 2016-07-06 | 1028d | 0d |
| 465 | 3.5.5.2.2.2 | Proyecto Piloto de Regalias para el OGP disenado e implementado |  | 6mo | 2016-07-07 | 2016-12-29 | 464 | 2016-07-07 | 2016-12-29 | 1028d |  |
| 466 | 3.5.5.2.3 | **Cierre** |  | 80d | 2015-02-16 | 2015-06-16 |  | 2015-02-16 | 2015-06-16 | 1406d |  |
| 467 | 3.5.5.2.3.1 | Liquidación del contrato |  | 4mo | 2015-02-16 | 2015-06-16 |  | 2015-02-16 | 2015-06-16 | 1406d |  |
| 468 | 3.5.5.3 | **Consultoria: Diseno e implementacion de instrumentos informaticos para el OGP conforme al modelo conceptual y metodologico del sistema. SBCC** |  | 362d | 2016-03-17 | 2017-09-08 |  | 2016-03-17 | 2017-09-08 | 859d |  |
| 469 | 3.2.3.3.1 | **Precontractual** |  | 118d | 2016-03-17 | 2016-09-09 |  | 2016-03-17 | 2016-09-09 | 859d |  |
| 470 | 3.2.3.3.1.1 | Elaboración de los términos de referencia (TR) |  | 1d | 2016-03-17 | 2016-03-17 | 46FS+7mo | 2016-03-17 | 2016-03-17 | 859d | 0d |
| 471 | 3.2.3.3.1.3 | Preparación de la estimación de costos y presupuesto (Estudio de mercado) |  | 5d | 2016-03-18 | 2016-03-29 | 470 | 2016-03-18 | 2016-03-29 | 859d | 0d |
| 472 | 3.5.5.3.1.3 | Solicitud de Vigencias Futuras 2017 | milestone | 0d | 2016-03-29 | 2016-03-29 | 471 | 2016-03-29 | 2016-03-29 | 897d | 38d |
| 473 | 3.2.3.3.1.4 | Elaboración del Aviso Específico de Adquisiciones (AEA) solicitando expresiones de interés y solicitud de No Objeción al Banco |  | 1d | 2016-03-30 | 2016-03-30 | 471 | 2016-03-30 | 2016-03-30 | 859d | 0d |
| 474 | 3.2.3.3.1.5 | No Objeción del Banco al AEA |  | 5d | 2016-03-31 | 2016-04-06 | 473 | 2016-03-31 | 2016-04-06 | 859d | 0d |
| 475 | 3.2.3.3.1.6 | Publicación del AEA en SECOP (los contratos de valor mayor al equivalente de US $200.000 se deben anunciar ademas en los sitios de Internet del UNDB online y del Banco) |  | 2d | 2016-04-07 | 2016-04-08 | 474 | 2016-04-07 | 2016-04-08 | 859d | 0d |
| 476 | 3.2.3.3.1.7 | Recepción de expresiones de interés | milestone | 0d | 2016-04-22 | 2016-04-22 | 475FS+14ed | 2016-04-22 | 2016-04-22 | 859d | 0d |
| 477 | 3.2.3.3.1.8 | Evaluación de Expresiones de Interés recibidas y conformación de lista corta |  | 10d | 2016-04-25 | 2016-05-06 | 476 | 2016-04-25 | 2016-05-06 | 1187d |  |
| 478 | 3.2.3.3.1.9 | Elaboración de la Solicitud de Propuesta (SP) que incluye: (a) la Carta de Invitación a las firmas de la lista corta; (b) las Instrucciones a los Consultores; © los TR; y (d) el contrato propuesto; y solicitud de No Objeción al Banco |  | 15d | 2016-04-25 | 2016-05-16 | 476 | 2016-04-25 | 2016-05-16 | 859d | 0d |
| 479 | 3.2.3.3.1.10 | No Objeción del Banco a la SP y conformacion Lista Corta |  | 5d | 2016-05-17 | 2016-05-23 | 478 | 2016-05-17 | 2016-05-23 | 859d | 0d |
| 480 | 3.5.5.3.1.11 | Solicitud vigencias futuras 2017 | milestone | 0d | 2016-07-22 | 2016-07-22 | 479FS+2mo |  |  | 1137d |  |
| 481 | 3.2.3.3.1.11 | Envio de Solicitud de Propuestas (SP) a los integrantes de la lista corta (Invitación a presentar propuestas) |  | 2d | 2016-05-24 | 2016-05-25 | 472, 479 | 2016-05-24 | 2016-05-25 | 859d | 0d |
| 482 | 3.2.3.3.1.12 | Reunión aclaratoria (eventual a los diez días de la invitación) | milestone | 0d | 2016-06-10 | 2016-06-10 | 481FS+10d | 2016-06-10 | 2016-06-10 | 859d | 0d |
| 483 | 3.2.3.3.1.13 | Preparación de respuestas a las solicitudes de aclaraciones de los oferentes y solicitud de No Objeción al Banco |  | 3d | 2016-06-13 | 2016-06-15 | 482 | 2016-06-13 | 2016-06-15 | 859d | 0d |
| 484 | 3.2.3.3.1.14 | No objeción del Banco a las respuestas de aclaraciones |  | 5d | 2016-06-16 | 2016-06-22 | 483 | 2016-06-16 | 2016-06-22 | 859d | 0d |
| 485 | 3.2.3.3.1.15 | Respuesta a las solicitudes de aclaración antes de la recepción de propuestas |  | 1d | 2016-06-23 | 2016-06-23 | 484 | 2016-06-23 | 2016-06-23 | 859d | 0d |
| 486 | 3.2.3.3.1.17 | Designación del Comité de Evaluación |  | 1d | 2016-06-24 | 2016-06-24 | 485 | 2016-06-24 | 2016-06-24 | 859d | 0d |
| 487 | 3.2.3.3.1.18 | Recepción de las Propuestas técnicas y de precio y Apertura de propuestas técnicas | milestone | 0d | 2016-06-24 | 2016-06-24 | 481FS+4w | 2016-06-24 | 2016-06-24 | 859d | 0d |
| 488 | 3.2.3.3.1.19 | Envío de propuestas al Comité de Evaluación y al Especialista en Adquisiciones | milestone | 0d | 2016-06-24 | 2016-06-24 | 486, 487 | 2016-06-24 | 2016-06-24 | 859d | 0d |
| 489 | 3.2.3.3.1.20 | Evaluación de propuestas técnicas y elaboración borrador del Informe de Evaluación Técnica (IET) |  | 10d | 2016-06-27 | 2016-07-11 | 488 | 2016-06-27 | 2016-07-11 | 859d | 0d |
| 490 | 3.2.3.3.1.16 | Reunion Comité de Evaluación |  | 1d | 2016-07-12 | 2016-07-12 | 489 | 2016-07-12 | 2016-07-12 | 859d | 0d |
| 491 | 3.2.3.3.1.21 | Solicitud de No Objeción del Banco al Informe de Evaluación Técnica (IET) de las propuestas |  | 1d | 2016-07-13 | 2016-07-13 | 490 | 2016-07-13 | 2016-07-13 | 859d | 0d |
| 492 | 3.2.3.3.1.22 | No Objeción del Banco al IET |  | 5d | 2016-07-14 | 2016-07-21 | 491 | 2016-07-14 | 2016-07-21 | 859d | 0d |
| 493 | 3.2.3.3.1.23 | Notificación del puntaje de la evaluación técnica a los proponentes y notificar simultáneamente a los que obtuvieron la calificación mínima necesaria e indicar la fecha, lugar y hora fijada para abrir las propuestas de precio. |  | 1d | 2016-07-22 | 2016-07-22 | 492 | 2016-07-22 | 2016-07-22 | 859d | 0d |
| 494 | 3.2.3.3.1.24 | Apertura de propuesta de precio en Audiencia Pública | milestone | 0d | 2016-07-29 | 2016-07-29 | 493FS+5d | 2016-07-29 | 2016-07-29 | 859d | 0d |
| 495 | 3.2.3.3.1.25 | Evaluación del Costo y Evaluación Combinada de la Calidad y el Costo |  | 1d | 2016-08-01 | 2016-08-01 | 494 | 2016-08-01 | 2016-08-01 | 859d | 0d |
| 496 | 3.2.3.3.1.26 | Notificación y negociación del contrato con el proponente seleccionado, elaboración del borrador del contrato negociado y solicitud de No Objeción Banco |  | 10d | 2016-08-02 | 2016-08-16 | 495 | 2016-08-02 | 2016-08-16 | 859d | 0d |
| 497 | 3.2.3.3.1.27 | No Objeción del Banco al borrador del contrato negociado y envio acta de apertura de sobres y evaluacion combinada |  | 5d | 2016-08-17 | 2016-08-23 | 496 | 2016-08-17 | 2016-08-23 | 859d | 0d |
| 498 | 3.2.3.3.1.28 | Notificación a las demás firmas incluidas en la lista corta que sus propuestas no fueron seleccionadas |  | 1d | 2016-08-24 | 2016-08-24 | 497 | 2016-08-24 | 2016-08-24 | 859d | 0d |
| 499 | 3.2.3.3.1.29 | Publicación de la Adjudicación del Contrato |  | 1d | 2016-08-25 | 2016-08-25 | 498 | 2016-08-25 | 2016-08-25 | 859d | 0d |
| 500 | 3.2.3.3.1.30 | Legalización y Firma del Contrato |  | 10d | 2016-08-26 | 2016-09-08 | 499 | 2016-08-26 | 2016-09-08 | 859d | 0d |
| 501 | 3.2.3.3.1.31 | Envio al Banco de una copia firmada del contrato |  | 1d | 2016-09-09 | 2016-09-09 | 500 | 2016-09-09 | 2016-09-09 | 1103d |  |

| ID | WBS | Task | Type | Duration | Start | Finish | Predecessors | Baseline 1 start | Baseline 1 finish | Total slack | Free slack |
| --- | --- | --- | --- | --- | --- | --- | --- | --- | --- | --- | --- |
| 502 | 3.2.4.47 | **Contractual** |  | 165d | 2016-09-09 | 2017-05-10 |  | 2016-09-09 | 2017-05-10 | 859d |  |
| 503 | 3.2.3.3.2.1 | Acta de inicio |  | 5d | 2016-09-09 | 2016-09-15 | 500 | 2016-09-09 | 2016-09-15 | 859d | 0d |
| 504 | 3.5.5.3.2.2 | Diseno e implementacion de los instrumentos informaticos requeridos para el OGP |  | 8mo | 2016-09-16 | 2017-05-10 | 503 | 2016-09-16 | 2017-05-10 | 859d | 0d |
| 505 | 3.5.5.3.3 | **Cierre** |  | 80d | 2017-05-11 | 2017-09-08 |  | 2017-05-11 | 2017-09-08 | 859d |  |
| 506 | 3.5.5.3.3.1 | Liquidación del contrato |  | 4mo | 2017-05-11 | 2017-09-08 | 504 | 2017-05-11 | 2017-09-08 | 859d |  |
| 507 | 3.5.6 | **Producto 6 - Modelo basico de control fiscal micro con normativa internacional NIA e ISSAI fortalecido** |  | 424d | 2015-11-30 | 2017-08-23 |  | 2015-11-30 | 2017-07-19 | 871d |  |
| 508 | 3.5.6.1 | **Consultoría: Fortalecimiento del modelo basico del control fiscal micro incorporando la normativa internacional NIA e ISSAI. SBCC** |  | 424d | 2015-11-30 | 2017-08-23 |  | 2015-11-30 | 2017-07-19 | 871d |  |
| 509 | 3.2.3.3.1 | **Precontractual** |  | 140d | 2015-11-30 | 2016-06-24 |  | 2015-11-30 | 2016-05-23 | 871d |  |
| 510 | 3.2.3.3.1.1 | Elaboración de los términos de referencia (TR) |  | 10d | 2015-11-30 | 2015-12-14 | 147 | 2015-11-30 | 2015-12-14 | 1285d |  |
| 511 | 3.2.3.3.1.3 | Preparación de la estimación de costos y presupuesto (Estudio de mercado) |  | 10d | 2015-11-30 | 2015-12-14 | 147 | 2015-11-30 | 2015-12-14 | 871d | 0d |
| 512 | 3.5.6.1.1.3 | Solicitud de Vigencias Futuras | milestone | 0d | 2016-01-14 | 2016-01-14 | 511FS+20d | 2015-12-14 | 2015-12-14 | 871d | 0d |
| 513 | 3.2.3.3.1.4 | Elaboración del Aviso Específico de Adquisiciones (AEA) solicitando expresiones de interés y solicitud de No Objeción al Banco |  | 2d | 2016-01-15 | 2016-01-18 | 512 | 2015-12-15 | 2015-12-16 | 871d | 0d |
| 514 | 3.2.3.3.1.5 | No Objeción del Banco al AEA |  | 5d | 2016-01-19 | 2016-01-25 | 513 | 2015-12-17 | 2015-12-23 | 871d | 0d |
| 515 | 3.2.3.3.1.6 | Publicación del AEA en SECOP (los contratos de valor mayor al equivalente de US $200.000 se deben anunciar ademas en los sitios de Internet del UNDB online y del Banco) |  | 2d | 2016-01-26 | 2016-01-27 | 514 | 2015-12-24 | 2015-12-28 | 871d | 0d |
| 516 | 3.2.3.3.1.7 | Recepción de expresiones de interés | milestone | 0d | 2016-02-10 | 2016-02-10 | 515FS+14ed | 2016-01-11 | 2016-01-11 | 871d | 0d |
| 517 | 3.2.3.3.1.8 | Evaluación de Expresiones de Interés recibidas y conformación de lista corta |  | 5d | 2016-02-11 | 2016-02-17 | 516 | 2016-01-12 | 2016-01-18 | 1241d |  |
| 518 | 3.2.3.3.1.9 | Elaboración de la Solicitud de Propuesta (SP) que incluye: (a) la Carta de Invitación a las firmas de la lista corta; (b) las Instrucciones a los Consultores; © los TR; y (d) el contrato propuesto; y solicitud de No Objeción al Banco |  | 10d | 2016-02-11 | 2016-02-24 | 516 | 2016-01-12 | 2016-01-25 | 871d | 0d |
| 519 | 3.2.3.3.1.10 | No Objeción del Banco a la SP y conformacion Lista Corta |  | 5d | 2016-02-25 | 2016-03-02 | 518 | 2016-01-26 | 2016-02-01 | 871d | 0d |
| 520 | 3.2.3.3.1.11 | Envio de Solicitud de Propuestas (SP) a los integrantes de la lista corta (Invitación a presentar propuestas) |  | 2d | 2016-03-03 | 2016-03-04 | 512, 519 | 2016-02-02 | 2016-02-03 | 871d | 0d |
| 521 | 3.2.3.3.1.12 | Reunión aclaratoria (eventual a los diez días de la invitación) | milestone | 0d | 2016-03-18 | 2016-03-18 | 520FS+10d | 2016-02-17 | 2016-02-17 | 871d | 0d |
| 522 | 3.2.3.3.1.13 | Preparación de respuestas a las solicitudes de aclaraciones de los oferentes y solicitud de No Objeción al Banco |  | 3d | 2016-03-22 | 2016-03-28 | 521 | 2016-02-18 | 2016-02-22 | 871d | 0d |
| 523 | 3.2.3.3.1.14 | No objeción del Banco a las respuestas de aclaraciones |  | 5d | 2016-03-29 | 2016-04-04 | 522 | 2016-02-23 | 2016-02-29 | 871d | 0d |
| 524 | 3.2.3.3.1.15 | Respuesta a las solicitudes de aclaración antes de la recepción de propuestas |  | 3d | 2016-04-05 | 2016-04-07 | 523 | 2016-03-01 | 2016-03-03 | 871d | 0d |
| 525 | 3.2.3.3.1.17 | Designación del Comité de Evaluación |  | 1d | 2016-04-08 | 2016-04-08 | 524 | 2016-03-04 | 2016-03-04 | 871d | 0d |
| 526 | 3.2.3.3.1.18 | Recepción de las Propuestas técnicas y de precio y Apertura de propuestas técnicas | milestone | 0d | 2016-04-06 | 2016-04-06 | 520FS+4w | 2016-03-02 | 2016-03-02 | 873d | 2d |
| 527 | 3.2.3.3.1.19 | Envío de propuestas al Comité de Evaluación y al Especialista en Adquisiciones | milestone | 0d | 2016-04-08 | 2016-04-08 | 525, 526 | 2016-03-04 | 2016-03-04 | 871d | 0d |
| 528 | 3.2.3.3.1.20 | Evaluación de propuestas técnicas y elaboración borrador del Informe de Evaluación Técnica (IET) |  | 10d | 2016-04-11 | 2016-04-22 | 527 | 2016-03-07 | 2016-03-18 | 871d | 0d |
| 529 | 3.2.3.3.1.16 | Reunion Comité de Evaluación |  | 1d | 2016-04-25 | 2016-04-25 | 528 | 2016-03-22 | 2016-03-22 | 871d | 0d |
| 530 | 3.2.3.3.1.21 | Solicitud de No Objeción del Banco al Informe de Evaluación Técnica (IET) de las propuestas |  | 1d | 2016-04-26 | 2016-04-26 | 529 | 2016-03-23 | 2016-03-23 | 871d | 0d |
| 531 | 3.2.3.3.1.22 | No Objeción del Banco al IET |  | 5d | 2016-04-27 | 2016-05-03 | 530 | 2016-03-28 | 2016-04-01 | 871d | 0d |
| 532 | 3.2.3.3.1.23 | Notificación del puntaje de la evaluación técnica a los proponentes y notificar simultáneamente a los que obtuvieron la calificación mínima necesaria e indicar la fecha, lugar y hora fijada para abrir las propuestas de precio. |  | 1d | 2016-05-04 | 2016-05-04 | 531 | 2016-04-04 | 2016-04-04 | 871d | 0d |
| 533 | 3.2.3.3.1.24 | Apertura de propuesta de precio en Audiencia Pública | milestone | 0d | 2016-05-12 | 2016-05-12 | 532FS+5d | 2016-04-11 | 2016-04-11 | 871d | 0d |
| 534 | 3.2.3.3.1.25 | Evaluación del Costo y Evaluación Combinada de la Calidad y el Costo |  | 1d | 2016-05-13 | 2016-05-13 | 533 | 2016-04-12 | 2016-04-12 | 871d | 0d |
| 535 | 3.2.3.3.1.26 | Notificación y negociación del contrato con el proponente seleccionado, elaboración del borrador del contrato negociado y solicitud de No Objeción Banco |  | 10d | 2016-05-16 | 2016-05-27 | 534 | 2016-04-13 | 2016-04-26 | 871d | 0d |
| 536 | 3.2.3.3.1.27 | No Objeción del Banco al borrador del contrato negociado y envio acta de apertura de sobres y evaluacion combinada |  | 5d | 2016-05-31 | 2016-06-07 | 535 | 2016-04-27 | 2016-05-03 | 871d | 0d |
| 537 | 3.2.3.3.1.28 | Notificación a las demás firmas incluidas en la lista corta que sus propuestas no fueron seleccionadas |  | 1d | 2016-06-08 | 2016-06-08 | 536 | 2016-05-04 | 2016-05-04 | 871d | 0d |
| 538 | 3.2.3.3.1.29 | Publicación de la Adjudicación del Contrato |  | 1d | 2016-06-09 | 2016-06-09 | 537 | 2016-05-05 | 2016-05-05 | 871d | 0d |
| 539 | 3.2.3.3.1.30 | Legalización y Firma del Contrato |  | 10d | 2016-06-10 | 2016-06-23 | 538 | 2016-05-06 | 2016-05-20 | 871d | 0d |
| 540 | 3.2.3.3.1.31 | Envio al Banco de una copia firmada del contrato |  | 1d | 2016-06-24 | 2016-06-24 | 539 | 2016-05-23 | 2016-05-23 | 1155d |  |

| ID | WBS | Task | Type | Duration | Start | Finish | Predecessors | Baseline 1 start | Baseline 1 finish | Total slack | Free slack |
| --- | --- | --- | --- | --- | --- | --- | --- | --- | --- | --- | --- |
| 541 | 3.2.4.47 | **Contractual** |  | 205d | 2016-06-24 | 2017-04-21 |  | 2016-05-23 | 2017-03-17 | 871d |  |
| 542 | 3.2.3.3.2.1 | Acta de inicio |  | 5d | 2016-06-24 | 2016-06-30 | 539 | 2016-05-23 | 2016-05-27 | 871d | 0d |
| 543 | 3.5.6.1.2.2 | Fortalecimiento del modelo basico del control fiscal micro incorporando la normativa internacional NIA e ISSA. |  | 4mo | 2016-07-01 | 2016-10-26 | 542 | 2016-05-31 | 2016-09-23 | 871d | 0d |
| 544 | 3.5.6.1.2.3 | Implementación del Modelo Básico de Control Fiscal fortalecido (Comprende gestión del cambio, capacitación y revisión de la práctica) |  | 5mo | 2016-10-27 | 2017-03-22 | 543 | 2016-09-26 | 2017-02-17 | 971d |  |
| 545 | 3.5.6.1.2.4 | Diseño y aplicación de tres (3) ejercicios piloto para implementar Modelos Especializados de Control Fiscal – MECF incorporando esquemas de auditorías tipo (Cumplimiento, Desempeño, Financiera) |  | 6mo | 2016-10-27 | 2017-04-21 | 543 | 2016-09-26 | 2017-03-17 | 871d | 0d |
| 546 | 3.5.6.1.3 | **Cierre** |  | 80d | 2017-04-24 | 2017-08-23 |  | 2017-03-21 | 2017-07-19 | 871d |  |
| 547 | 3.5.6.1.3.1 | Liquidación del contrato |  | 4mo | 2017-04-24 | 2017-08-23 | 545 | 2017-03-21 | 2017-07-19 | 871d |  |
| 548 | 3.5.7 | **Producto 7 - Modelo de operación para el Control Fiscal Macro diagnosticado y fortalecido.** |  | 250d | 2015-09-22 | 2016-09-27 |  | 2015-09-22 | 2016-09-27 | 1091d |  |
| 549 | 3.5.7.1 | **Consultoria: Definir el alcance y competencias de la función de control fiscal macro. SCC** |  | 250d | 2015-09-22 | 2016-09-27 |  | 2015-09-22 | 2016-09-27 | 1091d |  |
| 550 | 3.5.7.1.1 | **Precontractual** |  | 105d | 2015-09-22 | 2016-02-24 |  | 2015-09-22 | 2016-02-24 | 1091d |  |
| 551 | 3.5.7.1.1.1 | Elaboración de los TR |  | 1mo | 2015-09-22 | 2015-10-20 | 46FS+1mo | 2015-09-22 | 2015-10-20 | 1091d | 0d |
| 552 | 3.5.7.1.1.2 | Estimado de costos y presupuesto |  | 5d | 2015-10-21 | 2015-10-27 | 551 | 2015-10-21 | 2015-10-27 | 1091d | 0d |
| 553 | 3.5.7.1.1.3 | No objeción del Banco a los TR |  | 5d | 2015-10-28 | 2015-11-04 | 552 | 2015-10-28 | 2015-11-04 | 1091d | 0d |
| 554 | 3.5.7.1.1.4 | Elaboración del Aviso Específico de Adquisiciones (AEA) solicitando Expresiones de Interés (EI) |  | 2d | 2015-11-05 | 2015-11-06 | 553 | 2015-11-05 | 2015-11-06 | 1091d | 0d |
| 555 | 3.5.7.1.1.5 | No Objeción del Banco al AEA |  | 5d | 2015-11-09 | 2015-11-13 | 554 | 2015-11-09 | 2015-11-13 | 1091d | 0d |
| 556 | 3.5.7.1.1.6 | Publicación del AEA en SECOP |  | 2d | 2015-11-17 | 2015-11-18 | 555 | 2015-11-17 | 2015-11-18 | 1091d | 0d |
| 557 | 3.5.7.1.1.7 | Recepción de Expresiones de Interés | milestone | 0d | 2015-12-02 | 2015-12-02 | 556FS+14ed | 2015-12-02 | 2015-12-02 | 1091d | 0d |
| 558 | 3.5.7.1.1.8 | Evaluación de EI recibidas y conformación de lista corta ordenada por Orden de Merito |  | 10d | 2015-12-03 | 2015-12-17 | 557 | 2015-12-03 | 2015-12-17 | 1096d | 5d |
| 559 | 3.5.7.1.1.9 | Elaboracion de la Solicitud de Propuestas (SP) |  | 15d | 2015-12-03 | 2015-12-24 | 557 | 2015-12-03 | 2015-12-24 | 1091d | 0d |
| 560 | 3.5.7.1.1.10 | No Objeción del Banco a la lista corta rankeada y SP |  | 5d | 2015-12-28 | 2016-01-04 | 558, 559 | 2015-12-28 | 2016-01-04 | 1091d | 0d |
| 561 | 3.5.7.1.1.11 | Invitación a presentar propuesta tecnica y economica solo a la Firma Consultora (FC) rankeada en 1º lugar |  | 2d | 2016-01-05 | 2016-01-06 | 560 | 2016-01-05 | 2016-01-06 | 1091d | 0d |
| 562 | 3.5.7.1.1.12 | Recepción de propuesta de la FC invitada | milestone | 0d | 2016-01-21 | 2016-01-21 | 561FS+2w | 2016-01-21 | 2016-01-21 | 1091d | 0d |
| 563 | 3.5.7.1.1.13 | Evaluación de la propuesta y negociación del contrato |  | 10d | 2016-01-22 | 2016-02-04 | 562 | 2016-01-22 | 2016-02-04 | 1091d | 0d |
| 564 | 3.5.7.1.1.14 | No Objeción del Banco al contrato negociado y rubricado |  | 5d | 2016-02-05 | 2016-02-11 | 563 | 2016-02-05 | 2016-02-11 | 1091d | 0d |
| 565 | 3.5.7.1.1.15 | Publicar el nombre del consultor al cual se le adjudicó el contrato, |  | 2d | 2016-02-12 | 2016-02-15 | 564 | 2016-02-12 | 2016-02-15 | 1091d | 0d |
| 566 | 3.5.7.1.1.16 | Firma del contrato y envío del contrato al Banco para registro |  | 7d | 2016-02-16 | 2016-02-24 | 565 | 2016-02-16 | 2016-02-24 | 1091d | 0d |

| ID | WBS | Task | Type | Duration | Start | Finish | Predecessors | Baseline 1 start | Baseline 1 finish | Total slack | Free slack |
| --- | --- | --- | --- | --- | --- | --- | --- | --- | --- | --- | --- |
| 567 | 3.2.4.47 | **Contractual** |  | 65d | 2016-02-25 | 2016-06-01 |  | 2016-02-25 | 2016-06-01 | 1091d |  |
| 568 | 3.5.7.1.2.1 | Acta de inicio |  | 5d | 2016-02-25 | 2016-03-02 | 566 | 2016-02-25 | 2016-03-02 | 1091d | 0d |
| 569 | 3.5.7.1.2.2 | Fortalecer el modelo de operación para el Control Fiscal Macro |  | 3mo | 2016-03-03 | 2016-06-01 | 568 | 2016-03-03 | 2016-06-01 | 1091d | 0d |
| 570 | 3.5.7.1.3 | **Cierre** |  | 80d | 2016-06-02 | 2016-09-27 |  | 2016-06-02 | 2016-09-27 | 1091d |  |
| 571 | 3.5.7.1.3.1 | Liquidacion de contrato |  | 4mo | 2016-06-02 | 2016-09-27 | 569 | 2016-06-02 | 2016-09-27 | 1091d |  |
| 572 | 3.5.8 | **Producto 8 - Sistema de Control de Calidad de Auditorías disenado e implementado** |  | 205d | 2015-06-25 | 2016-04-26 |  | 2015-02-16 | 2018-01-11 | 1193d |  |
| 573 | 3.5.8.1 | **Consultoria: Diseñar e implementar el Sistema de Control de Calidad de Auditorías de la CGR homologable a las NIAs ISSAIs - SCC.** |  | 205d | 2015-06-25 | 2016-04-26 |  | 2015-02-16 | 2015-11-25 | 1193d |  |
| 574 | 3.5.8.1.1 | **Precontractual** |  | 83d | 2015-06-25 | 2015-10-26 |  | 2015-02-16 | 2015-06-26 | 1193d |  |
| 575 | 3.5.8.1.1.1 | Elaboración de los TR |  | 10d | 2015-06-25 | 2015-07-09 | 16 | 2015-02-16 | 2015-02-27 | 1193d | 0d |
| 576 | 3.5.8.1.1.2 | Estimado de costos y presupuesto |  | 5d | 2015-07-10 | 2015-07-16 | 575 | 2015-03-02 | 2015-03-06 | 1193d | 0d |
| 577 | 3.5.8.1.1.3 | No objeción del Banco a los TR |  | 5d | 2015-07-17 | 2015-07-24 | 576 | 2015-03-09 | 2015-03-13 | 1193d | 0d |
| 578 | 3.5.8.1.1.4 | Elaboración del Aviso Específico de Adquisiciones (AEA) solicitando Expresiones de Interés (EI) |  | 2d | 2015-07-27 | 2015-07-28 | 577 | 2015-03-16 | 2015-03-17 | 1193d | 0d |
| 579 | 3.5.8.1.1.5 | No Objeción del Banco al AEA |  | 5d | 2015-07-29 | 2015-08-04 | 578 | 2015-03-18 | 2015-03-25 | 1193d | 0d |
| 580 | 3.5.8.1.1.6 | Publicación del AEA en SECOP |  | 2d | 2015-08-05 | 2015-08-06 | 579 | 2015-03-26 | 2015-03-27 | 1193d | 0d |
| 581 | 3.5.8.1.1.7 | Recepción de Expresiones de Interés | milestone | 0d | 2015-08-20 | 2015-08-20 | 580FS+14ed | 2015-04-10 | 2015-04-10 | 1195d | 0d |
| 582 | 3.5.8.1.1.8 | Evaluación de EI recibidas y conformación de lista corta ordenada por Orden de Merito |  | 10d | 2015-08-21 | 2015-09-03 | 581 | 2015-04-13 | 2015-04-24 | 1195d | 0d |
| 583 | 3.5.8.1.1.9 | Elaboracion de la Solicitud de Propuestas (SP) |  | 10d | 2015-08-21 | 2015-09-03 | 581 | 2015-04-13 | 2015-04-24 | 1195d | 0d |
| 584 | 3.5.8.1.1.10 | No Objeción del Banco a la lista corta rankeada y SP |  | 3d | 2015-09-04 | 2015-09-08 | 582, 583 | 2015-04-27 | 2015-05-04 | 1195d | 0d |
| 585 | 3.5.8.1.1.11 | Invitación a presentar propuesta tecnica y economica solo a la Firma Consultora (FC) rankeada en 1º lugar |  | 2d | 2015-09-09 | 2015-09-10 | 584 | 2015-05-05 | 2015-05-06 | 1195d | 0d |
| 586 | 3.5.8.1.1.12 | Recepción de propuesta de la FC invitada | milestone | 0d | 2015-09-24 | 2015-09-24 | 585FS+2w | 2015-05-21 | 2015-05-21 | 1195d | 0d |
| 587 | 3.5.8.1.1.13 | Evaluación de la propuesta y negociación del contrato |  | 10d | 2015-09-25 | 2015-10-08 | 586 | 2015-05-22 | 2015-06-04 | 1195d | 0d |
| 588 | 3.5.8.1.1.14 | No Objeción del Banco al contrato negociado y rubricado |  | 5d | 2015-10-09 | 2015-10-16 | 587 | 2015-06-05 | 2015-06-12 | 1195d | 0d |
| 589 | 3.5.8.1.1.15 | Publicar el nombre del consultor al cual se le adjudicó el contrato, |  | 2d | 2015-10-19 | 2015-10-20 | 588 | 2015-06-16 | 2015-06-17 | 1195d | 0d |
| 590 | 3.5.8.1.1.16 | Firma del contrato y envío del contrato al Banco para registro |  | 4d | 2015-10-21 | 2015-10-26 | 589 | 2015-06-18 | 2015-06-26 | 1195d | 0d |

| ID | WBS | Task | Type | Duration | Start | Finish | Predecessors | Baseline 1 start | Baseline 1 finish | Total slack | Free slack |
| --- | --- | --- | --- | --- | --- | --- | --- | --- | --- | --- | --- |
| 591 | 3.2.4.47 | **Contractual** |  | 42d | 2015-10-27 | 2015-12-29 |  | 2015-02-16 | 2015-07-29 | 1195d |  |
| 592 | 3.5.8.1.2.1 | Acta de inicio |  | 2d | 2015-10-27 | 2015-10-28 | 590 | 2015-06-30 | 2015-07-06 | 1195d | 0d |
| 593 | 3.5.8.1.2.2 | Sistema de Control de Calidad de Auditorías de la CGR homologable a las NIAs e ISSAIs diseñado e implementado |  | 2mo | 2015-10-29 | 2015-12-29 | 592 | 2015-02-16 | 2015-02-16 | 1195d | 0d |
| 594 | 3.5.8.1.3 | **Cierre** |  | 80d | 2015-12-30 | 2016-04-26 |  | 2015-07-30 | 2015-11-25 | 1195d |  |
| 595 | 3.5.8.1.3.1 | Liquidacion de contrato |  | 4mo | 2015-12-30 | 2016-04-26 | 593 | 2015-07-30 | 2015-11-25 | 1195d |  |
| 596 | 3.5.9 | **Producto 9 - Programas financiados por proveedores externos de apoyo financiero evaluados y con resultados presentados** |  | 258d | 2018-02-05 | 2019-02-20 |  | 2016-10-12 | 2017-11-01 | 501d |  |
| 597 | 3.5.9.1 | **Consultoria: Fortalecer las capacidades de la CGR para auditar los programas financiados por proveedores externos de apoyo financiero. SCC** |  | 258d | 2018-02-05 | 2019-02-20 |  | 2016-10-12 | 2017-11-01 | 501d |  |
| 598 | 3.5.9.1.1 | **Precontractual** |  | 93d | 2018-02-05 | 2018-06-22 |  | 2016-10-12 | 2017-02-27 | 501d |  |
| 599 | 3.5.9.1.1.1 | Elaboración de los TR |  | 10d | 2018-02-05 | 2018-02-16 | 46FS+30mo | 2016-10-12 | 2016-10-26 | 501d | 0d |
| 600 | 3.5.9.1.1.2 | Estimado de costos y presupuesto |  | 5d | 2018-02-19 | 2018-02-23 | 599 | 2016-10-27 | 2016-11-02 | 501d | 0d |
| 601 | 3.5.9.1.1.3 | No objeción del Banco a los TR |  | 5d | 2018-02-26 | 2018-03-02 | 600 | 2016-11-03 | 2016-11-10 | 501d | 0d |
| 602 | 3.5.9.1.1.4 | Elaboración del Aviso Específico de Adquisiciones (AEA) solicitando Expresiones de Interés (EI) |  | 2d | 2018-03-05 | 2018-03-06 | 601 | 2016-11-11 | 2016-11-15 | 501d | 0d |
| 603 | 3.5.9.1.1.5 | No Objeción del Banco al AEA |  | 5d | 2018-03-07 | 2018-03-13 | 602 | 2016-11-16 | 2016-11-22 | 501d | 0d |
| 604 | 3.5.9.1.1.6 | Publicación del AEA en SECOP |  | 2d | 2018-03-14 | 2018-03-15 | 603 | 2016-11-23 | 2016-11-24 | 501d | 0d |
| 605 | 3.5.9.1.1.7 | Recepción de Expresiones de Interés | milestone | 0d | 2018-03-29 | 2018-03-29 | 604FS+14ed | 2016-12-08 | 2016-12-08 | 503d | 0d |
| 606 | 3.5.9.1.1.8 | Evaluación de EI recibidas y conformación de lista corta ordenada por Orden de Merito |  | 10d | 2018-04-02 | 2018-04-13 | 605 | 2016-12-09 | 2016-12-22 | 508d | 5d |
| 607 | 3.5.9.1.1.9 | Elaboracion de la Solicitud de Propuestas (SP) |  | 15d | 2018-04-02 | 2018-04-20 | 605 | 2016-12-09 | 2016-12-29 | 503d | 0d |
| 608 | 3.5.9.1.1.10 | No Objeción del Banco a la lista corta rankeada y SP |  | 5d | 2018-04-23 | 2018-04-27 | 606, 607 | 2016-12-30 | 2017-01-05 | 503d | 0d |
| 609 | 3.5.9.1.1.11 | Invitación a presentar propuesta tecnica y economica solo a la Firma Consultora (FC) rankeada en 1º lugar |  | 2d | 2018-04-30 | 2018-05-02 | 608 | 2017-01-06 | 2017-01-10 | 503d | 0d |
| 610 | 3.5.9.1.1.12 | Recepción de propuesta de la FC invitada | milestone | 0d | 2018-05-17 | 2018-05-17 | 609FS+2w | 2017-01-24 | 2017-01-24 | 503d | 0d |
| 611 | 3.5.9.1.1.13 | Evaluación de la propuesta y negociación del contrato |  | 10d | 2018-05-18 | 2018-05-31 | 610 | 2017-01-25 | 2017-02-07 | 503d | 0d |
| 612 | 3.5.9.1.1.14 | No Objeción del Banco al contrato negociado y rubricado |  | 5d | 2018-06-01 | 2018-06-08 | 611 | 2017-02-08 | 2017-02-14 | 503d | 0d |
| 613 | 3.5.9.1.1.15 | Publicar el nombre del consultor al cual se le adjudicó el contrato, |  | 2d | 2018-06-12 | 2018-06-13 | 612 | 2017-02-15 | 2017-02-16 | 503d | 0d |
| 614 | 3.5.9.1.1.16 | Firma del contrato y envío del contrato al Banco para registro |  | 7d | 2018-06-14 | 2018-06-22 | 613 | 2017-02-17 | 2017-02-27 | 503d | 0d |

| ID | WBS | Task | Type | Duration | Start | Finish | Predecessors | Baseline 1 start | Baseline 1 finish | Total slack | Free slack |
| --- | --- | --- | --- | --- | --- | --- | --- | --- | --- | --- | --- |
| 615 | 3.2.4.47 | **Contractual** |  | 85d | 2018-06-25 | 2018-10-26 |  | 2017-02-28 | 2017-07-06 | 503d |  |
| 616 | 3.5.9.1.2.1 | Acta de inicio |  | 5d | 2018-06-25 | 2018-06-29 | 614 | 2017-02-28 | 2017-03-06 | 503d | 0d |
| 617 | 3.5.9.1.2.2 | Plan de fortalecimiento para auditar los programas financiados por proveedores externos de apoyo financiero implementado |  | 4mo | 2018-07-03 | 2018-10-26 | 616 | 2017-03-07 | 2017-07-06 | 503d | 0d |
| 618 | 3.5.9.1.3 | **Cierre** |  | 80d | 2018-10-29 | 2019-02-20 |  | 2017-07-07 | 2017-11-01 | 503d |  |
| 619 | 3.5.9.1.3.1 | Liquidacion de contrato |  | 4mo | 2018-10-29 | 2019-02-20 | 617 | 2017-07-07 | 2017-11-01 | 503d |  |
| 620 | 3.5.10 | **Producto 10 - Sistema de seguimiento de recomendaciones efectuadas a los entes auditados redisenado y fortalecido** |  | 685d | 2015-06-25 | 2018-04-12 |  | 2015-02-16 | 2018-01-11 | 715d |  |
| 621 | 3.5.10.1 | **Consultoria: Rediseñar y fortalecer el sistema de seguimiento de recomendaciones efectuadas a los entes auditados. - SCC.** |  | 685d | 2015-06-25 | 2018-04-12 |  | 2015-02-16 | 2015-11-25 | 715d |  |
| 622 | 3.5.10.1.1 | **Precontractual** |  | 100d | 2015-06-25 | 2015-11-20 |  | 2015-02-16 | 2015-06-26 | 715d |  |
| 623 | 3.5.10.1.1.1 | Elaboración de los TR |  | 3d | 2015-06-25 | 2015-06-30 | 16 | 2015-02-16 | 2015-02-27 | 716d | 0d |
| 624 | 3.5.10.1.1.2 | Estimado de costos y presupuesto |  | 2d | 2015-07-01 | 2015-07-02 | 623 | 2015-03-02 | 2015-03-06 | 716d | 0d |
| 625 | 3.5.10.1.1.3 | No objeción del Banco a los TR |  | 5d | 2015-07-03 | 2015-07-09 | 624 | 2015-03-09 | 2015-03-13 | 716d | 0d |
| 626 | 3.5.10.1.1.4 | Solicitud de Vigencias Futuras 2016, 2017 | milestone | 0d | 2015-08-10 | 2015-08-10 | 625FS+1mo | 2015-12-14 | 2015-12-14 | 716d | 0d |
| 627 | 3.5.10.1.1.5 | Elaboración del Aviso Específico de Adquisiciones (AEA) solicitando Expresiones de Interés (EI) |  | 2d | 2015-08-11 | 2015-08-12 | 626 | 2015-03-16 | 2015-03-17 | 716d | 0d |
| 628 | 3.5.10.1.1.6 | No Objeción del Banco al AEA |  | 5d | 2015-08-13 | 2015-08-20 | 627 | 2015-03-18 | 2015-03-25 | 716d | 0d |
| 629 | 3.5.10.1.1.7 | Publicación del AEA en SECOP |  | 2d | 2015-08-21 | 2015-08-24 | 628 | 2015-03-26 | 2015-03-27 | 716d | 0d |
| 630 | 3.5.10.1.1.8 | Recepción de Expresiones de Interés | milestone | 0d | 2015-09-07 | 2015-09-07 | 629FS+14ed | 2015-04-10 | 2015-04-10 | 715d | 0d |
| 631 | 3.5.10.1.1.9 | Evaluación de EI recibidas y conformación de lista corta ordenada por Orden de Merito |  | 10d | 2015-09-08 | 2015-09-21 | 630 | 2015-04-13 | 2015-04-24 | 715d | 0d |
| 632 | 3.5.10.1.1.10 | Elaboracion de la Solicitud de Propuestas (SP) |  | 10d | 2015-09-08 | 2015-09-21 | 630 | 2015-04-13 | 2015-04-24 | 715d | 0d |
| 633 | 3.5.10.1.1.11 | No Objeción del Banco a la lista corta rankeada y SP |  | 5d | 2015-09-22 | 2015-09-28 | 631, 632 | 2015-04-27 | 2015-05-04 | 715d | 0d |
| 634 | 3.5.10.1.1.12 | Invitación a presentar propuesta tecnica y economica solo a la Firma Consultora (FC) rankeada en 1º lugar |  | 2d | 2015-09-29 | 2015-09-30 | 633 | 2015-05-05 | 2015-05-06 | 715d | 0d |
| 635 | 3.5.10.1.1.13 | Recepción de propuesta de la FC invitada | milestone | 0d | 2015-10-15 | 2015-10-15 | 634FS+2w | 2015-05-21 | 2015-05-21 | 715d | 0d |
| 636 | 3.5.10.1.1.14 | Evaluación de la propuesta y negociación del contrato |  | 10d | 2015-10-16 | 2015-10-29 | 635 | 2015-05-22 | 2015-06-04 | 715d | 0d |
| 637 | 3.5.10.1.1.15 | No Objeción del Banco al contrato negociado y rubricado |  | 5d | 2015-10-30 | 2015-11-06 | 636 | 2015-06-05 | 2015-06-12 | 715d | 0d |
| 638 | 3.5.10.1.1.16 | Publicar el nombre del consultor al cual se le adjudicó el contrato, |  | 2d | 2015-11-09 | 2015-11-10 | 637 | 2015-06-16 | 2015-06-17 | 715d | 0d |
| 639 | 3.5.10.1.1.17 | Firma del contrato y envío del contrato al Banco para registro |  | 7d | 2015-11-11 | 2015-11-20 | 638 | 2015-06-18 | 2015-06-26 | 715d | 0d |

| ID | WBS | Task | Type | Duration | Start | Finish | Predecessors | Baseline 1 start | Baseline 1 finish | Total slack | Free slack |
| --- | --- | --- | --- | --- | --- | --- | --- | --- | --- | --- | --- |
| 640 | 3.2.4.47 | **Contractual** |  | 505d | 2015-11-23 | 2017-12-13 |  | 2015-02-16 | 2015-07-29 | 715d |  |
| 641 | 3.5.10.1.2.1 | Acta de inicio |  | 5d | 2015-11-23 | 2015-11-27 | 639 | 2015-06-30 | 2015-07-06 | 715d | 0d |
| 642 | 3.5.10.1.2.2 | Sistema de seguimiento de recomendaciones efectuadas a los entes auditados redisenado y fortalecido |  | 500d | 2015-11-30 | 2017-12-13 | 641 | 2015-02-16 | 2015-02-16 | 715d | 0d |
| 643 | 3.5.10.1.3 | **Cierre** |  | 80d | 2017-12-14 | 2018-04-12 |  | 2015-07-30 | 2015-11-25 | 715d |  |
| 644 | 3.5.10.1.3.1 | Liquidacion de contrato |  | 4mo | 2017-12-14 | 2018-04-12 | 642 | 2015-07-30 | 2015-11-25 | 715d |  |
| 645 | 3.6 | **COMPONENTE 2 - Mejoramiento de la gestión de información** |  | 1060d | 2015-08-25 | 2019-11-29 |  | 2015-08-25 | 2019-10-03 | 301d |  |
| 646 | 3.6.1 | **Producto 11 - Sistemas de Informacion de la CGR de soporte a procesos misionales integrados** |  | 840d | 2016-02-18 | 2019-07-12 |  | 2016-02-18 | 2019-06-14 | 401d |  |
| 647 | 3.6.1.1 | **Consultoria: Disenar e implementar el modelo de integracion de la CGR. SBCC** |  | 670d | 2016-02-18 | 2018-11-15 |  | 2016-02-18 | 2018-10-16 | 571d |  |
| 648 | 3.2.3.3.1 | **Precontractual** |  | 146d | 2016-02-18 | 2016-09-21 |  | 2016-02-18 | 2016-09-21 | 571d |  |
| 649 | 3.2.3.3.1.1 | Elaboración de los términos de referencia (TR) |  | 1mo | 2016-02-18 | 2016-03-16 | 46FS+6mo | 2016-02-18 | 2016-03-16 | 571d | 0d |
| 650 | 3.2.3.3.1.3 | Preparación de la estimación de costos y presupuesto (Estudio de mercado) |  | 10d | 2016-03-17 | 2016-04-04 | 649 | 2016-03-17 | 2016-04-04 | 571d | 0d |
| 651 | 3.6.1.1.1.3 | Solicitud de Vigencias Futuras 2017, 2018 y 2019 | milestone | 0d | 2016-06-01 | 2016-06-01 | 650FS+2mo | 2016-06-01 | 2016-06-01 | 571d | 0d |
| 652 | 3.2.3.3.1.4 | Elaboración del Aviso Específico de Adquisiciones (AEA) solicitando expresiones de interés y solicitud de No Objeción al Banco |  | 2d | 2016-04-05 | 2016-04-06 | 650 | 2016-04-05 | 2016-04-06 | 577d | 0d |
| 653 | 3.2.3.3.1.5 | No Objeción del Banco al AEA |  | 5d | 2016-04-07 | 2016-04-13 | 652 | 2016-04-07 | 2016-04-13 | 577d | 0d |
| 654 | 3.2.3.3.1.6 | Publicación del AEA en SECOP (los contratos de valor mayor al equivalente de US $200.000 se deben anunciar ademas en los sitios de Internet del UNDB online y del Banco) |  | 2d | 2016-04-14 | 2016-04-15 | 653 | 2016-04-14 | 2016-04-15 | 577d | 0d |
| 655 | 3.2.3.3.1.7 | Recepción de expresiones de interés | milestone | 0d | 2016-04-29 | 2016-04-29 | 654FS+14ed | 2016-04-29 | 2016-04-29 | 577d | 0d |
| 656 | 3.2.3.3.1.8 | Evaluación de Expresiones de Interés recibidas y conformación de lista corta |  | 5d | 2016-05-02 | 2016-05-06 | 655 | 2016-05-02 | 2016-05-06 | 1187d |  |
| 657 | 3.2.3.3.1.9 | Elaboración de la Solicitud de Propuesta (SP) que incluye: (a) la Carta de Invitación a las firmas de la lista corta; (b) las Instrucciones a los Consultores; © los TR; y (d) el contrato propuesto; y solicitud de No Objeción al Banco |  | 10d | 2016-05-02 | 2016-05-16 | 655 | 2016-05-02 | 2016-05-16 | 577d | 0d |
| 658 | 3.2.3.3.1.10 | No Objeción del Banco a la SP y conformacion Lista Corta |  | 5d | 2016-05-17 | 2016-05-23 | 657 | 2016-05-17 | 2016-05-23 | 577d | 6d |
| 659 | 3.2.3.3.1.11 | Envio de Solicitud de Propuestas (SP) a los integrantes de la lista corta (Invitación a presentar propuestas) |  | 2d | 2016-06-02 | 2016-06-03 | 651, 658 | 2016-06-02 | 2016-06-03 | 571d | 0d |
| 660 | 3.2.3.3.1.12 | Reunión aclaratoria (eventual a los diez días de la invitación) | milestone | 0d | 2016-06-20 | 2016-06-20 | 659FS+10d | 2016-06-20 | 2016-06-20 | 571d | 0d |
| 661 | 3.2.3.3.1.13 | Preparación de respuestas a las solicitudes de aclaraciones de los oferentes y solicitud de No Objeción al Banco |  | 3d | 2016-06-21 | 2016-06-23 | 660 | 2016-06-21 | 2016-06-23 | 571d | 0d |
| 662 | 3.2.3.3.1.14 | No objeción del Banco a las respuestas de aclaraciones |  | 5d | 2016-06-24 | 2016-06-30 | 661 | 2016-06-24 | 2016-06-30 | 571d | 0d |
| 663 | 3.2.3.3.1.15 | Respuesta a las solicitudes de aclaración antes de la recepción de propuestas |  | 3d | 2016-07-01 | 2016-07-06 | 662 | 2016-07-01 | 2016-07-06 | 571d | 0d |
| 664 | 3.2.3.3.1.17 | Designación del Comité de Evaluación |  | 1d | 2016-07-07 | 2016-07-07 | 663 | 2016-07-07 | 2016-07-07 | 571d | 0d |
| 665 | 3.2.3.3.1.18 | Recepción de las Propuestas técnicas y de precio y Apertura de propuestas técnicas | milestone | 0d | 2016-07-05 | 2016-07-05 | 659FS+4w | 2016-07-05 | 2016-07-05 | 573d | 2d |
| 666 | 3.2.3.3.1.19 | Envío de propuestas al Comité de Evaluación y al Especialista en Adquisiciones | milestone | 0d | 2016-07-07 | 2016-07-07 | 664, 665 | 2016-07-07 | 2016-07-07 | 571d | 0d |
| 667 | 3.2.3.3.1.20 | Evaluación de propuestas técnicas y elaboración borrador del Informe de Evaluación Técnica (IET) |  | 10d | 2016-07-08 | 2016-07-22 | 666 | 2016-07-08 | 2016-07-22 | 571d | 0d |
| 668 | 3.2.3.3.1.16 | Reunion Comité de Evaluación |  | 1d | 2016-07-25 | 2016-07-25 | 667 | 2016-07-25 | 2016-07-25 | 571d | 0d |
| 669 | 3.2.3.3.1.21 | Solicitud de No Objeción del Banco al Informe de Evaluación Técnica (IET) de las propuestas |  | 1d | 2016-07-26 | 2016-07-26 | 668 | 2016-07-26 | 2016-07-26 | 571d | 0d |
| 670 | 3.2.3.3.1.22 | No Objeción del Banco al IET |  | 5d | 2016-07-27 | 2016-08-02 | 669 | 2016-07-27 | 2016-08-02 | 571d | 0d |
| 671 | 3.2.3.3.1.23 | Notificación del puntaje de la evaluación técnica a los proponentes y notificar simultáneamente a los que obtuvieron la calificación mínima necesaria e indicar la fecha, lugar y hora fijada para abrir las propuestas de precio. |  | 1d | 2016-08-03 | 2016-08-03 | 670 | 2016-08-03 | 2016-08-03 | 571d | 0d |
| 672 | 3.2.3.3.1.24 | Apertura de propuesta de precio en Audiencia Pública | milestone | 0d | 2016-08-10 | 2016-08-10 | 671FS+5d | 2016-08-10 | 2016-08-10 | 571d | 0d |
| 673 | 3.2.3.3.1.25 | Evaluación del Costo y Evaluación Combinada de la Calidad y el Costo |  | 1d | 2016-08-11 | 2016-08-11 | 672 | 2016-08-11 | 2016-08-11 | 571d | 0d |
| 674 | 3.2.3.3.1.26 | Notificación y negociación del contrato con el proponente seleccionado, elaboración del borrador del contrato negociado y solicitud de No Objeción Banco |  | 10d | 2016-08-12 | 2016-08-26 | 673 | 2016-08-12 | 2016-08-26 | 571d | 0d |
| 675 | 3.2.3.3.1.27 | No Objeción del Banco al borrador del contrato negociado y envio acta de apertura de sobres y evaluacion combinada |  | 5d | 2016-08-29 | 2016-09-02 | 674 | 2016-08-29 | 2016-09-02 | 571d | 0d |
| 676 | 3.2.3.3.1.28 | Notificación a las demás firmas incluidas en la lista corta que sus propuestas no fueron seleccionadas |  | 1d | 2016-09-05 | 2016-09-05 | 675 | 2016-09-05 | 2016-09-05 | 571d | 0d |
| 677 | 3.2.3.3.1.29 | Publicación de la Adjudicación del Contrato |  | 1d | 2016-09-06 | 2016-09-06 | 676 | 2016-09-06 | 2016-09-06 | 571d | 0d |
| 678 | 3.2.3.3.1.30 | Legalización y Firma del Contrato |  | 10d | 2016-09-07 | 2016-09-20 | 677 | 2016-09-07 | 2016-09-20 | 571d | 0d |
| 679 | 3.2.3.3.1.31 | Envio al Banco de una copia firmada del contrato |  | 1d | 2016-09-21 | 2016-09-21 | 678 | 2016-09-21 | 2016-09-21 | 1095d |  |

| ID | WBS | Task | Type | Duration | Start | Finish | Predecessors | Baseline 1 start | Baseline 1 finish | Total slack | Free slack |
| --- | --- | --- | --- | --- | --- | --- | --- | --- | --- | --- | --- |
| 680 | 3.2.4.47 | **Contractual** |  | 445d | 2016-09-21 | 2018-07-18 |  | 2016-09-21 | 2018-06-19 | 571d |  |
| 681 | 3.2.3.3.2.1 | Acta de inicio |  | 5d | 2016-09-21 | 2016-09-27 | 678 | 2016-09-21 | 2016-09-27 | 571d | 0d |
| 682 | 3.6.1.1.2.2 | Modelo de integracion de la CGR disenado e implementado |  | 22mo | 2016-09-28 | 2018-07-18 | 681 | 2016-09-28 | 2018-06-19 | 571d | 0d |
| 683 | 3.6.1.1.3 | **Cierre** |  | 80d | 2018-07-19 | 2018-11-15 |  | 2018-06-20 | 2018-10-16 | 571d |  |
| 684 | 3.6.1.1.3.1 | Liquidación del contrato |  | 4mo | 2018-07-19 | 2018-11-15 | 682 | 2018-06-20 | 2018-10-16 | 571d |  |
| 685 | 3.6.1.2 | **Consultoria: Fortalecimiento de la solucion de apoyo al proceso misional control fiscal micro. SBCC** |  | 840d | 2016-02-18 | 2019-07-12 |  | 2016-02-18 | 2019-06-14 | 401d |  |
| 686 | 3.2.3.3.1 | **Precontractual** |  | 146d | 2016-02-18 | 2016-09-21 |  | 2016-02-18 | 2016-09-21 | 401d |  |
| 687 | 3.2.3.3.1.1 | Elaboración de los términos de referencia (TR) |  | 1mo | 2016-02-18 | 2016-03-16 | 46FS+6mo | 2016-02-18 | 2016-03-16 | 401d | 0d |
| 688 | 3.2.3.3.1.3 | Preparación de la estimación de costos y presupuesto (Estudio de mercado) |  | 10d | 2016-03-17 | 2016-04-04 | 687 | 2016-03-17 | 2016-04-04 | 401d | 0d |
| 689 | 3.6.1.2.1.3 | Solicitud de Vigencias Futuras 2017 , 2018 y 2019 | milestone | 0d | 2016-06-01 | 2016-06-01 | 688FS+2mo | 2016-06-01 | 2016-06-01 | 401d | 0d |
| 690 | 3.2.3.3.1.4 | Elaboración del Aviso Específico de Adquisiciones (AEA) solicitando expresiones de interés y solicitud de No Objeción al Banco |  | 2d | 2016-04-05 | 2016-04-06 | 688 | 2016-04-05 | 2016-04-06 | 408d | 0d |
| 691 | 3.2.3.3.1.5 | No Objeción del Banco al AEA |  | 5d | 2016-04-07 | 2016-04-13 | 690 | 2016-04-07 | 2016-04-13 | 408d | 0d |
| 692 | 3.2.3.3.1.6 | Publicación del AEA en SECOP (los contratos de valor mayor al equivalente de US $200.000 se deben anunciar ademas en los sitios de Internet del UNDB online y del Banco) |  | 2d | 2016-04-14 | 2016-04-15 | 691 | 2016-04-14 | 2016-04-15 | 408d | 0d |
| 693 | 3.2.3.3.1.7 | Recepción de expresiones de interés | milestone | 0d | 2016-04-29 | 2016-04-29 | 692FS+14ed | 2016-04-29 | 2016-04-29 | 407d | 0d |
| 694 | 3.2.3.3.1.8 | Evaluación de Expresiones de Interés recibidas y conformación de lista corta |  | 5d | 2016-05-02 | 2016-05-06 | 693 | 2016-05-02 | 2016-05-06 | 1187d |  |
| 695 | 3.2.3.3.1.9 | Elaboración de la Solicitud de Propuesta (SP) que incluye: (a) la Carta de Invitación a las firmas de la lista corta; (b) las Instrucciones a los Consultores; © los TR; y (d) el contrato propuesto; y solicitud de No Objeción al Banco |  | 10d | 2016-05-02 | 2016-05-16 | 693 | 2016-05-02 | 2016-05-16 | 407d | 0d |
| 696 | 3.2.3.3.1.10 | No Objeción del Banco a la SP y conformacion Lista Corta |  | 5d | 2016-05-17 | 2016-05-23 | 695 | 2016-05-17 | 2016-05-23 | 407d | 6d |
| 697 | 3.2.3.3.1.11 | Envio de Solicitud de Propuestas (SP) a los integrantes de la lista corta (Invitación a presentar propuestas) |  | 2d | 2016-06-02 | 2016-06-03 | 689, 696 | 2016-06-02 | 2016-06-03 | 401d | 0d |
| 698 | 3.2.3.3.1.12 | Reunión aclaratoria (eventual a los diez días de la invitación) | milestone | 0d | 2016-06-20 | 2016-06-20 | 697FS+10d | 2016-06-20 | 2016-06-20 | 401d | 0d |
| 699 | 3.2.3.3.1.13 | Preparación de respuestas a las solicitudes de aclaraciones de los oferentes y solicitud de No Objeción al Banco |  | 3d | 2016-06-21 | 2016-06-23 | 698 | 2016-06-21 | 2016-06-23 | 401d | 0d |
| 700 | 3.2.3.3.1.14 | No objeción del Banco a las respuestas de aclaraciones |  | 5d | 2016-06-24 | 2016-06-30 | 699 | 2016-06-24 | 2016-06-30 | 401d | 0d |
| 701 | 3.2.3.3.1.15 | Respuesta a las solicitudes de aclaración antes de la recepción de propuestas |  | 3d | 2016-07-01 | 2016-07-06 | 700 | 2016-07-01 | 2016-07-06 | 401d | 0d |
| 702 | 3.2.3.3.1.17 | Designación del Comité de Evaluación |  | 1d | 2016-07-07 | 2016-07-07 | 701 | 2016-07-07 | 2016-07-07 | 401d | 0d |
| 703 | 3.2.3.3.1.18 | Recepción de las Propuestas técnicas y de precio y Apertura de propuestas técnicas | milestone | 0d | 2016-07-05 | 2016-07-05 | 697FS+4w | 2016-07-05 | 2016-07-05 | 403d | 2d |
| 704 | 3.2.3.3.1.19 | Envío de propuestas al Comité de Evaluación y al Especialista en Adquisiciones | milestone | 0d | 2016-07-07 | 2016-07-07 | 702, 703 | 2016-07-07 | 2016-07-07 | 401d | 0d |
| 705 | 3.2.3.3.1.20 | Evaluación de propuestas técnicas y elaboración borrador del Informe de Evaluación Técnica (IET) |  | 10d | 2016-07-08 | 2016-07-22 | 704 | 2016-07-08 | 2016-07-22 | 401d | 0d |
| 706 | 3.2.3.3.1.16 | Reunion Comité de Evaluación |  | 1d | 2016-07-25 | 2016-07-25 | 705 | 2016-07-25 | 2016-07-25 | 401d | 0d |
| 707 | 3.2.3.3.1.21 | Solicitud de No Objeción del Banco al Informe de Evaluación Técnica (IET) de las propuestas |  | 1d | 2016-07-26 | 2016-07-26 | 706 | 2016-07-26 | 2016-07-26 | 401d | 0d |
| 708 | 3.2.3.3.1.22 | No Objeción del Banco al IET |  | 5d | 2016-07-27 | 2016-08-02 | 707 | 2016-07-27 | 2016-08-02 | 401d | 0d |
| 709 | 3.2.3.3.1.23 | Notificación del puntaje de la evaluación técnica a los proponentes y notificar simultáneamente a los que obtuvieron la calificación mínima necesaria e indicar la fecha, lugar y hora fijada para abrir las propuestas de precio. |  | 1d | 2016-08-03 | 2016-08-03 | 708 | 2016-08-03 | 2016-08-03 | 401d | 0d |
| 710 | 3.2.3.3.1.24 | Apertura de propuesta de precio en Audiencia Pública | milestone | 0d | 2016-08-10 | 2016-08-10 | 709FS+5d | 2016-08-10 | 2016-08-10 | 401d | 0d |
| 711 | 3.2.3.3.1.25 | Evaluación del Costo y Evaluación Combinada de la Calidad y el Costo |  | 1d | 2016-08-11 | 2016-08-11 | 710 | 2016-08-11 | 2016-08-11 | 401d | 0d |
| 712 | 3.2.3.3.1.26 | Notificación y negociación del contrato con el proponente seleccionado, elaboración del borrador del contrato negociado y solicitud de No Objeción Banco |  | 10d | 2016-08-12 | 2016-08-26 | 711 | 2016-08-12 | 2016-08-26 | 401d | 0d |
| 713 | 3.2.3.3.1.27 | No Objeción del Banco al borrador del contrato negociado y envio acta de apertura de sobres y evaluacion combinada |  | 5d | 2016-08-29 | 2016-09-02 | 712 | 2016-08-29 | 2016-09-02 | 401d | 0d |
| 714 | 3.2.3.3.1.28 | Notificación a las demás firmas incluidas en la lista corta que sus propuestas no fueron seleccionadas |  | 1d | 2016-09-05 | 2016-09-05 | 713 | 2016-09-05 | 2016-09-05 | 401d | 0d |
| 715 | 3.2.3.3.1.29 | Publicación de la Adjudicación del Contrato |  | 1d | 2016-09-06 | 2016-09-06 | 714 | 2016-09-06 | 2016-09-06 | 401d | 0d |
| 716 | 3.2.3.3.1.30 | Legalización y Firma del Contrato |  | 10d | 2016-09-07 | 2016-09-20 | 715 | 2016-09-07 | 2016-09-20 | 401d | 0d |
| 717 | 3.2.3.3.1.31 | Envio al Banco de una copia firmada del contrato |  | 1d | 2016-09-21 | 2016-09-21 | 716 | 2016-09-21 | 2016-09-21 | 1095d |  |

| ID | WBS | Task | Type | Duration | Start | Finish | Predecessors | Baseline 1 start | Baseline 1 finish | Total slack | Free slack | Constraint |
| --- | --- | --- | --- | --- | --- | --- | --- | --- | --- | --- | --- | --- |
| 718 | 3.2.4.47 | **Contractual** |  | 615d | 2016-09-21 | 2019-03-22 |  | 2016-09-21 | 2019-02-22 | 401d |  |  |
| 719 | 3.2.3.3.2.1 | Acta de inicio |  | 5d | 2016-09-21 | 2016-09-27 | 716 | 2016-09-21 | 2016-09-27 | 401d | 0d |  |
| 720 | 3.6.1.2.2.2 | Solucion de apoyo al proceso misional control fiscal micro fortalecida |  | 610d | 2016-09-28 | 2019-03-22 | 719 | 2016-09-28 | 2019-02-22 | 401d | 0d | finish no earlier than 2018-07-18 |
| 721 | 3.6.1.2.3 | **Cierre** |  | 80d | 2019-03-25 | 2019-07-12 |  | 2019-02-25 | 2019-06-14 | 401d |  |  |
| 722 | 3.6.1.2.3.1 | Liquidación del contrato |  | 4mo | 2019-03-25 | 2019-07-12 | 720 | 2019-02-25 | 2019-06-14 | 401d |  |  |
| 723 | 3.6.1.3 | **Consultoria: Aplicaciones de los procesos misionales ajustadas segun arquitectura empresarial. SBCC** |  | 710d | 2016-02-18 | 2019-01-11 |  | 2016-02-18 | 2019-01-11 | 531d |  |  |
| 724 | 3.2.3.3.1 | **Precontractual** |  | 146d | 2016-02-18 | 2016-09-21 |  | 2016-02-18 | 2016-09-21 | 531d |  |  |
| 725 | 3.2.3.3.1.1 | Elaboración de los términos de referencia (TR) |  | 1mo | 2016-02-18 | 2016-03-16 | 46FS+6mo | 2016-02-18 | 2016-03-16 | 531d | 0d |  |
| 726 | 3.2.3.3.1.3 | Preparación de la estimación de costos y presupuesto (Estudio de mercado) |  | 10d | 2016-03-17 | 2016-04-04 | 725 | 2016-03-17 | 2016-04-04 | 531d | 0d |  |
| 727 | 3.6.1.3.1.3 | Solicitud de Vigencias Futuras 2017, 2018 | milestone | 0d | 2016-06-01 | 2016-06-01 | 726FS+2mo | 2016-06-01 | 2016-06-01 | 531d | 0d |  |
| 728 | 3.2.3.3.1.4 | Elaboración del Aviso Específico de Adquisiciones (AEA) solicitando expresiones de interés y solicitud de No Objeción al Banco |  | 2d | 2016-04-05 | 2016-04-06 | 726 | 2016-04-05 | 2016-04-06 | 538d | 0d |  |
| 729 | 3.2.3.3.1.5 | No Objeción del Banco al AEA |  | 5d | 2016-04-07 | 2016-04-13 | 728 | 2016-04-07 | 2016-04-13 | 538d | 0d |  |
| 730 | 3.2.3.3.1.6 | Publicación del AEA en SECOP (los contratos de valor mayor al equivalente de US $200.000 se deben anunciar ademas en los sitios de Internet del UNDB online y del Banco) |  | 2d | 2016-04-14 | 2016-04-15 | 729 | 2016-04-14 | 2016-04-15 | 538d | 0d |  |
| 731 | 3.2.3.3.1.7 | Recepción de expresiones de interés | milestone | 0d | 2016-04-29 | 2016-04-29 | 730FS+14ed | 2016-04-29 | 2016-04-29 | 537d | 0d |  |
| 732 | 3.2.3.3.1.8 | Evaluación de Expresiones de Interés recibidas y conformación de lista corta |  | 5d | 2016-05-02 | 2016-05-06 | 731 | 2016-05-02 | 2016-05-06 | 1187d |  |  |
| 733 | 3.2.3.3.1.9 | Elaboración de la Solicitud de Propuesta (SP) que incluye: (a) la Carta de Invitación a las firmas de la lista corta; (b) las Instrucciones a los Consultores; © los TR; y (d) el contrato propuesto; y solicitud de No Objeción al Banco |  | 10d | 2016-05-02 | 2016-05-16 | 731 | 2016-05-02 | 2016-05-16 | 537d | 0d |  |
| 734 | 3.2.3.3.1.10 | No Objeción del Banco a la SP y conformacion Lista Corta |  | 5d | 2016-05-17 | 2016-05-23 | 733 | 2016-05-17 | 2016-05-23 | 537d | 6d |  |
| 735 | 3.2.3.3.1.11 | Envio de Solicitud de Propuestas (SP) a los integrantes de la lista corta (Invitación a presentar propuestas) |  | 2d | 2016-06-02 | 2016-06-03 | 727, 734 | 2016-06-02 | 2016-06-03 | 531d | 0d |  |
| 736 | 3.2.3.3.1.12 | Reunión aclaratoria (eventual a los diez días de la invitación) | milestone | 0d | 2016-06-20 | 2016-06-20 | 735FS+10d | 2016-06-20 | 2016-06-20 | 531d | 0d |  |
| 737 | 3.2.3.3.1.13 | Preparación de respuestas a las solicitudes de aclaraciones de los oferentes y solicitud de No Objeción al Banco |  | 3d | 2016-06-21 | 2016-06-23 | 736 | 2016-06-21 | 2016-06-23 | 531d | 0d |  |
| 738 | 3.2.3.3.1.14 | No objeción del Banco a las respuestas de aclaraciones |  | 5d | 2016-06-24 | 2016-06-30 | 737 | 2016-06-24 | 2016-06-30 | 531d | 0d |  |
| 739 | 3.2.3.3.1.15 | Respuesta a las solicitudes de aclaración antes de la recepción de propuestas |  | 3d | 2016-07-01 | 2016-07-06 | 738 | 2016-07-01 | 2016-07-06 | 531d | 0d |  |
| 740 | 3.2.3.3.1.17 | Designación del Comité de Evaluación |  | 1d | 2016-07-07 | 2016-07-07 | 739 | 2016-07-07 | 2016-07-07 | 531d | 0d |  |
| 741 | 3.2.3.3.1.18 | Recepción de las Propuestas técnicas y de precio y Apertura de propuestas técnicas | milestone | 0d | 2016-07-05 | 2016-07-05 | 735FS+4w | 2016-07-05 | 2016-07-05 | 533d | 2d |  |
| 742 | 3.2.3.3.1.19 | Envío de propuestas al Comité de Evaluación y al Especialista en Adquisiciones | milestone | 0d | 2016-07-07 | 2016-07-07 | 740, 741 | 2016-07-07 | 2016-07-07 | 531d | 0d |  |
| 743 | 3.2.3.3.1.20 | Evaluación de propuestas técnicas y elaboración borrador del Informe de Evaluación Técnica (IET) |  | 10d | 2016-07-08 | 2016-07-22 | 742 | 2016-07-08 | 2016-07-22 | 531d | 0d |  |
| 744 | 3.2.3.3.1.16 | Reunion Comité de Evaluación |  | 1d | 2016-07-25 | 2016-07-25 | 743 | 2016-07-25 | 2016-07-25 | 531d | 0d |  |
| 745 | 3.2.3.3.1.21 | Solicitud de No Objeción del Banco al Informe de Evaluación Técnica (IET) de las propuestas |  | 1d | 2016-07-26 | 2016-07-26 | 744 | 2016-07-26 | 2016-07-26 | 531d | 0d |  |
| 746 | 3.2.3.3.1.22 | No Objeción del Banco al IET |  | 5d | 2016-07-27 | 2016-08-02 | 745 | 2016-07-27 | 2016-08-02 | 531d | 0d |  |
| 747 | 3.2.3.3.1.23 | Notificación del puntaje de la evaluación técnica a los proponentes y notificar simultáneamente a los que obtuvieron la calificación mínima necesaria e indicar la fecha, lugar y hora fijada para abrir las propuestas de precio. |  | 1d | 2016-08-03 | 2016-08-03 | 746 | 2016-08-03 | 2016-08-03 | 531d | 0d |  |
| 748 | 3.2.3.3.1.24 | Apertura de propuesta de precio en Audiencia Pública | milestone | 0d | 2016-08-10 | 2016-08-10 | 747FS+5d | 2016-08-10 | 2016-08-10 | 531d | 0d |  |
| 749 | 3.2.3.3.1.25 | Evaluación del Costo y Evaluación Combinada de la Calidad y el Costo |  | 1d | 2016-08-11 | 2016-08-11 | 748 | 2016-08-11 | 2016-08-11 | 531d | 0d |  |
| 750 | 3.2.3.3.1.26 | Notificación y negociación del contrato con el proponente seleccionado, elaboración del borrador del contrato negociado y solicitud de No Objeción Banco |  | 10d | 2016-08-12 | 2016-08-26 | 749 | 2016-08-12 | 2016-08-26 | 531d | 0d |  |
| 751 | 3.2.3.3.1.27 | No Objeción del Banco al borrador del contrato negociado y envio acta de apertura de sobres y evaluacion combinada |  | 5d | 2016-08-29 | 2016-09-02 | 750 | 2016-08-29 | 2016-09-02 | 531d | 0d |  |
| 752 | 3.2.3.3.1.28 | Notificación a las demás firmas incluidas en la lista corta que sus propuestas no fueron seleccionadas |  | 1d | 2016-09-05 | 2016-09-05 | 751 | 2016-09-05 | 2016-09-05 | 531d | 0d |  |
| 753 | 3.2.3.3.1.29 | Publicación de la Adjudicación del Contrato |  | 1d | 2016-09-06 | 2016-09-06 | 752 | 2016-09-06 | 2016-09-06 | 531d | 0d |  |
| 754 | 3.2.3.3.1.30 | Legalización y Firma del Contrato |  | 10d | 2016-09-07 | 2016-09-20 | 753 | 2016-09-07 | 2016-09-20 | 531d | 0d |  |
| 755 | 3.2.3.3.1.31 | Envio al Banco de una copia firmada del contrato |  | 1d | 2016-09-21 | 2016-09-21 | 754 | 2016-09-21 | 2016-09-21 | 1095d |  |  |

| ID | WBS | Task | Type | Duration | Start | Finish | Predecessors | Baseline 1 start | Baseline 1 finish | Total slack | Free slack | Constraint |
| --- | --- | --- | --- | --- | --- | --- | --- | --- | --- | --- | --- | --- |
| 756 | 3.2.4.47 | **Contractual** |  | 485d | 2016-09-21 | 2018-09-17 |  | 2016-09-21 | 2018-09-17 | 531d |  |  |
| 757 | 3.2.3.3.2.1 | Acta de inicio |  | 5d | 2016-09-21 | 2016-09-27 | 754 | 2016-09-21 | 2016-09-27 | 531d | 0d |  |
| 758 | 3.6.1.3.2.2 | Aplicaciones de los procesos misionales ajustadas segun arquitectura empresarial |  | 24mo | 2016-09-28 | 2018-09-17 | 757 | 2016-09-28 | 2018-09-17 | 531d | 0d | finish no earlier than 2018-07-18 |
| 759 | 3.6.1.3.3 | **Cierre** |  | 80d | 2018-09-18 | 2019-01-11 |  | 2018-09-18 | 2019-01-11 | 531d |  |  |
| 760 | 3.6.1.3.3.1 | Liquidación del contrato |  | 4mo | 2018-09-18 | 2019-01-11 | 758 | 2018-09-18 | 2019-01-11 | 531d |  |  |
| 761 | 3.6.2 | **Producto 12 -Estrategia de politicas y controles para mejorar la calidad de la informacion y la gestion documental disenada e implementada** |  | 590d | 2017-04-06 | 2019-08-23 |  | 2017-04-06 | 2019-08-23 | 371d |  |  |
| 762 | 3.6.2.1 | **Consultoria: Evaluacion y definicion de politicas de calidad de la informacion. SBCC** |  | 283d | 2017-10-05 | 2018-12-04 |  | 2017-10-05 | 2018-12-04 | 557d |  |  |
| 763 | 3.2.3.3.1 | **Precontractual** |  | 139d | 2017-10-05 | 2018-05-02 |  | 2017-10-05 | 2018-05-02 | 557d |  |  |
| 764 | 3.2.3.3.1.1 | Elaboración de los términos de referencia (TR) |  | 1mo | 2017-10-05 | 2017-11-02 | 46FS+26mo | 2017-10-05 | 2017-11-02 | 557d | 0d |  |
| 765 | 3.2.3.3.1.3 | Preparación de la estimación de costos y presupuesto (Estudio de mercado) |  | 10d | 2017-11-03 | 2017-11-20 | 764 | 2017-11-03 | 2017-11-20 | 557d | 0d |  |
| 766 | 3.2.3.3.1.4 | Elaboración del Aviso Específico de Adquisiciones (AEA) solicitando expresiones de interés y solicitud de No Objeción al Banco |  | 2d | 2017-11-21 | 2017-11-22 | 765 | 2017-11-21 | 2017-11-22 | 557d | 0d |  |
| 767 | 3.2.3.3.1.5 | No Objeción del Banco al AEA |  | 5d | 2017-11-23 | 2017-11-29 | 766 | 2017-11-23 | 2017-11-29 | 557d | 0d |  |
| 768 | 3.2.3.3.1.6 | Publicación del AEA en SECOP (los contratos de valor mayor al equivalente de US $200.000 se deben anunciar ademas en los sitios de Internet del UNDB online y del Banco) |  | 2d | 2017-11-30 | 2017-12-01 | 767 | 2017-11-30 | 2017-12-01 | 557d | 0d |  |
| 769 | 3.2.3.3.1.7 | Recepción de expresiones de interés | milestone | 0d | 2017-12-15 | 2017-12-15 | 768FS+14ed | 2017-12-15 | 2017-12-15 | 558d | 0d |  |
| 770 | 3.2.3.3.1.8 | Evaluación de Expresiones de Interés recibidas y conformación de lista corta |  | 5d | 2017-12-18 | 2017-12-22 | 769 | 2017-12-18 | 2017-12-22 | 788d |  |  |
| 771 | 3.2.3.3.1.9 | Elaboración de la Solicitud de Propuesta (SP) que incluye: (a) la Carta de Invitación a las firmas de la lista corta; (b) las Instrucciones a los Consultores; © los TR; y (d) el contrato propuesto; y solicitud de No Objeción al Banco |  | 10d | 2017-12-18 | 2018-01-02 | 769 | 2017-12-18 | 2018-01-02 | 558d | 0d |  |
| 772 | 3.2.3.3.1.10 | No Objeción del Banco a la SP y conformacion Lista Corta |  | 5d | 2018-01-03 | 2018-01-10 | 771 | 2018-01-03 | 2018-01-10 | 558d | 0d |  |
| 773 | 3.2.3.3.1.11 | Envio de Solicitud de Propuestas (SP) a los integrantes de la lista corta (Invitación a presentar propuestas) |  | 2d | 2018-01-11 | 2018-01-12 | 772 | 2018-01-11 | 2018-01-12 | 558d | 0d |  |
| 774 | 3.2.3.3.1.12 | Reunión aclaratoria (eventual a los diez días de la invitación) | milestone | 0d | 2018-01-26 | 2018-01-26 | 773FS+10d | 2018-01-26 | 2018-01-26 | 558d | 0d |  |
| 775 | 3.2.3.3.1.13 | Preparación de respuestas a las solicitudes de aclaraciones de los oferentes y solicitud de No Objeción al Banco |  | 3d | 2018-01-29 | 2018-01-31 | 774 | 2018-01-29 | 2018-01-31 | 558d | 0d |  |
| 776 | 3.2.3.3.1.14 | No objeción del Banco a las respuestas de aclaraciones |  | 5d | 2018-02-01 | 2018-02-07 | 775 | 2018-02-01 | 2018-02-07 | 558d | 0d |  |
| 777 | 3.2.3.3.1.15 | Respuesta a las solicitudes de aclaración antes de la recepción de propuestas |  | 3d | 2018-02-08 | 2018-02-12 | 776 | 2018-02-08 | 2018-02-12 | 558d | 0d |  |
| 778 | 3.2.3.3.1.17 | Designación del Comité de Evaluación |  | 1d | 2018-02-13 | 2018-02-13 | 777 | 2018-02-13 | 2018-02-13 | 558d | 0d |  |
| 779 | 3.2.3.3.1.18 | Recepción de las Propuestas técnicas y de precio y Apertura de propuestas técnicas | milestone | 0d | 2018-02-09 | 2018-02-09 | 773FS+4w | 2018-02-09 | 2018-02-09 | 560d | 2d |  |
| 780 | 3.2.3.3.1.19 | Envío de propuestas al Comité de Evaluación y al Especialista en Adquisiciones | milestone | 0d | 2018-02-13 | 2018-02-13 | 778, 779 | 2018-02-13 | 2018-02-13 | 558d | 0d |  |
| 781 | 3.2.3.3.1.20 | Evaluación de propuestas técnicas y elaboración borrador del Informe de Evaluación Técnica (IET) |  | 10d | 2018-02-14 | 2018-02-27 | 780 | 2018-02-14 | 2018-02-27 | 558d | 0d |  |
| 782 | 3.2.3.3.1.16 | Reunion Comité de Evaluación |  | 1d | 2018-02-28 | 2018-02-28 | 781 | 2018-02-28 | 2018-02-28 | 558d | 0d |  |
| 783 | 3.2.3.3.1.21 | Solicitud de No Objeción del Banco al Informe de Evaluación Técnica (IET) de las propuestas |  | 1d | 2018-03-01 | 2018-03-01 | 782 | 2018-03-01 | 2018-03-01 | 558d | 0d |  |
| 784 | 3.2.3.3.1.22 | No Objeción del Banco al IET |  | 5d | 2018-03-02 | 2018-03-08 | 783 | 2018-03-02 | 2018-03-08 | 558d | 0d |  |
| 785 | 3.2.3.3.1.23 | Notificación del puntaje de la evaluación técnica a los proponentes y notificar simultáneamente a los que obtuvieron la calificación mínima necesaria e indicar la fecha, lugar y hora fijada para abrir las propuestas de precio. |  | 1d | 2018-03-09 | 2018-03-09 | 784 | 2018-03-09 | 2018-03-09 | 558d | 0d |  |
| 786 | 3.2.3.3.1.24 | Apertura de propuesta de precio en Audiencia Pública | milestone | 0d | 2018-03-16 | 2018-03-16 | 785FS+5d | 2018-03-16 | 2018-03-16 | 558d | 0d |  |
| 787 | 3.2.3.3.1.25 | Evaluación del Costo y Evaluación Combinada de la Calidad y el Costo |  | 1d | 2018-03-20 | 2018-03-20 | 786 | 2018-03-20 | 2018-03-20 | 558d | 0d |  |
| 788 | 3.2.3.3.1.26 | Notificación y negociación del contrato con el proponente seleccionado, elaboración del borrador del contrato negociado y solicitud de No Objeción Banco |  | 10d | 2018-03-21 | 2018-04-05 | 787 | 2018-03-21 | 2018-04-05 | 558d | 0d |  |
| 789 | 3.2.3.3.1.27 | No Objeción del Banco al borrador del contrato negociado y envio acta de apertura de sobres y evaluacion combinada |  | 5d | 2018-04-06 | 2018-04-12 | 788 | 2018-04-06 | 2018-04-12 | 558d | 0d |  |
| 790 | 3.2.3.3.1.28 | Notificación a las demás firmas incluidas en la lista corta que sus propuestas no fueron seleccionadas |  | 1d | 2018-04-13 | 2018-04-13 | 789 | 2018-04-13 | 2018-04-13 | 558d | 0d |  |
| 791 | 3.2.3.3.1.29 | Publicación de la Adjudicación del Contrato |  | 1d | 2018-04-16 | 2018-04-16 | 790 | 2018-04-16 | 2018-04-16 | 558d | 0d |  |
| 792 | 3.2.3.3.1.30 | Legalización y Firma del Contrato |  | 10d | 2018-04-17 | 2018-04-30 | 791 | 2018-04-17 | 2018-04-30 | 558d | 0d |  |
| 793 | 3.2.3.3.1.31 | Envio al Banco de una copia firmada del contrato |  | 1d | 2018-05-02 | 2018-05-02 | 792 | 2018-05-02 | 2018-05-02 | 702d |  |  |

| ID | WBS | Task | Type | Duration | Start | Finish | Predecessors | Baseline 1 start | Baseline 1 finish | Total slack | Free slack |
| --- | --- | --- | --- | --- | --- | --- | --- | --- | --- | --- | --- |
| 794 | 3.2.4.47 | **Contractual** |  | 65d | 2018-05-02 | 2018-08-08 |  | 2018-05-02 | 2018-08-08 | 558d |  |
| 795 | 3.2.3.3.2.1 | Acta de inicio |  | 5d | 2018-05-02 | 2018-05-08 | 792 | 2018-05-02 | 2018-05-08 | 558d | 0d |
| 796 | 3.6.2.1.2.2 | Politicas de calidad de la informacion definidas |  | 3mo | 2018-05-09 | 2018-08-08 | 795 | 2018-05-09 | 2018-08-08 | 558d | 0d |
| 797 | 3.6.2.1.3 | **Cierre** |  | 80d | 2018-08-09 | 2018-12-04 |  | 2018-08-09 | 2018-12-04 | 558d |  |
| 798 | 3.6.2.1.3.1 | Liquidación del contrato |  | 4mo | 2018-08-09 | 2018-12-04 | 796 | 2018-08-09 | 2018-12-04 | 558d |  |
| 799 | 3.6.2.2 | **Consultoria: Implementacion de la estrategia de datos e informacion. SBCC** |  | 490d | 2017-04-06 | 2019-04-05 |  | 2017-04-06 | 2019-05-03 | 471d |  |
| 800 | 3.2.3.3.1 | **Precontractual** |  | 146d | 2017-04-06 | 2017-11-14 |  | 2017-04-06 | 2017-11-14 | 471d |  |
| 801 | 3.2.3.3.1.1 | Elaboración de los términos de referencia (TR) |  | 1mo | 2017-04-06 | 2017-05-08 | 46FS+20mo | 2017-04-06 | 2017-05-08 | 471d | 0d |
| 802 | 3.2.3.3.1.3 | Preparación de la estimación de costos y presupuesto (Estudio de mercado) |  | 10d | 2017-05-09 | 2017-05-22 | 801 | 2017-05-09 | 2017-05-22 | 471d | 0d |
| 803 | 3.6.2.2.1.3 | Solicitud de Vigencias Futuras 2018 | milestone | 0d | 2017-07-24 | 2017-07-24 | 802FS+2mo | 2017-07-24 | 2017-07-24 | 471d | 0d |
| 804 | 3.2.3.3.1.4 | Elaboración del Aviso Específico de Adquisiciones (AEA) solicitando expresiones de interés y solicitud de No Objeción al Banco |  | 2d | 2017-05-23 | 2017-05-24 | 802 | 2017-05-23 | 2017-05-24 | 477d | 0d |
| 805 | 3.2.3.3.1.5 | No Objeción del Banco al AEA |  | 5d | 2017-05-25 | 2017-06-01 | 804 | 2017-05-25 | 2017-06-01 | 477d | 0d |
| 806 | 3.2.3.3.1.6 | Publicación del AEA en SECOP (los contratos de valor mayor al equivalente de US $200.000 se deben anunciar ademas en los sitios de Internet del UNDB online y del Banco) |  | 2d | 2017-06-02 | 2017-06-05 | 805 | 2017-06-02 | 2017-06-05 | 477d | 0d |
| 807 | 3.2.3.3.1.7 | Recepción de expresiones de interés | milestone | 0d | 2017-06-19 | 2017-06-19 | 806FS+14ed | 2017-06-19 | 2017-06-19 | 478d | 0d |
| 808 | 3.2.3.3.1.8 | Evaluación de Expresiones de Interés recibidas y conformación de lista corta |  | 5d | 2017-06-20 | 2017-06-27 | 807 | 2017-06-20 | 2017-06-27 | 908d |  |
| 809 | 3.2.3.3.1.9 | Elaboración de la Solicitud de Propuesta (SP) que incluye: (a) la Carta de Invitación a las firmas de la lista corta; (b) las Instrucciones a los Consultores; © los TR; y (d) el contrato propuesto; y solicitud de No Objeción al Banco |  | 10d | 2017-06-20 | 2017-07-05 | 807 | 2017-06-20 | 2017-07-05 | 478d | 0d |
| 810 | 3.2.3.3.1.10 | No Objeción del Banco a la SP y conformacion Lista Corta |  | 5d | 2017-07-06 | 2017-07-12 | 809 | 2017-07-06 | 2017-07-12 | 478d | 7d |
| 811 | 3.2.3.3.1.11 | Envio de Solicitud de Propuestas (SP) a los integrantes de la lista corta (Invitación a presentar propuestas) |  | 2d | 2017-07-25 | 2017-07-26 | 803, 810 | 2017-07-25 | 2017-07-26 | 471d | 0d |
| 812 | 3.2.3.3.1.12 | Reunión aclaratoria (eventual a los diez días de la invitación) | milestone | 0d | 2017-08-10 | 2017-08-10 | 811FS+10d | 2017-08-10 | 2017-08-10 | 471d | 0d |
| 813 | 3.2.3.3.1.13 | Preparación de respuestas a las solicitudes de aclaraciones de los oferentes y solicitud de No Objeción al Banco |  | 3d | 2017-08-11 | 2017-08-15 | 812 | 2017-08-11 | 2017-08-15 | 471d | 0d |
| 814 | 3.2.3.3.1.14 | No objeción del Banco a las respuestas de aclaraciones |  | 5d | 2017-08-16 | 2017-08-23 | 813 | 2017-08-16 | 2017-08-23 | 471d | 0d |
| 815 | 3.2.3.3.1.15 | Respuesta a las solicitudes de aclaración antes de la recepción de propuestas |  | 3d | 2017-08-24 | 2017-08-28 | 814 | 2017-08-24 | 2017-08-28 | 471d | 0d |
| 816 | 3.2.3.3.1.17 | Designación del Comité de Evaluación |  | 1d | 2017-08-29 | 2017-08-29 | 815 | 2017-08-29 | 2017-08-29 | 471d | 0d |
| 817 | 3.2.3.3.1.18 | Recepción de las Propuestas técnicas y de precio y Apertura de propuestas técnicas | milestone | 0d | 2017-08-25 | 2017-08-25 | 811FS+4w | 2017-08-25 | 2017-08-25 | 473d | 2d |
| 818 | 3.2.3.3.1.19 | Envío de propuestas al Comité de Evaluación y al Especialista en Adquisiciones | milestone | 0d | 2017-08-29 | 2017-08-29 | 816, 817 | 2017-08-29 | 2017-08-29 | 471d | 0d |
| 819 | 3.2.3.3.1.20 | Evaluación de propuestas técnicas y elaboración borrador del Informe de Evaluación Técnica (IET) |  | 10d | 2017-08-30 | 2017-09-12 | 818 | 2017-08-30 | 2017-09-12 | 471d | 0d |
| 820 | 3.2.3.3.1.16 | Reunion Comité de Evaluación |  | 1d | 2017-09-13 | 2017-09-13 | 819 | 2017-09-13 | 2017-09-13 | 471d | 0d |
| 821 | 3.2.3.3.1.21 | Solicitud de No Objeción del Banco al Informe de Evaluación Técnica (IET) de las propuestas |  | 1d | 2017-09-14 | 2017-09-14 | 820 | 2017-09-14 | 2017-09-14 | 471d | 0d |
| 822 | 3.2.3.3.1.22 | No Objeción del Banco al IET |  | 5d | 2017-09-15 | 2017-09-21 | 821 | 2017-09-15 | 2017-09-21 | 471d | 0d |
| 823 | 3.2.3.3.1.23 | Notificación del puntaje de la evaluación técnica a los proponentes y notificar simultáneamente a los que obtuvieron la calificación mínima necesaria e indicar la fecha, lugar y hora fijada para abrir las propuestas de precio. |  | 1d | 2017-09-22 | 2017-09-22 | 822 | 2017-09-22 | 2017-09-22 | 471d | 0d |
| 824 | 3.2.3.3.1.24 | Apertura de propuesta de precio en Audiencia Pública | milestone | 0d | 2017-09-29 | 2017-09-29 | 823FS+5d | 2017-09-29 | 2017-09-29 | 471d | 0d |
| 825 | 3.2.3.3.1.25 | Evaluación del Costo y Evaluación Combinada de la Calidad y el Costo |  | 1d | 2017-10-02 | 2017-10-02 | 824 | 2017-10-02 | 2017-10-02 | 471d | 0d |
| 826 | 3.2.3.3.1.26 | Notificación y negociación del contrato con el proponente seleccionado, elaboración del borrador del contrato negociado y solicitud de No Objeción Banco |  | 10d | 2017-10-03 | 2017-10-17 | 825 | 2017-10-03 | 2017-10-17 | 471d | 0d |
| 827 | 3.2.3.3.1.27 | No Objeción del Banco al borrador del contrato negociado y envio acta de apertura de sobres y evaluacion combinada |  | 5d | 2017-10-18 | 2017-10-24 | 826 | 2017-10-18 | 2017-10-24 | 471d | 0d |
| 828 | 3.2.3.3.1.28 | Notificación a las demás firmas incluidas en la lista corta que sus propuestas no fueron seleccionadas |  | 1d | 2017-10-25 | 2017-10-25 | 827 | 2017-10-25 | 2017-10-25 | 471d | 0d |
| 829 | 3.2.3.3.1.29 | Publicación de la Adjudicación del Contrato |  | 1d | 2017-10-26 | 2017-10-26 | 828 | 2017-10-26 | 2017-10-26 | 471d | 0d |
| 830 | 3.2.3.3.1.30 | Legalización y Firma del Contrato |  | 10d | 2017-10-27 | 2017-11-10 | 829 | 2017-10-27 | 2017-11-10 | 471d | 0d |
| 831 | 3.2.3.3.1.31 | Envio al Banco de una copia firmada del contrato |  | 1d | 2017-11-14 | 2017-11-14 | 830 | 2017-11-14 | 2017-11-14 | 815d |  |

| ID | WBS | Task | Type | Duration | Start | Finish | Predecessors | Baseline 1 start | Baseline 1 finish | Total slack | Free slack |
| --- | --- | --- | --- | --- | --- | --- | --- | --- | --- | --- | --- |
| 832 | 3.2.4.47 | **Contractual** |  | 265d | 2017-11-14 | 2018-12-13 |  | 2017-11-14 | 2019-01-11 | 471d |  |
| 833 | 3.2.3.3.2.1 | Acta de inicio |  | 5d | 2017-11-14 | 2017-11-20 | 830 | 2017-11-14 | 2017-11-20 | 471d | 0d |
| 834 | 3.6.2.2.2.2 | Estrategia de satos e informacion implementada |  | 13mo | 2017-11-21 | 2018-12-13 | 833 | 2017-11-21 | 2019-01-11 | 471d | 0d |
| 835 | 3.6.2.2.3 | **Cierre** |  | 80d | 2018-12-14 | 2019-04-05 |  | 2019-01-14 | 2019-05-03 | 471d |  |
| 836 | 3.6.2.2.3.1 | Liquidación del contrato |  | 4mo | 2018-12-14 | 2019-04-05 | 834 | 2019-01-14 | 2019-05-03 | 471d |  |
| 837 | 3.6.2.3 | **Consultoria: Fortalecimiento de la gestion documental de la CGR. SBCC** |  | 590d | 2017-04-06 | 2019-08-23 |  | 2017-04-06 | 2019-08-23 | 371d |  |
| 838 | 3.2.3.3.1 | **Precontractual** |  | 146d | 2017-04-06 | 2017-11-14 |  | 2017-04-06 | 2017-11-14 | 371d |  |
| 839 | 3.2.3.3.1.1 | Elaboración de los términos de referencia (TR) |  | 1mo | 2017-04-06 | 2017-05-08 | 46FS+20mo | 2017-04-06 | 2017-05-08 | 371d | 0d |
| 840 | 3.2.3.3.1.3 | Preparación de la estimación de costos y presupuesto (Estudio de mercado) |  | 10d | 2017-05-09 | 2017-05-22 | 839 | 2017-05-09 | 2017-05-22 | 371d | 0d |
| 841 | 3.6.2.3.1.3 | Solicitud de vigencia futuras 2018 y 2019 | milestone | 0d | 2017-07-24 | 2017-07-24 | 840FS+2mo | 2017-07-24 | 2017-07-24 | 371d | 0d |
| 842 | 3.2.3.3.1.4 | Elaboración del Aviso Específico de Adquisiciones (AEA) solicitando expresiones de interés y solicitud de No Objeción al Banco |  | 2d | 2017-05-23 | 2017-05-24 | 840 | 2017-05-23 | 2017-05-24 | 378d | 0d |
| 843 | 3.2.3.3.1.5 | No Objeción del Banco al AEA |  | 5d | 2017-05-25 | 2017-06-01 | 842 | 2017-05-25 | 2017-06-01 | 378d | 0d |
| 844 | 3.2.3.3.1.6 | Publicación del AEA en SECOP (los contratos de valor mayor al equivalente de US $200.000 se deben anunciar ademas en los sitios de Internet del UNDB online y del Banco) |  | 2d | 2017-06-02 | 2017-06-05 | 843 | 2017-06-02 | 2017-06-05 | 378d | 0d |
| 845 | 3.2.3.3.1.7 | Recepción de expresiones de interés | milestone | 0d | 2017-06-19 | 2017-06-19 | 844FS+14ed | 2017-06-19 | 2017-06-19 | 378d | 0d |
| 846 | 3.2.3.3.1.8 | Evaluación de Expresiones de Interés recibidas y conformación de lista corta |  | 5d | 2017-06-20 | 2017-06-27 | 845 | 2017-06-20 | 2017-06-27 | 908d |  |
| 847 | 3.2.3.3.1.9 | Elaboración de la Solicitud de Propuesta (SP) que incluye: (a) la Carta de Invitación a las firmas de la lista corta; (b) las Instrucciones a los Consultores; © los TR; y (d) el contrato propuesto; y solicitud de No Objeción al Banco |  | 10d | 2017-06-20 | 2017-07-05 | 845 | 2017-06-20 | 2017-07-05 | 378d | 0d |
| 848 | 3.2.3.3.1.10 | No Objeción del Banco a la SP y conformacion Lista Corta |  | 5d | 2017-07-06 | 2017-07-12 | 847 | 2017-07-06 | 2017-07-12 | 378d | 7d |
| 849 | 3.2.3.3.1.11 | Envio de Solicitud de Propuestas (SP) a los integrantes de la lista corta (Invitación a presentar propuestas) |  | 2d | 2017-07-25 | 2017-07-26 | 848, 841 | 2017-07-25 | 2017-07-26 | 371d | 0d |
| 850 | 3.2.3.3.1.12 | Reunión aclaratoria (eventual a los diez días de la invitación) | milestone | 0d | 2017-08-10 | 2017-08-10 | 849FS+10d | 2017-08-10 | 2017-08-10 | 371d | 0d |
| 851 | 3.2.3.3.1.13 | Preparación de respuestas a las solicitudes de aclaraciones de los oferentes y solicitud de No Objeción al Banco |  | 3d | 2017-08-11 | 2017-08-15 | 850 | 2017-08-11 | 2017-08-15 | 371d | 0d |
| 852 | 3.2.3.3.1.14 | No objeción del Banco a las respuestas de aclaraciones |  | 5d | 2017-08-16 | 2017-08-23 | 851 | 2017-08-16 | 2017-08-23 | 371d | 0d |
| 853 | 3.2.3.3.1.15 | Respuesta a las solicitudes de aclaración antes de la recepción de propuestas |  | 3d | 2017-08-24 | 2017-08-28 | 852 | 2017-08-24 | 2017-08-28 | 371d | 0d |
| 854 | 3.2.3.3.1.17 | Designación del Comité de Evaluación |  | 1d | 2017-08-29 | 2017-08-29 | 853 | 2017-08-29 | 2017-08-29 | 371d | 0d |
| 855 | 3.2.3.3.1.18 | Recepción de las Propuestas técnicas y de precio y Apertura de propuestas técnicas | milestone | 0d | 2017-08-25 | 2017-08-25 | 849FS+4w | 2017-08-25 | 2017-08-25 | 373d | 2d |
| 856 | 3.2.3.3.1.19 | Envío de propuestas al Comité de Evaluación y al Especialista en Adquisiciones | milestone | 0d | 2017-08-29 | 2017-08-29 | 854, 855 | 2017-08-29 | 2017-08-29 | 371d | 0d |
| 857 | 3.2.3.3.1.20 | Evaluación de propuestas técnicas y elaboración borrador del Informe de Evaluación Técnica (IET) |  | 10d | 2017-08-30 | 2017-09-12 | 856 | 2017-08-30 | 2017-09-12 | 371d | 0d |
| 858 | 3.2.3.3.1.16 | Reunion Comité de Evaluación |  | 1d | 2017-09-13 | 2017-09-13 | 857 | 2017-09-13 | 2017-09-13 | 371d | 0d |
| 859 | 3.2.3.3.1.21 | Solicitud de No Objeción del Banco al Informe de Evaluación Técnica (IET) de las propuestas |  | 1d | 2017-09-14 | 2017-09-14 | 858 | 2017-09-14 | 2017-09-14 | 371d | 0d |
| 860 | 3.2.3.3.1.22 | No Objeción del Banco al IET |  | 5d | 2017-09-15 | 2017-09-21 | 859 | 2017-09-15 | 2017-09-21 | 371d | 0d |
| 861 | 3.2.3.3.1.23 | Notificación del puntaje de la evaluación técnica a los proponentes y notificar simultáneamente a los que obtuvieron la calificación mínima necesaria e indicar la fecha, lugar y hora fijada para abrir las propuestas de precio. |  | 1d | 2017-09-22 | 2017-09-22 | 860 | 2017-09-22 | 2017-09-22 | 371d | 0d |
| 862 | 3.2.3.3.1.24 | Apertura de propuesta de precio en Audiencia Pública | milestone | 0d | 2017-09-29 | 2017-09-29 | 861FS+5d | 2017-09-29 | 2017-09-29 | 371d | 0d |
| 863 | 3.2.3.3.1.25 | Evaluación del Costo y Evaluación Combinada de la Calidad y el Costo |  | 1d | 2017-10-02 | 2017-10-02 | 862 | 2017-10-02 | 2017-10-02 | 371d | 0d |
| 864 | 3.2.3.3.1.26 | Notificación y negociación del contrato con el proponente seleccionado, elaboración del borrador del contrato negociado y solicitud de No Objeción Banco |  | 10d | 2017-10-03 | 2017-10-17 | 863 | 2017-10-03 | 2017-10-17 | 371d | 0d |
| 865 | 3.2.3.3.1.27 | No Objeción del Banco al borrador del contrato negociado y envio acta de apertura de sobres y evaluacion combinada |  | 5d | 2017-10-18 | 2017-10-24 | 864 | 2017-10-18 | 2017-10-24 | 371d | 0d |
| 866 | 3.2.3.3.1.28 | Notificación a las demás firmas incluidas en la lista corta que sus propuestas no fueron seleccionadas |  | 1d | 2017-10-25 | 2017-10-25 | 865 | 2017-10-25 | 2017-10-25 | 371d | 0d |
| 867 | 3.2.3.3.1.29 | Publicación de la Adjudicación del Contrato |  | 1d | 2017-10-26 | 2017-10-26 | 866 | 2017-10-26 | 2017-10-26 | 371d | 0d |
| 868 | 3.2.3.3.1.30 | Legalización y Firma del Contrato |  | 10d | 2017-10-27 | 2017-11-10 | 867 | 2017-10-27 | 2017-11-10 | 371d | 0d |
| 869 | 3.2.3.3.1.31 | Envio al Banco de una copia firmada del contrato |  | 1d | 2017-11-14 | 2017-11-14 | 868 | 2017-11-14 | 2017-11-14 | 815d |  |

| ID | WBS | Task | Type | Duration | Start | Finish | Predecessors | Baseline 1 start | Baseline 1 finish | Total slack | Free slack |
| --- | --- | --- | --- | --- | --- | --- | --- | --- | --- | --- | --- |
| 870 | 3.2.4.47 | **Contractual** |  | 365d | 2017-11-14 | 2019-05-03 |  | 2017-11-14 | 2019-05-03 | 371d |  |
| 871 | 3.2.3.3.2.1 | Acta de inicio |  | 5d | 2017-11-14 | 2017-11-20 | 868 | 2017-11-14 | 2017-11-20 | 371d | 0d |
| 872 | 3.6.2.3.2.2 | Gestion documental de la CGR fortalecida |  | 18mo | 2017-11-21 | 2019-05-03 | 871 | 2017-11-21 | 2019-05-03 | 371d | 0d |
| 873 | 3.6.2.3.3 | **Cierre** |  | 80d | 2019-05-06 | 2019-08-23 |  | 2019-05-06 | 2019-08-23 | 371d |  |
| 874 | 3.6.2.3.3.1 | Liquidación del contrato |  | 4mo | 2019-05-06 | 2019-08-23 | 872 | 2019-05-06 | 2019-08-23 | 371d |  |
| 875 | 3.6.2.4 | **Consultoria: Diseno e implementacion de solucion informatica de apoyo al modelo de gestion de conocimiento definido. SBCC** |  | 470d | 2017-04-06 | 2019-03-08 |  | 2017-04-06 | 2019-03-08 | 491d |  |
| 876 | 3.2.3.3.1 | **Precontractual** |  | 146d | 2017-04-06 | 2017-11-14 |  | 2017-04-06 | 2017-11-14 | 491d |  |
| 877 | 3.2.3.3.1.1 | Elaboración de los términos de referencia (TR) |  | 1mo | 2017-04-06 | 2017-05-08 | 46FS+20mo | 2017-04-06 | 2017-05-08 | 491d | 0d |
| 878 | 3.2.3.3.1.3 | Preparación de la estimación de costos y presupuesto (Estudio de mercado) |  | 10d | 2017-05-09 | 2017-05-22 | 877 | 2017-05-09 | 2017-05-22 | 491d | 0d |
| 879 | 3.6.2.4.1.3 | Solicitud de vigencia futuras 2018 | milestone | 0d | 2017-07-24 | 2017-07-24 | 878FS+2mo | 2017-07-24 | 2017-07-24 | 491d | 0d |
| 880 | 3.2.3.3.1.4 | Elaboración del Aviso Específico de Adquisiciones (AEA) solicitando expresiones de interés y solicitud de No Objeción al Banco |  | 2d | 2017-05-23 | 2017-05-24 | 878 | 2017-05-23 | 2017-05-24 | 497d | 0d |
| 881 | 3.2.3.3.1.5 | No Objeción del Banco al AEA |  | 5d | 2017-05-25 | 2017-06-01 | 880 | 2017-05-25 | 2017-06-01 | 497d | 0d |
| 882 | 3.2.3.3.1.6 | Publicación del AEA en SECOP (los contratos de valor mayor al equivalente de US $200.000 se deben anunciar ademas en los sitios de Internet del UNDB online y del Banco) |  | 2d | 2017-06-02 | 2017-06-05 | 881 | 2017-06-02 | 2017-06-05 | 497d | 0d |
| 883 | 3.2.3.3.1.7 | Recepción de expresiones de interés | milestone | 0d | 2017-06-19 | 2017-06-19 | 882FS+14ed | 2017-06-19 | 2017-06-19 | 498d | 0d |
| 884 | 3.2.3.3.1.8 | Evaluación de Expresiones de Interés recibidas y conformación de lista corta |  | 5d | 2017-06-20 | 2017-06-27 | 883 | 2017-06-20 | 2017-06-27 | 908d |  |
| 885 | 3.2.3.3.1.9 | Elaboración de la Solicitud de Propuesta (SP) que incluye: (a) la Carta de Invitación a las firmas de la lista corta; (b) las Instrucciones a los Consultores; © los TR; y (d) el contrato propuesto; y solicitud de No Objeción al Banco |  | 10d | 2017-06-20 | 2017-07-05 | 883 | 2017-06-20 | 2017-07-05 | 498d | 0d |
| 886 | 3.2.3.3.1.10 | No Objeción del Banco a la SP y conformacion Lista Corta |  | 5d | 2017-07-06 | 2017-07-12 | 885 | 2017-07-06 | 2017-07-12 | 498d | 7d |
| 887 | 3.2.3.3.1.11 | Envio de Solicitud de Propuestas (SP) a los integrantes de la lista corta (Invitación a presentar propuestas) |  | 2d | 2017-07-25 | 2017-07-26 | 879, 886 | 2017-07-25 | 2017-07-26 | 491d | 0d |
| 888 | 3.2.3.3.1.12 | Reunión aclaratoria (eventual a los diez días de la invitación) | milestone | 0d | 2017-08-10 | 2017-08-10 | 887FS+10d | 2017-08-10 | 2017-08-10 | 491d | 0d |
| 889 | 3.2.3.3.1.13 | Preparación de respuestas a las solicitudes de aclaraciones de los oferentes y solicitud de No Objeción al Banco |  | 3d | 2017-08-11 | 2017-08-15 | 888 | 2017-08-11 | 2017-08-15 | 491d | 0d |
| 890 | 3.2.3.3.1.14 | No objeción del Banco a las respuestas de aclaraciones |  | 5d | 2017-08-16 | 2017-08-23 | 889 | 2017-08-16 | 2017-08-23 | 491d | 0d |
| 891 | 3.2.3.3.1.15 | Respuesta a las solicitudes de aclaración antes de la recepción de propuestas |  | 3d | 2017-08-24 | 2017-08-28 | 890 | 2017-08-24 | 2017-08-28 | 491d | 0d |
| 892 | 3.2.3.3.1.17 | Designación del Comité de Evaluación |  | 1d | 2017-08-29 | 2017-08-29 | 891 | 2017-08-29 | 2017-08-29 | 491d | 0d |
| 893 | 3.2.3.3.1.18 | Recepción de las Propuestas técnicas y de precio y Apertura de propuestas técnicas | milestone | 0d | 2017-08-25 | 2017-08-25 | 887FS+4w | 2017-08-25 | 2017-08-25 | 493d | 2d |
| 894 | 3.2.3.3.1.19 | Envío de propuestas al Comité de Evaluación y al Especialista en Adquisiciones | milestone | 0d | 2017-08-29 | 2017-08-29 | 892, 893 | 2017-08-29 | 2017-08-29 | 491d | 0d |
| 895 | 3.2.3.3.1.20 | Evaluación de propuestas técnicas y elaboración borrador del Informe de Evaluación Técnica (IET) |  | 10d | 2017-08-30 | 2017-09-12 | 894 | 2017-08-30 | 2017-09-12 | 491d | 0d |
| 896 | 3.2.3.3.1.16 | Reunion Comité de Evaluación |  | 1d | 2017-09-13 | 2017-09-13 | 895 | 2017-09-13 | 2017-09-13 | 491d | 0d |
| 897 | 3.2.3.3.1.21 | Solicitud de No Objeción del Banco al Informe de Evaluación Técnica (IET) de las propuestas |  | 1d | 2017-09-14 | 2017-09-14 | 896 | 2017-09-14 | 2017-09-14 | 491d | 0d |
| 898 | 3.2.3.3.1.22 | No Objeción del Banco al IET |  | 5d | 2017-09-15 | 2017-09-21 | 897 | 2017-09-15 | 2017-09-21 | 491d | 0d |
| 899 | 3.2.3.3.1.23 | Notificación del puntaje de la evaluación técnica a los proponentes y notificar simultáneamente a los que obtuvieron la calificación mínima necesaria e indicar la fecha, lugar y hora fijada para abrir las propuestas de precio. |  | 1d | 2017-09-22 | 2017-09-22 | 898 | 2017-09-22 | 2017-09-22 | 491d | 0d |
| 900 | 3.2.3.3.1.24 | Apertura de propuesta de precio en Audiencia Pública | milestone | 0d | 2017-09-29 | 2017-09-29 | 899FS+5d | 2017-09-29 | 2017-09-29 | 491d | 0d |
| 901 | 3.2.3.3.1.25 | Evaluación del Costo y Evaluación Combinada de la Calidad y el Costo |  | 1d | 2017-10-02 | 2017-10-02 | 900 | 2017-10-02 | 2017-10-02 | 491d | 0d |
| 902 | 3.2.3.3.1.26 | Notificación y negociación del contrato con el proponente seleccionado, elaboración del borrador del contrato negociado y solicitud de No Objeción Banco |  | 10d | 2017-10-03 | 2017-10-17 | 901 | 2017-10-03 | 2017-10-17 | 491d | 0d |
| 903 | 3.2.3.3.1.27 | No Objeción del Banco al borrador del contrato negociado y envio acta de apertura de sobres y evaluacion combinada |  | 5d | 2017-10-18 | 2017-10-24 | 902 | 2017-10-18 | 2017-10-24 | 491d | 0d |
| 904 | 3.2.3.3.1.28 | Notificación a las demás firmas incluidas en la lista corta que sus propuestas no fueron seleccionadas |  | 1d | 2017-10-25 | 2017-10-25 | 903 | 2017-10-25 | 2017-10-25 | 491d | 0d |
| 905 | 3.2.3.3.1.29 | Publicación de la Adjudicación del Contrato |  | 1d | 2017-10-26 | 2017-10-26 | 904 | 2017-10-26 | 2017-10-26 | 491d | 0d |
| 906 | 3.2.3.3.1.30 | Legalización y Firma del Contrato |  | 10d | 2017-10-27 | 2017-11-10 | 905 | 2017-10-27 | 2017-11-10 | 491d | 0d |
| 907 | 3.2.3.3.1.31 | Envio al Banco de una copia firmada del contrato |  | 1d | 2017-11-14 | 2017-11-14 | 906 | 2017-11-14 | 2017-11-14 | 815d |  |

| ID | WBS | Task | Type | Duration | Start | Finish | Predecessors | Baseline 1 start | Baseline 1 finish | Total slack | Free slack |
| --- | --- | --- | --- | --- | --- | --- | --- | --- | --- | --- | --- |
| 908 | 3.2.4.47 | **Contractual** |  | 245d | 2017-11-14 | 2018-11-15 |  | 2017-11-14 | 2018-11-15 | 491d |  |
| 909 | 3.2.3.3.2.1 | Acta de inicio |  | 5d | 2017-11-14 | 2017-11-20 | 906 | 2017-11-14 | 2017-11-20 | 491d | 0d |
| 910 | 3.6.2.4.2.2 | Solucion informatica de apoyo al modelo de gestion de conocimiento disenada e implementada |  | 12mo | 2017-11-21 | 2018-11-15 | 909 | 2017-11-21 | 2018-11-15 | 491d | 0d |
| 911 | 3.6.2.4.3 | **Cierre** |  | 80d | 2018-11-16 | 2019-03-08 |  | 2018-11-16 | 2019-03-08 | 491d |  |
| 912 | 3.6.2.4.3.1 | Liquidación del contrato |  | 4mo | 2018-11-16 | 2019-03-08 | 910 | 2018-11-16 | 2019-03-08 | 491d |  |
| 913 | 3.6.3 | **Producto 13 - Modelo de inteligencia de negocios diseñado e implementado** |  | 769d | 2015-08-25 | 2018-10-12 |  | 2015-08-25 | 2018-06-18 | 542d |  |
| 914 | 3.6.3.1 | **Consultoria: Diseno e implementacion del modelo de inteligencia de negocios. SBCC** |  | 769d | 2015-08-25 | 2018-10-12 |  | 2015-08-25 | 2018-06-18 | 542d |  |
| 915 | 3.2.3.3.1 | **Precontractual** |  | 225d | 2015-08-25 | 2016-07-25 |  | 2015-08-25 | 2016-07-25 | 542d |  |
| 916 | 3.2.3.3.1.1 | Elaboración de los términos de referencia (TR) |  | 2mo | 2015-08-25 | 2015-10-20 | 46 | 2015-08-25 | 2015-10-20 | 542d | 0d |
| 917 | 3.2.3.3.1.3 | Preparación de la estimación de costos y presupuesto (Estudio de mercado) |  | 10d | 2015-10-21 | 2015-11-04 | 916 | 2015-10-21 | 2015-11-04 | 542d | 0d |
| 918 | 3.2.3.3.1.4 | Elaboración del Aviso Específico de Adquisiciones (AEA) solicitando expresiones de interés y solicitud de No Objeción al Banco |  | 2d | 2015-11-05 | 2015-11-06 | 917 | 2015-11-05 | 2015-11-06 | 542d | 0d |
| 919 | 3.2.3.3.1.5 | No Objeción del Banco al AEA |  | 5d | 2015-11-09 | 2015-11-13 | 918 | 2015-11-09 | 2015-11-13 | 542d | 0d |
| 920 | 3.2.3.3.1.6 | Publicación del AEA en SECOP (los contratos de valor mayor al equivalente de US $200.000 se deben anunciar ademas en los sitios de Internet del UNDB online y del Banco) |  | 2d | 2015-11-17 | 2015-11-18 | 919 | 2015-11-17 | 2015-11-18 | 542d | 0d |
| 921 | 3.2.3.3.1.7 | Recepción de expresiones de interés | milestone | 0d | 2015-12-02 | 2015-12-02 | 920FS+14ed | 2015-12-02 | 2015-12-02 | 542d | 0d |
| 922 | 3.2.3.3.1.8 | Evaluación de Expresiones de Interés recibidas y conformación de lista corta |  | 5d | 2015-12-03 | 2015-12-10 | 921 | 2015-12-03 | 2015-12-10 | 1287d |  |
| 923 | 3.2.3.3.1.9 | Elaboración de la Solicitud de Propuesta (SP) que incluye: (a) la Carta de Invitación a las firmas de la lista corta; (b) las Instrucciones a los Consultores; © los TR; y (d) el contrato propuesto; y solicitud de No Objeción al Banco |  | 20d | 2015-12-03 | 2016-01-04 | 921 | 2015-12-03 | 2016-01-04 | 542d | 0d |
| 924 | 3.2.3.3.1.10 | No Objeción del Banco a la SP y conformacion Lista Corta |  | 5d | 2016-01-05 | 2016-01-12 | 923 | 2016-01-05 | 2016-01-12 | 542d | 0d |
| 925 | 3.6.3.1.1.10 | Solicitud de vigencias futuras 2017 y 2018 | milestone | 0d | 2016-03-08 | 2016-03-08 | 924FS+2mo | 2016-03-08 | 2016-03-08 | 542d | 0d |
| 926 | 3.2.3.3.1.11 | Envio de Solicitud de Propuestas (SP) a los integrantes de la lista corta (Invitación a presentar propuestas) |  | 2d | 2016-03-09 | 2016-03-10 | 925 | 2016-03-09 | 2016-03-10 | 542d | 0d |
| 927 | 3.2.3.3.1.12 | Reunión aclaratoria (eventual a los diez días de la invitación) | milestone | 0d | 2016-03-29 | 2016-03-29 | 926FS+10d | 2016-03-29 | 2016-03-29 | 542d | 0d |
| 928 | 3.2.3.3.1.13 | Preparación de respuestas a las solicitudes de aclaraciones de los oferentes y solicitud de No Objeción al Banco |  | 3d | 2016-03-30 | 2016-04-01 | 927 | 2016-03-30 | 2016-04-01 | 542d | 0d |
| 929 | 3.2.3.3.1.14 | No objeción del Banco a las respuestas de aclaraciones |  | 5d | 2016-04-04 | 2016-04-08 | 928 | 2016-04-04 | 2016-04-08 | 542d | 0d |
| 930 | 3.2.3.3.1.15 | Respuesta a las solicitudes de aclaración antes de la recepción de propuestas |  | 3d | 2016-04-11 | 2016-04-13 | 929 | 2016-04-11 | 2016-04-13 | 542d | 0d |
| 931 | 3.2.3.3.1.17 | Designación del Comité de Evaluación |  | 1d | 2016-04-14 | 2016-04-14 | 930 | 2016-04-14 | 2016-04-14 | 542d | 0d |
| 932 | 3.2.3.3.1.18 | Recepción de las Propuestas técnicas y de precio y Apertura de propuestas técnicas | milestone | 0d | 2016-04-12 | 2016-04-12 | 926FS+4w | 2016-04-12 | 2016-04-12 | 544d | 2d |
| 933 | 3.2.3.3.1.19 | Envío de propuestas al Comité de Evaluación y al Especialista en Adquisiciones | milestone | 0d | 2016-04-14 | 2016-04-14 | 931, 932 | 2016-04-14 | 2016-04-14 | 542d | 0d |
| 934 | 3.2.3.3.1.20 | Evaluación de propuestas técnicas y elaboración borrador del Informe de Evaluación Técnica (IET) |  | 15d | 2016-04-15 | 2016-05-05 | 933 | 2016-04-15 | 2016-05-05 | 542d | 0d |
| 935 | 3.2.3.3.1.16 | Reunion Comité de Evaluación |  | 1d | 2016-05-06 | 2016-05-06 | 934 | 2016-05-06 | 2016-05-06 | 542d | 0d |
| 936 | 3.2.3.3.1.21 | Solicitud de No Objeción del Banco al Informe de Evaluación Técnica (IET) de las propuestas |  | 1d | 2016-05-10 | 2016-05-10 | 935 | 2016-05-10 | 2016-05-10 | 542d | 0d |
| 937 | 3.2.3.3.1.22 | No Objeción del Banco al IET |  | 5d | 2016-05-11 | 2016-05-17 | 936 | 2016-05-11 | 2016-05-17 | 542d | 0d |
| 938 | 3.2.3.3.1.23 | Notificación del puntaje de la evaluación técnica a los proponentes y notificar simultáneamente a los que obtuvieron la calificación mínima necesaria e indicar la fecha, lugar y hora fijada para abrir las propuestas de precio. |  | 1d | 2016-05-18 | 2016-05-18 | 937 | 2016-05-18 | 2016-05-18 | 542d | 0d |
| 939 | 3.2.3.3.1.24 | Apertura de propuesta de precio en Audiencia Pública | milestone | 0d | 2016-05-25 | 2016-05-25 | 938FS+5d | 2016-05-25 | 2016-05-25 | 542d | 0d |
| 940 | 3.2.3.3.1.25 | Evaluación del Costo y Evaluación Combinada de la Calidad y el Costo |  | 1d | 2016-05-26 | 2016-05-26 | 939 | 2016-05-26 | 2016-05-26 | 542d | 0d |
| 941 | 3.2.3.3.1.26 | Notificación y negociación del contrato con el proponente seleccionado, elaboración del borrador del contrato negociado y solicitud de No Objeción Banco |  | 15d | 2016-05-27 | 2016-06-20 | 940 | 2016-05-27 | 2016-06-20 | 542d | 0d |
| 942 | 3.2.3.3.1.27 | No Objeción del Banco al borrador del contrato negociado y envio acta de apertura de sobres y evaluacion combinada |  | 5d | 2016-06-21 | 2016-06-27 | 941 | 2016-06-21 | 2016-06-27 | 542d | 0d |
| 943 | 3.2.3.3.1.28 | Notificación a las demás firmas incluidas en la lista corta que sus propuestas no fueron seleccionadas |  | 1d | 2016-06-28 | 2016-06-28 | 942 | 2016-06-28 | 2016-06-28 | 542d | 0d |
| 944 | 3.2.3.3.1.29 | Publicación de la Adjudicación del Contrato |  | 1d | 2016-06-29 | 2016-06-29 | 943 | 2016-06-29 | 2016-06-29 | 542d | 0d |
| 945 | 3.2.3.3.1.30 | Legalización y Firma del Contrato |  | 15d | 2016-06-30 | 2016-07-22 | 944 | 2016-06-30 | 2016-07-22 | 542d | 0d |
| 946 | 3.2.3.3.1.31 | Envio al Banco de una copia firmada del contrato |  | 1d | 2016-07-25 | 2016-07-25 | 945 | 2016-07-25 | 2016-07-25 | 1136d |  |

| ID | WBS | Task | Type | Duration | Start | Finish | Predecessors | Baseline 1 start | Baseline 1 finish | Total slack | Free slack |
| --- | --- | --- | --- | --- | --- | --- | --- | --- | --- | --- | --- |
| 947 | 3.2.4.47 | **Contractual** |  | 465d | 2016-07-25 | 2018-06-18 |  | 2016-07-25 | 2018-02-15 | 542d |  |
| 948 | 3.2.3.3.2.1 | Acta de inicio |  | 5d | 2016-07-25 | 2016-07-29 | 945 | 2016-07-25 | 2016-07-29 | 542d | 0d |
| 949 | 3.6.3.1.2.2 | Modelo de inteligencia de negocios disenado e implementado |  | 23mo | 2016-08-01 | 2018-06-18 | 948 | 2016-08-01 | 2018-02-15 | 592d | 0d |
| 950 | 3.6.3.1.3 | **Cierre** |  | 80d | 2018-06-19 | 2018-10-12 |  | 2018-02-16 | 2018-06-18 | 592d |  |
| 951 | 3.6.3.1.3.1 | Liquidación del contrato |  | 4mo | 2018-06-19 | 2018-10-12 | 949 | 2018-02-16 | 2018-06-18 | 592d |  |
| 952 | 3.6.4 | **Producto 14 - Tablero de control disenado e implementado** |  | 470d | 2017-01-24 | 2018-12-27 |  | 2017-01-24 | 2018-12-27 | 542d |  |
| 953 | 3.6.4.1 | **Consultoria: Diseno e implementacion de un tablero de control. SBCC** |  | 470d | 2017-01-24 | 2018-12-27 |  | 2017-01-24 | 2018-12-27 | 542d |  |
| 954 | 3.2.3.3.1 | **Precontractual** |  | 146d | 2017-01-24 | 2017-08-30 |  | 2017-01-24 | 2017-08-30 | 542d |  |
| 955 | 3.2.3.3.1.1 | Elaboración de los términos de referencia (TR) |  | 1mo | 2017-01-24 | 2017-02-20 | 948FS+6mo | 2017-01-24 | 2017-02-20 | 542d | 0d |
| 956 | 3.2.3.3.1.3 | Preparación de la estimación de costos y presupuesto (Estudio de mercado) |  | 10d | 2017-02-21 | 2017-03-06 | 955 | 2017-02-21 | 2017-03-06 | 542d | 0d |
| 957 | 3.6.4.1.1.3 | Solicitud de vigencia futuras 2018 | milestone | 0d | 2017-05-05 | 2017-05-05 | 956FS+2mo | 2017-05-05 | 2017-05-05 | 542d | 0d |
| 958 | 3.2.3.3.1.4 | Elaboración del Aviso Específico de Adquisiciones (AEA) solicitando expresiones de interés y solicitud de No Objeción al Banco |  | 2d | 2017-03-07 | 2017-03-08 | 956 | 2017-03-07 | 2017-03-08 | 548d | 0d |
| 959 | 3.2.3.3.1.5 | No Objeción del Banco al AEA |  | 5d | 2017-03-09 | 2017-03-15 | 958 | 2017-03-09 | 2017-03-15 | 548d | 0d |
| 960 | 3.2.3.3.1.6 | Publicación del AEA en SECOP (los contratos de valor mayor al equivalente de US $200.000 se deben anunciar ademas en los sitios de Internet del UNDB online y del Banco) |  | 2d | 2017-03-16 | 2017-03-17 | 959 | 2017-03-16 | 2017-03-17 | 548d | 0d |
| 961 | 3.2.3.3.1.7 | Recepción de expresiones de interés | milestone | 0d | 2017-03-31 | 2017-03-31 | 960FS+14ed | 2017-03-31 | 2017-03-31 | 549d | 0d |
| 962 | 3.2.3.3.1.8 | Evaluación de Expresiones de Interés recibidas y conformación de lista corta |  | 5d | 2017-04-03 | 2017-04-07 | 961 | 2017-04-03 | 2017-04-07 | 959d |  |
| 963 | 3.2.3.3.1.9 | Elaboración de la Solicitud de Propuesta (SP) que incluye: (a) la Carta de Invitación a las firmas de la lista corta; (b) las Instrucciones a los Consultores; © los TR; y (d) el contrato propuesto; y solicitud de No Objeción al Banco |  | 10d | 2017-04-03 | 2017-04-18 | 961 | 2017-04-03 | 2017-04-18 | 549d | 0d |
| 964 | 3.2.3.3.1.10 | No Objeción del Banco a la SP y conformacion Lista Corta |  | 5d | 2017-04-19 | 2017-04-25 | 963 | 2017-04-19 | 2017-04-25 | 549d | 7d |
| 965 | 3.2.3.3.1.11 | Envio de Solicitud de Propuestas (SP) a los integrantes de la lista corta (Invitación a presentar propuestas) |  | 2d | 2017-05-08 | 2017-05-09 | 957, 964 | 2017-05-08 | 2017-05-09 | 542d | 0d |
| 966 | 3.2.3.3.1.12 | Reunión aclaratoria (eventual a los diez días de la invitación) | milestone | 0d | 2017-05-23 | 2017-05-23 | 965FS+10d | 2017-05-23 | 2017-05-23 | 542d | 0d |
| 967 | 3.2.3.3.1.13 | Preparación de respuestas a las solicitudes de aclaraciones de los oferentes y solicitud de No Objeción al Banco |  | 3d | 2017-05-24 | 2017-05-26 | 966 | 2017-05-24 | 2017-05-26 | 542d | 0d |
| 968 | 3.2.3.3.1.14 | No objeción del Banco a las respuestas de aclaraciones |  | 5d | 2017-05-30 | 2017-06-05 | 967 | 2017-05-30 | 2017-06-05 | 542d | 0d |
| 969 | 3.2.3.3.1.15 | Respuesta a las solicitudes de aclaración antes de la recepción de propuestas |  | 3d | 2017-06-06 | 2017-06-08 | 968 | 2017-06-06 | 2017-06-08 | 542d | 0d |
| 970 | 3.2.3.3.1.17 | Designación del Comité de Evaluación |  | 1d | 2017-06-09 | 2017-06-09 | 969 | 2017-06-09 | 2017-06-09 | 542d | 0d |
| 971 | 3.2.3.3.1.18 | Recepción de las Propuestas técnicas y de precio y Apertura de propuestas técnicas | milestone | 0d | 2017-06-07 | 2017-06-07 | 965FS+4w | 2017-06-07 | 2017-06-07 | 544d | 2d |
| 972 | 3.2.3.3.1.19 | Envío de propuestas al Comité de Evaluación y al Especialista en Adquisiciones | milestone | 0d | 2017-06-09 | 2017-06-09 | 970, 971 | 2017-06-09 | 2017-06-09 | 542d | 0d |
| 973 | 3.2.3.3.1.20 | Evaluación de propuestas técnicas y elaboración borrador del Informe de Evaluación Técnica (IET) |  | 10d | 2017-06-12 | 2017-06-27 | 972 | 2017-06-12 | 2017-06-27 | 542d | 0d |
| 974 | 3.2.3.3.1.16 | Reunion Comité de Evaluación |  | 1d | 2017-06-28 | 2017-06-28 | 973 | 2017-06-28 | 2017-06-28 | 542d | 0d |
| 975 | 3.2.3.3.1.21 | Solicitud de No Objeción del Banco al Informe de Evaluación Técnica (IET) de las propuestas |  | 1d | 2017-06-29 | 2017-06-29 | 974 | 2017-06-29 | 2017-06-29 | 542d | 0d |
| 976 | 3.2.3.3.1.22 | No Objeción del Banco al IET |  | 5d | 2017-06-30 | 2017-07-07 | 975 | 2017-06-30 | 2017-07-07 | 542d | 0d |
| 977 | 3.2.3.3.1.23 | Notificación del puntaje de la evaluación técnica a los proponentes y notificar simultáneamente a los que obtuvieron la calificación mínima necesaria e indicar la fecha, lugar y hora fijada para abrir las propuestas de precio. |  | 1d | 2017-07-10 | 2017-07-10 | 976 | 2017-07-10 | 2017-07-10 | 542d | 0d |
| 978 | 3.2.3.3.1.24 | Apertura de propuesta de precio en Audiencia Pública | milestone | 0d | 2017-07-17 | 2017-07-17 | 977FS+5d | 2017-07-17 | 2017-07-17 | 542d | 0d |
| 979 | 3.2.3.3.1.25 | Evaluación del Costo y Evaluación Combinada de la Calidad y el Costo |  | 1d | 2017-07-18 | 2017-07-18 | 978 | 2017-07-18 | 2017-07-18 | 542d | 0d |
| 980 | 3.2.3.3.1.26 | Notificación y negociación del contrato con el proponente seleccionado, elaboración del borrador del contrato negociado y solicitud de No Objeción Banco |  | 10d | 2017-07-19 | 2017-08-02 | 979 | 2017-07-19 | 2017-08-02 | 542d | 0d |
| 981 | 3.2.3.3.1.27 | No Objeción del Banco al borrador del contrato negociado y envio acta de apertura de sobres y evaluacion combinada |  | 5d | 2017-08-03 | 2017-08-10 | 980 | 2017-08-03 | 2017-08-10 | 542d | 0d |
| 982 | 3.2.3.3.1.28 | Notificación a las demás firmas incluidas en la lista corta que sus propuestas no fueron seleccionadas |  | 1d | 2017-08-11 | 2017-08-11 | 981 | 2017-08-11 | 2017-08-11 | 542d | 0d |
| 983 | 3.2.3.3.1.29 | Publicación de la Adjudicación del Contrato |  | 1d | 2017-08-14 | 2017-08-14 | 982 | 2017-08-14 | 2017-08-14 | 542d | 0d |
| 984 | 3.2.3.3.1.30 | Legalización y Firma del Contrato |  | 10d | 2017-08-15 | 2017-08-29 | 983 | 2017-08-15 | 2017-08-29 | 542d | 0d |
| 985 | 3.2.3.3.1.31 | Envio al Banco de una copia firmada del contrato |  | 1d | 2017-08-30 | 2017-08-30 | 984 | 2017-08-30 | 2017-08-30 | 866d |  |

| ID | WBS | Task | Type | Duration | Start | Finish | Predecessors | Baseline 1 start | Baseline 1 finish | Total slack | Free slack |
| --- | --- | --- | --- | --- | --- | --- | --- | --- | --- | --- | --- |
| 986 | 3.2.4.47 | **Contractual** |  | 245d | 2017-08-30 | 2018-08-31 |  | 2017-08-30 | 2018-08-31 | 542d |  |
| 987 | 3.2.3.3.2.1 | Acta de inicio |  | 5d | 2017-08-30 | 2017-09-05 | 984 | 2017-08-30 | 2017-09-05 | 542d | 0d |
| 988 | 3.6.4.1.2.2 | Tablero de control disenado e implementado |  | 12mo | 2017-09-06 | 2018-08-31 | 987 | 2017-09-06 | 2018-08-31 | 542d | 0d |
| 989 | 3.6.4.1.3 | **Cierre** |  | 80d | 2018-09-03 | 2018-12-27 |  | 2018-09-03 | 2018-12-27 | 542d |  |
| 990 | 3.6.4.1.3.1 | Liquidación del contrato |  | 4mo | 2018-09-03 | 2018-12-27 | 988 | 2018-09-03 | 2018-12-27 | 542d |  |
| 991 | 3.6.5 | **Producto 15 - Sistema de soporte para el control en linea disenado e implementado** |  | 480d | 2016-09-14 | 2018-09-03 |  | 2016-09-14 | 2018-09-03 | 620d |  |
| 992 | 3.6.5.1 | **Consultoria: Diseno e implementacion de un sistema de control en linea. SBCC** |  | 480d | 2016-09-14 | 2018-09-03 |  | 2016-09-14 | 2018-09-03 | 620d |  |
| 993 | 3.2.3.3.1 | **Precontractual** |  | 196d | 2016-09-14 | 2017-06-30 |  | 2016-09-14 | 2017-06-30 | 620d |  |
| 994 | 3.2.3.3.1.1 | Elaboración de los términos de referencia (TR) |  | 1.5mo | 2016-09-14 | 2016-10-26 | 46FS+13mo | 2016-09-14 | 2016-10-26 | 620d | 0d |
| 995 | 3.2.3.3.1.3 | Preparación de la estimación de costos y presupuesto (Estudio de mercado) |  | 12d | 2016-10-27 | 2016-11-15 | 994 | 2016-10-27 | 2016-11-15 | 620d | 0d |
| 996 | 3.2.3.3.1.4 | Elaboración del Aviso Específico de Adquisiciones (AEA) solicitando expresiones de interés y solicitud de No Objeción al Banco |  | 2d | 2016-11-16 | 2016-11-17 | 995 | 2016-11-16 | 2016-11-17 | 620d | 0d |
| 997 | 3.2.3.3.1.5 | No Objeción del Banco al AEA |  | 5d | 2016-11-18 | 2016-11-24 | 996 | 2016-11-18 | 2016-11-24 | 620d | 0d |
| 998 | 3.2.3.3.1.6 | Publicación del AEA en SECOP (los contratos de valor mayor al equivalente de US $200.000 se deben anunciar ademas en los sitios de Internet del UNDB online y del Banco) |  | 2d | 2016-11-25 | 2016-11-28 | 997 | 2016-11-25 | 2016-11-28 | 620d | 0d |
| 999 | 3.2.3.3.1.7 | Recepción de expresiones de interés | milestone | 0d | 2016-12-12 | 2016-12-12 | 998FS+14ed | 2016-12-12 | 2016-12-12 | 621d | 0d |
| 1000 | 3.2.3.3.1.8 | Evaluación de Expresiones de Interés recibidas y conformación de lista corta |  | 5d | 2016-12-13 | 2016-12-19 | 999 | 2016-12-13 | 2016-12-19 | 1036d |  |
| 1001 | 3.2.3.3.1.9 | Elaboración de la Solicitud de Propuesta (SP) que incluye: (a) la Carta de Invitación a las firmas de la lista corta; (b) las Instrucciones a los Consultores; © los TR; y (d) el contrato propuesto; y solicitud de No Objeción al Banco |  | 15d | 2016-12-13 | 2017-01-02 | 999 | 2016-12-13 | 2017-01-02 | 621d | 0d |
| 1002 | 3.2.3.3.1.10 | No Objeción del Banco a la SP y conformacion Lista Corta |  | 5d | 2017-01-03 | 2017-01-10 | 1001 | 2017-01-03 | 2017-01-10 | 621d | 0d |
| 1003 | 3.6.5.1.1.10 | Solicitud vigencias futuras 2018 | milestone | 0d | 2017-03-07 | 2017-03-07 | 1002FS+2mo | 2017-03-07 | 2017-03-07 | 621d | 0d |
| 1004 | 3.2.3.3.1.11 | Envio de Solicitud de Propuestas (SP) a los integrantes de la lista corta (Invitación a presentar propuestas) |  | 2d | 2017-03-08 | 2017-03-09 | 1003 | 2017-03-08 | 2017-03-09 | 621d | 0d |
| 1005 | 3.2.3.3.1.12 | Reunión aclaratoria (eventual a los diez días de la invitación) | milestone | 0d | 2017-03-24 | 2017-03-24 | 1004FS+10d | 2017-03-24 | 2017-03-24 | 621d | 0d |
| 1006 | 3.2.3.3.1.13 | Preparación de respuestas a las solicitudes de aclaraciones de los oferentes y solicitud de No Objeción al Banco |  | 3d | 2017-03-27 | 2017-03-29 | 1005 | 2017-03-27 | 2017-03-29 | 621d | 0d |
| 1007 | 3.2.3.3.1.14 | No objeción del Banco a las respuestas de aclaraciones |  | 5d | 2017-03-30 | 2017-04-05 | 1006 | 2017-03-30 | 2017-04-05 | 621d | 0d |
| 1008 | 3.2.3.3.1.15 | Respuesta a las solicitudes de aclaración antes de la recepción de propuestas |  | 3d | 2017-04-06 | 2017-04-10 | 1007 | 2017-04-06 | 2017-04-10 | 621d | 0d |
| 1009 | 3.2.3.3.1.17 | Designación del Comité de Evaluación |  | 1d | 2017-04-11 | 2017-04-11 | 1008 | 2017-04-11 | 2017-04-11 | 621d | 0d |
| 1010 | 3.2.3.3.1.18 | Recepción de las Propuestas técnicas y de precio y Apertura de propuestas técnicas | milestone | 0d | 2017-04-07 | 2017-04-07 | 1004FS+4w | 2017-04-07 | 2017-04-07 | 623d | 2d |
| 1011 | 3.2.3.3.1.19 | Envío de propuestas al Comité de Evaluación y al Especialista en Adquisiciones | milestone | 0d | 2017-04-11 | 2017-04-11 | 1009, 1010 | 2017-04-11 | 2017-04-11 | 621d | 0d |
| 1012 | 3.2.3.3.1.20 | Evaluación de propuestas técnicas y elaboración borrador del Informe de Evaluación Técnica (IET) |  | 10d | 2017-04-12 | 2017-04-27 | 1011 | 2017-04-12 | 2017-04-27 | 621d | 0d |
| 1013 | 3.2.3.3.1.16 | Reunion Comité de Evaluación |  | 1d | 2017-04-28 | 2017-04-28 | 1012 | 2017-04-28 | 2017-04-28 | 621d | 0d |
| 1014 | 3.2.3.3.1.21 | Solicitud de No Objeción del Banco al Informe de Evaluación Técnica (IET) de las propuestas |  | 1d | 2017-05-02 | 2017-05-02 | 1013 | 2017-05-02 | 2017-05-02 | 621d | 0d |
| 1015 | 3.2.3.3.1.22 | No Objeción del Banco al IET |  | 5d | 2017-05-03 | 2017-05-09 | 1014 | 2017-05-03 | 2017-05-09 | 621d | 0d |
| 1016 | 3.2.3.3.1.23 | Notificación del puntaje de la evaluación técnica a los proponentes y notificar simultáneamente a los que obtuvieron la calificación mínima necesaria e indicar la fecha, lugar y hora fijada para abrir las propuestas de precio. |  | 1d | 2017-05-10 | 2017-05-10 | 1015 | 2017-05-10 | 2017-05-10 | 621d | 0d |
| 1017 | 3.2.3.3.1.24 | Apertura de propuesta de precio en Audiencia Pública | milestone | 0d | 2017-05-17 | 2017-05-17 | 1016FS+5d | 2017-05-17 | 2017-05-17 | 621d | 0d |
| 1018 | 3.2.3.3.1.25 | Evaluación del Costo y Evaluación Combinada de la Calidad y el Costo |  | 1d | 2017-05-18 | 2017-05-18 | 1017 | 2017-05-18 | 2017-05-18 | 621d | 0d |
| 1019 | 3.2.3.3.1.26 | Notificación y negociación del contrato con el proponente seleccionado, elaboración del borrador del contrato negociado y solicitud de No Objeción Banco |  | 10d | 2017-05-19 | 2017-06-02 | 1018 | 2017-05-19 | 2017-06-02 | 621d | 0d |
| 1020 | 3.2.3.3.1.27 | No Objeción del Banco al borrador del contrato negociado y envio acta de apertura de sobres y evaluacion combinada |  | 5d | 2017-06-05 | 2017-06-09 | 1019 | 2017-06-05 | 2017-06-09 | 621d | 0d |
| 1021 | 3.2.3.3.1.28 | Notificación a las demás firmas incluidas en la lista corta que sus propuestas no fueron seleccionadas |  | 1d | 2017-06-12 | 2017-06-12 | 1020 | 2017-06-12 | 2017-06-12 | 621d | 0d |
| 1022 | 3.2.3.3.1.29 | Publicación de la Adjudicación del Contrato |  | 1d | 2017-06-13 | 2017-06-13 | 1021 | 2017-06-13 | 2017-06-13 | 621d | 0d |
| 1023 | 3.2.3.3.1.30 | Legalización y Firma del Contrato |  | 10d | 2017-06-14 | 2017-06-29 | 1022 | 2017-06-14 | 2017-06-29 | 621d | 0d |
| 1024 | 3.2.3.3.1.31 | Envio al Banco de una copia firmada del contrato |  | 1d | 2017-06-30 | 2017-06-30 | 1023 | 2017-06-30 | 2017-06-30 | 905d |  |

| ID | WBS | Task | Type | Duration | Start | Finish | Predecessors | Baseline 1 start | Baseline 1 finish | Total slack | Free slack |
| --- | --- | --- | --- | --- | --- | --- | --- | --- | --- | --- | --- |
| 1025 | 3.2.4.47 | **Contractual** |  | 205d | 2017-06-30 | 2018-05-03 |  | 2017-06-30 | 2018-05-03 | 621d |  |
| 1026 | 3.2.3.3.2.1 | Acta de inicio |  | 5d | 2017-06-30 | 2017-07-07 | 1023 | 2017-06-30 | 2017-07-07 | 621d | 0d |
| 1027 | 3.6.5.1.2.2 | Sistema de control en linea disenado e implementado |  | 10mo | 2017-07-10 | 2018-05-03 | 1026 | 2017-07-10 | 2018-05-03 | 621d | 0d |
| 1028 | 3.6.5.1.3 | **Cierre** |  | 80d | 2018-05-04 | 2018-09-03 |  | 2018-05-04 | 2018-09-03 | 621d |  |
| 1029 | 3.6.5.1.3.1 | Liquidación del contrato |  | 4mo | 2018-05-04 | 2018-09-03 | 1027 | 2018-05-04 | 2018-09-03 | 621d |  |
| 1030 | 3.6.6 | **Producto 16 - Modelo de gestion de incidentes de la CGR disenado e implementado** |  | 234d | 2017-09-07 | 2018-08-24 |  | 2017-09-07 | 2018-08-24 | 627d |  |
| 1031 | 3.6.6.1 | **Consultoria: Diseno e implementacion del nuevo proceso de gestion de incidentes con alcance interno y externo. SCC** |  | 234d | 2017-09-07 | 2018-08-24 |  | 2017-09-07 | 2018-08-24 | 627d |  |
| 1032 | 3.6.6.1.1 | **Precontractual** |  | 113d | 2017-09-07 | 2018-02-21 |  | 2017-09-07 | 2018-02-21 | 627d |  |
| 1033 | 3.6.6.1.1.1 | Elaboración de los TR |  | 1mo | 2017-09-07 | 2017-10-04 | 46FS+25mo | 2017-09-07 | 2017-10-04 | 627d | 0d |
| 1034 | 3.6.6.1.1.2 | Estimado de costos y presupuesto |  | 15d | 2017-10-05 | 2017-10-26 | 1033 | 2017-10-05 | 2017-10-26 | 627d | 0d |
| 1035 | 3.6.6.1.1.3 | No objeción del Banco a los TR |  | 5d | 2017-10-27 | 2017-11-02 | 1034 | 2017-10-27 | 2017-11-02 | 627d | 0d |
| 1036 | 3.6.6.1.1.4 | Elaboración del Aviso Específico de Adquisiciones (AEA) solicitando Expresiones de Interés (EI) |  | 2d | 2017-11-03 | 2017-11-07 | 1035 | 2017-11-03 | 2017-11-07 | 627d | 0d |
| 1037 | 3.6.6.1.1.5 | No Objeción del Banco al AEA |  | 5d | 2017-11-08 | 2017-11-15 | 1036 | 2017-11-08 | 2017-11-15 | 627d | 0d |
| 1038 | 3.6.6.1.1.6 | Publicación del AEA en SECOP |  | 2d | 2017-11-16 | 2017-11-17 | 1037 | 2017-11-16 | 2017-11-17 | 627d | 0d |
| 1039 | 3.6.6.1.1.7 | Recepción de Expresiones de Interés | milestone | 0d | 2017-12-01 | 2017-12-01 | 1038FS+14ed | 2017-12-01 | 2017-12-01 | 627d | 0d |
| 1040 | 3.6.6.1.1.8 | Evaluación de EI recibidas y conformación de lista corta ordenada por Orden de Merito |  | 10d | 2017-12-04 | 2017-12-18 | 1039 | 2017-12-04 | 2017-12-18 | 632d | 5d |
| 1041 | 3.6.6.1.1.9 | Elaboracion de la Solicitud de Propuestas (SP) |  | 15d | 2017-12-04 | 2017-12-26 | 1039 | 2017-12-04 | 2017-12-26 | 627d | 0d |
| 1042 | 3.6.6.1.1.10 | No Objeción del Banco a la lista corta rankeada y SP |  | 5d | 2017-12-27 | 2018-01-03 | 1040, 1041 | 2017-12-27 | 2018-01-03 | 627d | 0d |
| 1043 | 3.6.6.1.1.11 | Invitación a presentar propuesta tecnica y economica solo a la Firma Consultora (FC) rankeada en 1º lugar |  | 2d | 2018-01-04 | 2018-01-05 | 1042 | 2018-01-04 | 2018-01-05 | 627d | 0d |
| 1044 | 3.6.6.1.1.12 | Recepción de propuesta de la FC invitada | milestone | 0d | 2018-01-22 | 2018-01-22 | 1043FS+2w | 2018-01-22 | 2018-01-22 | 627d | 0d |
| 1045 | 3.6.6.1.1.13 | Evaluación de la propuesta y negociación del contrato |  | 10d | 2018-01-23 | 2018-02-05 | 1044 | 2018-01-23 | 2018-02-05 | 627d | 0d |
| 1046 | 3.6.6.1.1.14 | No Objeción del Banco al contrato negociado y rubricado |  | 5d | 2018-02-06 | 2018-02-12 | 1045 | 2018-02-06 | 2018-02-12 | 627d | 0d |
| 1047 | 3.6.6.1.1.15 | Publicar el nombre del consultor al cual se le adjudicó el contrato, |  | 2d | 2018-02-13 | 2018-02-14 | 1046 | 2018-02-13 | 2018-02-14 | 627d | 0d |
| 1048 | 3.6.6.1.1.16 | Firma del contrato y envío del contrato al Banco para registro |  | 5d | 2018-02-15 | 2018-02-21 | 1047 | 2018-02-15 | 2018-02-21 | 627d | 0d |

Notes:
- 1041: Modelo Base SP bajo la modalidad SCC

| ID | WBS | Task | Type | Duration | Start | Finish | Predecessors | Baseline 1 start | Baseline 1 finish | Total slack | Free slack |
| --- | --- | --- | --- | --- | --- | --- | --- | --- | --- | --- | --- |
| 1049 | 3.2.4.47 | **Contractual** |  | 41d | 2018-02-22 | 2018-04-24 |  | 2018-02-22 | 2018-04-24 | 627d |  |
| 1050 | 3.2.3.3.2.1 | Acta de inicio |  | 1d | 2018-02-22 | 2018-02-22 | 1048 | 2018-02-22 | 2018-02-22 | 627d | 0d |
| 1051 | 3.6.6.1.2.2 | Nuevo proceso de gestion de incidentes con alcance interno y externo disenado e implementado |  | 2mo | 2018-02-23 | 2018-04-24 | 1050 | 2018-02-23 | 2018-04-24 | 627d | 0d |
| 1052 | 3.6.6.1.3 | **Cierre** |  | 80d | 2018-04-25 | 2018-08-24 |  | 2018-04-25 | 2018-08-24 | 627d |  |
| 1053 | 3.6.6.1.3.1 | Liquidacion de contrato |  | 4mo | 2018-04-25 | 2018-08-24 | 1051 | 2018-04-25 | 2018-08-24 | 627d |  |
| 1054 | 3.6.6.2 | **Adquisicion de infraestructura fisica y licenciamiento para el modelo de gestion de incidentes. CP** |  | 107d | 2018-02-23 | 2018-08-03 |  | 2018-02-23 | 2018-08-03 | 640d |  |
| 1055 | 3.6.6.2.1 | **Precontractual** |  | 64d | 2018-02-23 | 2018-05-30 |  | 2018-02-23 | 2018-05-30 | 640d |  |
| 1056 | 3.6.6.2.1.1 | Elaboracion de Especificaciones Tecnicas |  | 1mo | 2018-02-23 | 2018-03-23 | 1050 | 2018-02-23 | 2018-03-23 | 640d | 0d |
| 1057 | 3.6.6.2.1.2 | Elaboracion de la Solicitud de Cotizacion de Precios |  | 5d | 2018-03-26 | 2018-04-03 | 1056 | 2018-03-26 | 2018-04-03 | 640d | 0d |
| 1058 | 3.6.6.2.1.3 | No Objecion del Banco a las especificaciones tecnicas y Solicitud de Cotizacion de Precios |  | 5d | 2018-04-04 | 2018-04-10 | 1057 | 2018-04-04 | 2018-04-10 | 640d | 0d |
| 1059 | 3.6.6.2.1.4 | Invitacion a cotizar a diversos proveedores (minimo 3) |  | 2d | 2018-04-11 | 2018-04-12 | 1058 | 2018-04-11 | 2018-04-12 | 640d | 0d |
| 1060 | 3.6.6.2.1.5 | Recibo de cotizaciones |  | 3w | 2018-04-13 | 2018-05-04 | 1059 | 2018-04-13 | 2018-05-04 | 640d | 0d |
| 1061 | 3.6.6.2.1.6 | Evaluacion de cotizaciones recibidas |  | 5d | 2018-05-07 | 2018-05-11 | 1060 | 2018-05-07 | 2018-05-11 | 640d | 0d |
| 1062 | 3.6.6.2.1.7 | Solicitud de no objecion al Banco con recomendacion de adjudicacion |  | 2d | 2018-05-15 | 2018-05-16 | 1061 | 2018-05-15 | 2018-05-16 | 640d | 0d |
| 1063 | 3.6.6.2.1.8 | No objecion al Banco con recomendacion de adjudicacion |  | 5d | 2018-05-17 | 2018-05-23 | 1062 | 2018-05-17 | 2018-05-23 | 640d | 0d |
| 1064 | 3.6.6.2.1.9 | Firma de orden de compra o un contrato simplificado |  | 5d | 2018-05-24 | 2018-05-30 | 1063 | 2018-05-24 | 2018-05-30 | 640d | 0d |
| 1065 | 3.6.6.2.2 | **Contractual** |  | 33d | 2018-05-31 | 2018-07-19 |  | 2018-05-31 | 2018-07-19 | 640d |  |
| 1066 | 3.6.6.2.2.1 | Acta de Inicio |  | 3d | 2018-05-31 | 2018-06-05 | 1064 | 2018-05-31 | 2018-06-05 | 640d | 0d |
| 1067 | 3.6.6.2.2.2 | Entrega de los bienes |  | 1mo | 2018-06-06 | 2018-07-05 | 1066 | 2018-06-06 | 2018-07-05 | 640d | 0d |
| 1068 | 3.6.6.2.2.3 | Ingreso a almacen y registro por la CGR |  | 2w | 2018-07-06 | 2018-07-19 | 1067 | 2018-07-06 | 2018-07-19 | 650d |  |
| 1069 | 3.6.6.2.3 | **Cierre** |  | 20d | 2018-07-06 | 2018-08-03 |  | 2018-07-06 | 2018-08-03 | 640d |  |
| 1070 | 3.6.6.2.3.1 | Liquidacion del contrato |  | 4w | 2018-07-06 | 2018-08-03 | 1067 | 2018-07-06 | 2018-08-03 | 640d |  |
| 1071 | 3.6.7 | **Producto 17 - Plan de recuperacion de desastres - DRP definido** |  | 780d | 2016-10-12 | 2019-11-29 |  | 2016-09-14 | 2019-10-03 | 300d |  |
| 1072 | 3.6.7.1 | **Consultoria: Deficinicion del Plan de Recuperacion de Desastres de la CGR. SBCC** |  | 302d | 2017-10-05 | 2019-01-01 |  | 2016-09-14 | 2017-12-04 | 536d |  |
| 1073 | 3.2.3.3.1 | **Precontractual** |  | 158d | 2017-10-05 | 2018-05-30 |  | 2016-09-14 | 2017-05-02 | 536d |  |
| 1074 | 3.2.3.3.1.1 | Elaboración de los términos de referencia (TR) |  | 1.5mo | 2017-10-05 | 2017-11-20 | 46FS+26mo | 2016-09-14 | 2016-10-26 | 536d | 0d |
| 1075 | 3.2.3.3.1.3 | Preparación de la estimación de costos y presupuesto (Estudio de mercado) |  | 12d | 2017-11-21 | 2017-12-06 | 1074 | 2016-10-27 | 2016-11-15 | 536d | 0d |
| 1076 | 3.2.3.3.1.4 | Elaboración del Aviso Específico de Adquisiciones (AEA) solicitando expresiones de interés y solicitud de No Objeción al Banco |  | 2d | 2017-12-07 | 2017-12-11 | 1075 | 2016-11-16 | 2016-11-17 | 536d | 0d |
| 1077 | 3.2.3.3.1.5 | No Objeción del Banco al AEA |  | 5d | 2017-12-12 | 2017-12-18 | 1076 | 2016-11-18 | 2016-11-24 | 536d | 0d |
| 1078 | 3.2.3.3.1.6 | Publicación del AEA en SECOP (los contratos de valor mayor al equivalente de US $200.000 se deben anunciar ademas en los sitios de Internet del UNDB online y del Banco) |  | 2d | 2017-12-19 | 2017-12-20 | 1077 | 2016-11-25 | 2016-11-28 | 536d | 0d |
| 1079 | 3.2.3.3.1.7 | Recepción de expresiones de interés | milestone | 0d | 2018-01-09 | 2018-01-09 | 1078FS+20ed | 2016-12-12 | 2016-12-12 | 539d | 0d |
| 1080 | 3.2.3.3.1.8 | Evaluación de Expresiones de Interés recibidas y conformación de lista corta |  | 5d | 2018-01-10 | 2018-01-16 | 1079 | 2016-12-13 | 2016-12-19 | 774d |  |
| 1081 | 3.2.3.3.1.9 | Elaboración de la Solicitud de Propuesta (SP) que incluye: (a) la Carta de Invitación a las firmas de la lista corta; (b) las Instrucciones a los Consultores; © los TR; y (d) el contrato propuesto; y solicitud de No Objeción al Banco |  | 15d | 2018-01-10 | 2018-01-30 | 1079 | 2016-12-13 | 2017-01-02 | 539d | 0d |
| 1082 | 3.2.3.3.1.10 | No Objeción del Banco a la SP y conformacion Lista Corta |  | 5d | 2018-01-31 | 2018-02-06 | 1081 | 2017-01-03 | 2017-01-10 | 539d | 0d |
| 1083 | 3.2.3.3.1.11 | Envio de Solicitud de Propuestas (SP) a los integrantes de la lista corta (Invitación a presentar propuestas) |  | 2d | 2018-02-07 | 2018-02-08 | 1082 | 2017-01-11 | 2017-01-12 | 539d | 0d |
| 1084 | 3.2.3.3.1.12 | Reunión aclaratoria (eventual a los diez días de la invitación) | milestone | 0d | 2018-02-22 | 2018-02-22 | 1083FS+10d | 2017-01-26 | 2017-01-26 | 539d | 0d |
| 1085 | 3.2.3.3.1.13 | Preparación de respuestas a las solicitudes de aclaraciones de los oferentes y solicitud de No Objeción al Banco |  | 3d | 2018-02-23 | 2018-02-27 | 1084 | 2017-01-27 | 2017-01-31 | 539d | 0d |
| 1086 | 3.2.3.3.1.14 | No objeción del Banco a las respuestas de aclaraciones |  | 5d | 2018-02-28 | 2018-03-06 | 1085 | 2017-02-01 | 2017-02-07 | 539d | 0d |
| 1087 | 3.2.3.3.1.15 | Respuesta a las solicitudes de aclaración antes de la recepción de propuestas |  | 3d | 2018-03-07 | 2018-03-09 | 1086 | 2017-02-08 | 2017-02-10 | 539d | 0d |
| 1088 | 3.2.3.3.1.17 | Designación del Comité de Evaluación |  | 1d | 2018-03-12 | 2018-03-12 | 1087 | 2017-02-13 | 2017-02-13 | 539d | 0d |
| 1089 | 3.2.3.3.1.18 | Recepción de las Propuestas técnicas y de precio y Apertura de propuestas técnicas | milestone | 0d | 2018-03-08 | 2018-03-08 | 1083FS+4w | 2017-02-09 | 2017-02-09 | 541d | 2d |
| 1090 | 3.2.3.3.1.19 | Envío de propuestas al Comité de Evaluación y al Especialista en Adquisiciones | milestone | 0d | 2018-03-12 | 2018-03-12 | 1088, 1089 | 2017-02-13 | 2017-02-13 | 539d | 0d |
| 1091 | 3.2.3.3.1.20 | Evaluación de propuestas técnicas y elaboración borrador del Informe de Evaluación Técnica (IET) |  | 10d | 2018-03-13 | 2018-03-27 | 1090 | 2017-02-14 | 2017-02-27 | 539d | 0d |
| 1092 | 3.2.3.3.1.16 | Reunion Comité de Evaluación |  | 1d | 2018-03-28 | 2018-03-28 | 1091 | 2017-02-28 | 2017-02-28 | 539d | 0d |
| 1093 | 3.2.3.3.1.21 | Solicitud de No Objeción del Banco al Informe de Evaluación Técnica (IET) de las propuestas |  | 1d | 2018-04-02 | 2018-04-02 | 1092 | 2017-03-01 | 2017-03-01 | 539d | 0d |
| 1094 | 3.2.3.3.1.22 | No Objeción del Banco al IET |  | 5d | 2018-04-03 | 2018-04-09 | 1093 | 2017-03-02 | 2017-03-08 | 539d | 0d |
| 1095 | 3.2.3.3.1.23 | Notificación del puntaje de la evaluación técnica a los proponentes y notificar simultáneamente a los que obtuvieron la calificación mínima necesaria e indicar la fecha, lugar y hora fijada para abrir las propuestas de precio. |  | 1d | 2018-04-10 | 2018-04-10 | 1094 | 2017-03-09 | 2017-03-09 | 539d | 0d |
| 1096 | 3.2.3.3.1.24 | Apertura de propuesta de precio en Audiencia Pública | milestone | 0d | 2018-04-17 | 2018-04-17 | 1095FS+5d | 2017-03-16 | 2017-03-16 | 539d | 0d |
| 1097 | 3.2.3.3.1.25 | Evaluación del Costo y Evaluación Combinada de la Calidad y el Costo |  | 1d | 2018-04-18 | 2018-04-18 | 1096 | 2017-03-17 | 2017-03-17 | 539d | 0d |
| 1098 | 3.2.3.3.1.26 | Notificación y negociación del contrato con el proponente seleccionado, elaboración del borrador del contrato negociado y solicitud de No Objeción Banco |  | 10d | 2018-04-19 | 2018-05-03 | 1097 | 2017-03-21 | 2017-04-03 | 539d | 0d |
| 1099 | 3.2.3.3.1.27 | No Objeción del Banco al borrador del contrato negociado y envio acta de apertura de sobres y evaluacion combinada |  | 5d | 2018-05-04 | 2018-05-10 | 1098 | 2017-04-04 | 2017-04-10 | 539d | 0d |
| 1100 | 3.2.3.3.1.28 | Notificación a las demás firmas incluidas en la lista corta que sus propuestas no fueron seleccionadas |  | 1d | 2018-05-11 | 2018-05-11 | 1099 | 2017-04-11 | 2017-04-11 | 539d | 0d |
| 1101 | 3.2.3.3.1.29 | Publicación de la Adjudicación del Contrato |  | 1d | 2018-05-15 | 2018-05-15 | 1100 | 2017-04-12 | 2017-04-12 | 539d | 0d |
| 1102 | 3.2.3.3.1.30 | Legalización y Firma del Contrato |  | 10d | 2018-05-16 | 2018-05-29 | 1101 | 2017-04-17 | 2017-04-28 | 539d | 0d |
| 1103 | 3.2.3.3.1.31 | Envio al Banco de una copia firmada del contrato |  | 1d | 2018-05-30 | 2018-05-30 | 1102 | 2017-05-02 | 2017-05-02 | 683d |  |

| ID | WBS | Task | Type | Duration | Start | Finish | Predecessors | Baseline 1 start | Baseline 1 finish | Total slack | Free slack |
| --- | --- | --- | --- | --- | --- | --- | --- | --- | --- | --- | --- |
| 1104 | 3.2.4.47 | **Contractual** |  | 65d | 2018-05-30 | 2018-09-05 |  | 2017-05-02 | 2017-08-08 | 539d |  |
| 1105 | 3.2.3.3.2.1 | Acta de inicio |  | 5d | 2018-05-30 | 2018-06-06 | 1102 | 2017-05-02 | 2017-05-08 | 539d | 0d |
| 1106 | 3.6.7.1.2.2 | Plan de Recuperacion de Desastres definido |  | 3mo | 2018-06-07 | 2018-09-05 | 1105 | 2017-05-09 | 2017-08-08 | 539d | 0d |
| 1107 | 3.6.7.1.3 | **Cierre** |  | 80d | 2018-09-06 | 2019-01-01 |  | 2017-08-09 | 2017-12-04 | 539d |  |
| 1108 | 3.6.7.1.3.1 | Liquidación del contrato |  | 4mo | 2018-09-06 | 2019-01-01 | 1106 | 2017-08-09 | 2017-12-04 | 539d |  |
| 1109 | 3.6.7.2 | **Consultoria: Diseno e implementacion del sitio alterno acorde al modelo DRP. SBCC** |  | 780d | 2016-10-12 | 2019-11-29 |  | 2017-08-09 | 2019-10-03 | 300d |  |
| 1110 | 3.2.3.3.1 | **Precontractual** |  | 216d | 2016-10-12 | 2017-08-31 |  | 2017-08-09 | 2018-06-26 | 300d |  |
| 1111 | 3.2.3.3.1.1 | Elaboración de los términos de referencia (TR) |  | 1.5mo | 2016-10-12 | 2016-11-25 | 46FS+14mo | 2017-08-09 | 2017-09-20 | 300d | 0d |
| 1112 | 3.2.3.3.1.3 | Preparación de la estimación de costos y presupuesto (Estudio de mercado) |  | 20d | 2016-11-28 | 2016-12-26 | 1111 | 2017-09-21 | 2017-10-19 | 300d | 0d |
| 1113 | 3.2.3.3.1.4 | Elaboración del Aviso Específico de Adquisiciones (AEA) solicitando expresiones de interés y solicitud de No Objeción al Banco |  | 2d | 2016-12-27 | 2016-12-28 | 1112 | 2017-10-20 | 2017-10-23 | 300d | 0d |
| 1114 | 3.2.3.3.1.5 | No Objeción del Banco al AEA |  | 5d | 2016-12-29 | 2017-01-04 | 1113 | 2017-10-24 | 2017-10-30 | 300d | 0d |
| 1115 | 3.2.3.3.1.6 | Publicación del AEA en SECOP (los contratos de valor mayor al equivalente de US $200.000 se deben anunciar ademas en los sitios de Internet del UNDB online y del Banco) |  | 2d | 2017-01-05 | 2017-01-06 | 1114 | 2017-10-31 | 2017-11-01 | 300d | 0d |
| 1116 | 3.2.3.3.1.7 | Recepción de expresiones de interés | milestone | 0d | 2017-01-20 | 2017-01-20 | 1115FS+14ed | 2017-11-15 | 2017-11-15 | 301d | 0d |
| 1117 | 3.2.3.3.1.8 | Evaluación de Expresiones de Interés recibidas y conformación de lista corta |  | 7d | 2017-01-23 | 2017-01-31 | 1116 | 2017-11-16 | 2017-11-24 | 301d | 0d |
| 1118 | 3.2.3.3.1.9 | Elaboración de la Solicitud de Propuesta (SP) que incluye: (a) la Carta de Invitación a las firmas de la lista corta; (b) las Instrucciones a los Consultores; © los TR; y (d) el contrato propuesto; y solicitud de No Objeción al Banco |  | 20d | 2017-02-01 | 2017-02-28 | 1117 | 2017-11-27 | 2017-12-26 | 301d | 0d |
| 1119 | 3.2.3.3.1.10 | No Objeción del Banco a la SP y conformacion Lista Corta |  | 5d | 2017-03-01 | 2017-03-07 | 1118 | 2017-12-27 | 2018-01-03 | 301d | 0d |
| 1120 | 3.6.7.2.1.10 | Solicitud vigencias futuras 2018 y 2019 | milestone | 0d | 2017-05-08 | 2017-05-08 | 1119FS+2mo | 2018-03-01 | 2018-03-01 | 301d | 0d |
| 1121 | 3.2.3.3.1.11 | Envio de Solicitud de Propuestas (SP) a los integrantes de la lista corta (Invitación a presentar propuestas) |  | 2d | 2017-05-09 | 2017-05-10 | 1120 | 2018-03-02 | 2018-03-05 | 301d | 0d |
| 1122 | 3.2.3.3.1.12 | Reunión aclaratoria (eventual a los diez días de la invitación) | milestone | 0d | 2017-05-24 | 2017-05-24 | 1121FS+10d | 2018-03-20 | 2018-03-20 | 301d | 0d |
| 1123 | 3.2.3.3.1.13 | Preparación de respuestas a las solicitudes de aclaraciones de los oferentes y solicitud de No Objeción al Banco |  | 3d | 2017-05-25 | 2017-05-30 | 1122 | 2018-03-21 | 2018-03-23 | 301d | 0d |
| 1124 | 3.2.3.3.1.14 | No objeción del Banco a las respuestas de aclaraciones |  | 5d | 2017-05-31 | 2017-06-06 | 1123 | 2018-03-26 | 2018-04-03 | 301d | 0d |
| 1125 | 3.2.3.3.1.15 | Respuesta a las solicitudes de aclaración antes de la recepción de propuestas |  | 3d | 2017-06-07 | 2017-06-09 | 1124 | 2018-04-04 | 2018-04-06 | 301d | 0d |
| 1126 | 3.2.3.3.1.17 | Designación del Comité de Evaluación |  | 1d | 2017-06-12 | 2017-06-12 | 1125 | 2018-04-09 | 2018-04-09 | 301d | 0d |
| 1127 | 3.2.3.3.1.18 | Recepción de las Propuestas técnicas y de precio y Apertura de propuestas técnicas | milestone | 0d | 2017-06-08 | 2017-06-08 | 1121FS+4w | 2018-04-05 | 2018-04-05 | 303d | 2d |
| 1128 | 3.2.3.3.1.19 | Envío de propuestas al Comité de Evaluación y al Especialista en Adquisiciones | milestone | 0d | 2017-06-12 | 2017-06-12 | 1126, 1127 | 2018-04-09 | 2018-04-09 | 301d | 0d |
| 1129 | 3.2.3.3.1.20 | Evaluación de propuestas técnicas y elaboración borrador del Informe de Evaluación Técnica (IET) |  | 10d | 2017-06-13 | 2017-06-28 | 1128 | 2018-04-10 | 2018-04-23 | 301d | 0d |
| 1130 | 3.2.3.3.1.16 | Reunion Comité de Evaluación |  | 1d | 2017-06-29 | 2017-06-29 | 1129 | 2018-04-24 | 2018-04-24 | 301d | 0d |
| 1131 | 3.2.3.3.1.21 | Solicitud de No Objeción del Banco al Informe de Evaluación Técnica (IET) de las propuestas |  | 1d | 2017-06-30 | 2017-06-30 | 1130 | 2018-04-25 | 2018-04-25 | 301d | 0d |
| 1132 | 3.2.3.3.1.22 | No Objeción del Banco al IET |  | 5d | 2017-07-04 | 2017-07-10 | 1131 | 2018-04-26 | 2018-05-03 | 301d | 0d |
| 1133 | 3.2.3.3.1.23 | Notificación del puntaje de la evaluación técnica a los proponentes y notificar simultáneamente a los que obtuvieron la calificación mínima necesaria e indicar la fecha, lugar y hora fijada para abrir las propuestas de precio. |  | 1d | 2017-07-11 | 2017-07-11 | 1132 | 2018-05-04 | 2018-05-04 | 301d | 0d |
| 1134 | 3.2.3.3.1.24 | Apertura de propuesta de precio en Audiencia Pública | milestone | 0d | 2017-07-18 | 2017-07-18 | 1133FS+5d | 2018-05-11 | 2018-05-11 | 301d | 0d |
| 1135 | 3.2.3.3.1.25 | Evaluación del Costo y Evaluación Combinada de la Calidad y el Costo |  | 1d | 2017-07-19 | 2017-07-19 | 1134 | 2018-05-15 | 2018-05-15 | 301d | 0d |
| 1136 | 3.2.3.3.1.26 | Notificación y negociación del contrato con el proponente seleccionado, elaboración del borrador del contrato negociado y solicitud de No Objeción Banco |  | 10d | 2017-07-21 | 2017-08-03 | 1135 | 2018-05-16 | 2018-05-29 | 301d | 0d |
| 1137 | 3.2.3.3.1.27 | No Objeción del Banco al borrador del contrato negociado y envio acta de apertura de sobres y evaluacion combinada |  | 5d | 2017-08-04 | 2017-08-11 | 1136 | 2018-05-30 | 2018-06-06 | 301d | 0d |
| 1138 | 3.2.3.3.1.28 | Notificación a las demás firmas incluidas en la lista corta que sus propuestas no fueron seleccionadas |  | 1d | 2017-08-14 | 2017-08-14 | 1137 | 2018-06-07 | 2018-06-07 | 301d | 0d |
| 1139 | 3.2.3.3.1.29 | Publicación de la Adjudicación del Contrato |  | 1d | 2017-08-15 | 2017-08-15 | 1138 | 2018-06-08 | 2018-06-08 | 301d | 0d |
| 1140 | 3.2.3.3.1.30 | Legalización y Firma del Contrato |  | 10d | 2017-08-16 | 2017-08-30 | 1139 | 2018-06-12 | 2018-06-25 | 301d | 0d |
| 1141 | 3.2.3.3.1.31 | Envio al Banco de una copia firmada del contrato |  | 1d | 2017-08-31 | 2017-08-31 | 1140 | 2018-06-26 | 2018-06-26 | 865d |  |

Notes:
- 1109: Un ano de ejecucion posterior al diseno del Plan de Recuperacion de Desastres

| ID | WBS | Task | Type | Duration | Start | Finish | Predecessors | Baseline 1 start | Baseline 1 finish | Total slack | Free slack |
| --- | --- | --- | --- | --- | --- | --- | --- | --- | --- | --- | --- |
| 1142 | 3.2.4.47 | **Contractual** |  | 485d | 2017-08-31 | 2019-08-09 |  | 2018-06-26 | 2019-06-13 | 301d |  |
| 1143 | 3.2.3.3.2.1 | Acta de inicio |  | 5d | 2017-08-31 | 2017-09-06 | 1140 | 2018-06-26 | 2018-07-03 | 301d | 0d |
| 1144 | 3.6.7.2.2.2 | Sitio alterno acorde al Modelo de DRP Disenado e implementado |  | 24mo | 2017-09-07 | 2019-08-09 | 1143 | 2018-07-04 | 2019-06-13 | 301d | 0d |
| 1145 | 3.6.7.2.3 | **Cierre** |  | 80d | 2019-08-12 | 2019-11-29 |  | 2019-06-14 | 2019-10-03 | 301d |  |
| 1146 | 3.6.7.2.3.1 | Liquidación del contrato |  | 4mo | 2019-08-12 | 2019-11-29 | 1144 | 2019-06-14 | 2019-10-03 | 301d |  |
| 1147 | 3.6.8 | **Producto 18 - Infraestructura Tecnologica Instalada** |  | 582d | 2016-11-11 | 2019-03-26 |  | 2016-11-11 | 2018-06-06 | 479d |  |
| 1148 | 3.6.8.1 | **Adquisicion de infraestructura Tecnologica (incluye instalacion). CP** |  | 582d | 2016-11-11 | 2019-03-26 |  | 2016-11-11 | 2018-06-06 | 479d |  |
| 1149 | 3.6.8.1.1 | **Precontractual** |  | 119d | 2016-11-11 | 2017-05-05 |  | 2016-11-11 | 2017-05-05 | 479d |  |
| 1150 | 3.6.8.1.1.1 | Elaboracion de Especificaciones Tecnicas |  | 1.5mo | 2016-11-11 | 2016-12-26 | 46FS+15mo | 2016-11-11 | 2016-12-26 | 479d | 0d |
| 1151 | 3.6.8.1.1.2 | Elaboracion de la Solicitud de Cotizacion de Precios |  | 5d | 2016-12-27 | 2017-01-02 | 1150 | 2016-12-27 | 2017-01-02 | 479d | 0d |
| 1152 | 3.6.8.1.1.3 | No Objecion del Banco a las especificaciones tecnicas y Solicitud de Cotizacion de Precios |  | 5d | 2017-01-03 | 2017-01-10 | 1151 | 2017-01-03 | 2017-01-10 | 479d | 0d |
| 1153 | 3.6.8.1.1.4 | Tramite Vigencias Futuras 2019 | milestone | 0d | 2017-03-07 | 2017-03-07 | 1152FS+2mo | 2017-03-07 | 2017-03-07 | 479d | 0d |
| 1154 | 3.6.8.1.1.5 | Invitacion a cotizar a diversos proveedores (minimo 3) |  | 2d | 2017-03-08 | 2017-03-09 | 1153 | 2017-03-08 | 2017-03-09 | 479d | 0d |
| 1155 | 3.6.8.1.1.6 | Recibo de cotizaciones |  | 3w | 2017-03-10 | 2017-03-31 | 1154 | 2017-03-10 | 2017-03-31 | 479d | 0d |
| 1156 | 3.6.8.1.1.7 | Evaluacion de cotizaciones recibidas |  | 10d | 2017-04-03 | 2017-04-18 | 1155 | 2017-04-03 | 2017-04-18 | 479d | 0d |
| 1157 | 3.6.8.1.1.8 | Solicitud de no objecion al Banco con recomendacion de adjudicacion |  | 2d | 2017-04-19 | 2017-04-20 | 1156 | 2017-04-19 | 2017-04-20 | 479d | 0d |
| 1158 | 3.6.8.1.1.9 | No objecion al Banco con recomendacion de adjudicacion |  | 5d | 2017-04-21 | 2017-04-27 | 1157 | 2017-04-21 | 2017-04-27 | 479d | 0d |
| 1159 | 3.6.8.1.1.10 | Firma de orden de compra o un contrato simplificado |  | 5d | 2017-04-28 | 2017-05-05 | 1158 | 2017-04-28 | 2017-05-05 | 479d | 0d |
| 1160 | 3.6.8.1.2 | **Contractual** |  | 453d | 2017-05-08 | 2019-03-12 |  | 2017-05-08 | 2018-05-22 | 479d |  |
| 1161 | 3.6.8.1.2.1 | Acta de Inicio |  | 3d | 2017-05-08 | 2017-05-10 | 1159 | 2017-05-08 | 2017-05-10 | 479d | 0d |
| 1162 | 3.6.8.1.2.2 | Entrega de los bienes |  | 22mo | 2017-05-11 | 2019-02-26 | 1161 | 2017-05-11 | 2018-05-07 | 479d | 0d |
| 1163 | 3.6.8.1.2.3 | Ingreso a almacen y registro por la CGR |  | 2w | 2019-02-27 | 2019-03-12 | 1162 | 2018-05-08 | 2018-05-22 | 489d |  |
| 1164 | 3.6.8.1.3 | **Cierre** |  | 20d | 2019-02-27 | 2019-03-26 |  | 2018-05-08 | 2018-06-06 | 479d |  |
| 1165 | 3.6.8.1.3.1 | Liquidacion del contrato |  | 4w | 2019-02-27 | 2019-03-26 | 1162 | 2018-05-08 | 2018-06-06 | 479d |  |

| ID | WBS | Task | Type | Duration | Start | Finish | Predecessors | Baseline 1 start | Baseline 1 finish | Total slack | Free slack |
| --- | --- | --- | --- | --- | --- | --- | --- | --- | --- | --- | --- |
| 1166 | 3.6.9 | **Producto 19 - Cursos de capacitación en Sistemas de Información Integrados impartidos** |  | 582d | 2016-11-11 | 2019-03-26 |  | 2016-11-11 | 2018-06-06 | 479d |  |
| 1167 | 3.6.9.1 | **Cursos de Capacitación impartidos. CP** |  | 582d | 2016-11-11 | 2019-03-26 |  | 2016-11-11 | 2018-06-06 | 479d |  |
| 1168 | 3.6.9.1.1 | **Precontractual** |  | 119d | 2016-11-11 | 2017-05-05 |  | 2016-11-11 | 2017-05-05 | 479d |  |
| 1169 | 3.6.9.1.1.1 | Elaboracion de Especificaciones Tecnicas |  | 1.5mo | 2016-11-11 | 2016-12-26 | 46FS+15mo | 2016-11-11 | 2016-12-26 | 479d | 0d |
| 1170 | 3.6.9.1.1.2 | Elaboracion de la Solicitud de Cotizacion de Precios |  | 5d | 2016-12-27 | 2017-01-02 | 1169 | 2016-12-27 | 2017-01-02 | 479d | 0d |
| 1171 | 3.6.9.1.1.3 | No Objecion del Banco a las especificaciones tecnicas y Solicitud de Cotizacion de Precios |  | 5d | 2017-01-03 | 2017-01-10 | 1170 | 2017-01-03 | 2017-01-10 | 479d | 0d |
| 1172 | 3.6.9.1.1.4 | Tramite Vigencias Futuras 2019 | milestone | 0d | 2017-03-07 | 2017-03-07 | 1171FS+2mo | 2017-03-07 | 2017-03-07 | 479d | 0d |
| 1173 | 3.6.9.1.1.5 | Invitacion a cotizar a diversos proveedores (minimo 3) |  | 2d | 2017-03-08 | 2017-03-09 | 1172 | 2017-03-08 | 2017-03-09 | 479d | 0d |
| 1174 | 3.6.9.1.1.6 | Recibo de cotizaciones |  | 3w | 2017-03-10 | 2017-03-31 | 1173 | 2017-03-10 | 2017-03-31 | 479d | 0d |
| 1175 | 3.6.9.1.1.7 | Evaluacion de cotizaciones recibidas |  | 10d | 2017-04-03 | 2017-04-18 | 1174 | 2017-04-03 | 2017-04-18 | 479d | 0d |
| 1176 | 3.6.9.1.1.8 | Solicitud de no objecion al Banco con recomendacion de adjudicacion |  | 2d | 2017-04-19 | 2017-04-20 | 1175 | 2017-04-19 | 2017-04-20 | 479d | 0d |
| 1177 | 3.6.9.1.1.9 | No objecion al Banco con recomendacion de adjudicacion |  | 5d | 2017-04-21 | 2017-04-27 | 1176 | 2017-04-21 | 2017-04-27 | 479d | 0d |
| 1178 | 3.6.9.1.1.10 | Firma de orden de compra o un contrato simplificado |  | 5d | 2017-04-28 | 2017-05-05 | 1177 | 2017-04-28 | 2017-05-05 | 479d | 0d |
| 1179 | 3.6.9.1.2 | **Contractual** |  | 443d | 2017-05-08 | 2019-02-26 |  | 2017-05-08 | 2018-05-22 | 479d |  |
| 1180 | 3.6.9.1.2.1 | Acta de Inicio |  | 3d | 2017-05-08 | 2017-05-10 | 1178 | 2017-05-08 | 2017-05-10 | 479d | 0d |
| 1181 | 3.6.9.1.2.2 | Capacitaciones impartidas |  | 22mo | 2017-05-11 | 2019-02-26 | 1180 | 2017-05-11 | 2018-05-07 | 479d | 0d |
| 1182 | 3.6.9.1.3 | **Cierre** |  | 20d | 2019-02-27 | 2019-03-26 |  | 2018-05-08 | 2018-06-06 | 479d |  |
| 1183 | 3.6.9.1.3.1 | Liquidacion del contrato |  | 4w | 2019-02-27 | 2019-03-26 | 1181 | 2018-05-08 | 2018-06-06 | 479d |  |
| 1184 | 3.7 | **COMPONENTE 3 - Promoción de la transparencia y la participación ciudadana** |  | 1055d | 2015-06-25 | 2019-09-30 |  | 2015-06-25 | 2019-02-25 | 345d |  |
| 1185 | 3.7.1 | **Producto 19. Portal WEB de la CGR Disenado e implementado** |  | 344d | 2016-10-12 | 2018-03-08 |  | 2016-10-12 | 2018-03-08 | 737d |  |
| 1186 | 3.7.1.1 | **Consultoria: Disenar e implementar el Portal WEB de la CGR. SBCC** |  | 344d | 2016-10-12 | 2018-03-08 |  | 2016-10-12 | 2018-03-08 | 737d |  |
| 1187 | 3.2.3.3.1 | **Precontractual** |  | 140d | 2016-10-12 | 2017-05-08 |  | 2016-10-12 | 2017-05-08 | 737d |  |
| 1188 | 3.2.3.3.1.1 | Elaboración de los términos de referencia (TR) |  | 1mo | 2016-10-12 | 2016-11-10 | 46FS+14mo | 2016-10-12 | 2016-11-10 | 737d | 0d |
| 1189 | 3.2.3.3.1.3 | Preparación de la estimación de costos y presupuesto (Estudio de mercado) |  | 10d | 2016-11-11 | 2016-11-25 | 1188 | 2016-11-11 | 2016-11-25 | 737d | 0d |
| 1190 | 3.7.1.1.1.3 | Solicitud de Vigencias Futuras | milestone | 0d | 2016-11-25 | 2016-11-25 | 1189 | 2016-11-25 | 2016-11-25 | 771d | 34d |
| 1191 | 3.2.3.3.1.4 | Elaboración del Aviso Específico de Adquisiciones (AEA) solicitando expresiones de interés y solicitud de No Objeción al Banco |  | 2d | 2016-11-28 | 2016-11-29 | 1189 | 2016-11-28 | 2016-11-29 | 737d | 0d |
| 1192 | 3.2.3.3.1.5 | No Objeción del Banco al AEA |  | 5d | 2016-11-30 | 2016-12-06 | 1191 | 2016-11-30 | 2016-12-06 | 737d | 0d |
| 1193 | 3.2.3.3.1.6 | Publicación del AEA en SECOP (los contratos de valor mayor al equivalente de US $200.000 se deben anunciar ademas en los sitios de Internet del UNDB online y del Banco) |  | 2d | 2016-12-07 | 2016-12-09 | 1192 | 2016-12-07 | 2016-12-09 | 737d | 0d |
| 1194 | 3.2.3.3.1.7 | Recepción de expresiones de interés | milestone | 0d | 2016-12-23 | 2016-12-23 | 1193FS+14ed | 2016-12-23 | 2016-12-23 | 737d | 0d |
| 1195 | 3.2.3.3.1.8 | Evaluación de Expresiones de Interés recibidas y conformación de lista corta |  | 5d | 2016-12-26 | 2016-12-30 | 1194 | 2016-12-26 | 2016-12-30 | 1027d |  |
| 1196 | 3.2.3.3.1.9 | Elaboración de la Solicitud de Propuesta (SP) que incluye: (a) la Carta de Invitación a las firmas de la lista corta; (b) las Instrucciones a los Consultores; © los TR; y (d) el contrato propuesto; y solicitud de No Objeción al Banco |  | 10d | 2016-12-26 | 2017-01-06 | 1194 | 2016-12-26 | 2017-01-06 | 737d | 0d |
| 1197 | 3.2.3.3.1.10 | No Objeción del Banco a la SP y conformacion Lista Corta |  | 5d | 2017-01-10 | 2017-01-16 | 1196 | 2017-01-10 | 2017-01-16 | 737d | 0d |
| 1198 | 3.2.3.3.1.11 | Envio de Solicitud de Propuestas (SP) a los integrantes de la lista corta (Invitación a presentar propuestas) |  | 2d | 2017-01-17 | 2017-01-18 | 1190, 1197 | 2017-01-17 | 2017-01-18 | 737d | 0d |
| 1199 | 3.2.3.3.1.12 | Reunión aclaratoria (eventual a los diez días de la invitación) | milestone | 0d | 2017-02-01 | 2017-02-01 | 1198FS+10d | 2017-02-01 | 2017-02-01 | 737d | 0d |
| 1200 | 3.2.3.3.1.13 | Preparación de respuestas a las solicitudes de aclaraciones de los oferentes y solicitud de No Objeción al Banco |  | 3d | 2017-02-02 | 2017-02-06 | 1199 | 2017-02-02 | 2017-02-06 | 737d | 0d |
| 1201 | 3.2.3.3.1.14 | No objeción del Banco a las respuestas de aclaraciones |  | 5d | 2017-02-07 | 2017-02-13 | 1200 | 2017-02-07 | 2017-02-13 | 737d | 0d |
| 1202 | 3.2.3.3.1.15 | Respuesta a las solicitudes de aclaración antes de la recepción de propuestas |  | 3d | 2017-02-14 | 2017-02-16 | 1201 | 2017-02-14 | 2017-02-16 | 737d | 0d |
| 1203 | 3.2.3.3.1.17 | Designación del Comité de Evaluación |  | 1d | 2017-02-17 | 2017-02-17 | 1202 | 2017-02-17 | 2017-02-17 | 737d | 0d |
| 1204 | 3.2.3.3.1.18 | Recepción de las Propuestas técnicas y de precio y Apertura de propuestas técnicas | milestone | 0d | 2017-02-15 | 2017-02-15 | 1198FS+4w | 2017-02-15 | 2017-02-15 | 739d | 2d |
| 1205 | 3.2.3.3.1.19 | Envío de propuestas al Comité de Evaluación y al Especialista en Adquisiciones | milestone | 0d | 2017-02-17 | 2017-02-17 | 1203, 1204 | 2017-02-17 | 2017-02-17 | 737d | 0d |
| 1206 | 3.2.3.3.1.20 | Evaluación de propuestas técnicas y elaboración borrador del Informe de Evaluación Técnica (IET) |  | 10d | 2017-02-20 | 2017-03-03 | 1205 | 2017-02-20 | 2017-03-03 | 737d | 0d |
| 1207 | 3.2.3.3.1.16 | Reunion Comité de Evaluación |  | 1d | 2017-03-06 | 2017-03-06 | 1206 | 2017-03-06 | 2017-03-06 | 737d | 0d |
| 1208 | 3.2.3.3.1.21 | Solicitud de No Objeción del Banco al Informe de Evaluación Técnica (IET) de las propuestas |  | 1d | 2017-03-07 | 2017-03-07 | 1207 | 2017-03-07 | 2017-03-07 | 737d | 0d |
| 1209 | 3.2.3.3.1.22 | No Objeción del Banco al IET |  | 5d | 2017-03-08 | 2017-03-14 | 1208 | 2017-03-08 | 2017-03-14 | 737d | 0d |
| 1210 | 3.2.3.3.1.23 | Notificación del puntaje de la evaluación técnica a los proponentes y notificar simultáneamente a los que obtuvieron la calificación mínima necesaria e indicar la fecha, lugar y hora fijada para abrir las propuestas de precio. |  | 1d | 2017-03-15 | 2017-03-15 | 1209 | 2017-03-15 | 2017-03-15 | 737d | 0d |
| 1211 | 3.2.3.3.1.24 | Apertura de propuesta de precio en Audiencia Pública | milestone | 0d | 2017-03-23 | 2017-03-23 | 1210FS+5d | 2017-03-23 | 2017-03-23 | 737d | 0d |
| 1212 | 3.2.3.3.1.25 | Evaluación del Costo y Evaluación Combinada de la Calidad y el Costo |  | 1d | 2017-03-24 | 2017-03-24 | 1211 | 2017-03-24 | 2017-03-24 | 737d | 0d |
| 1213 | 3.2.3.3.1.26 | Notificación y negociación del contrato con el proponente seleccionado, elaboración del borrador del contrato negociado y solicitud de No Objeción Banco |  | 10d | 2017-03-27 | 2017-04-07 | 1212 | 2017-03-27 | 2017-04-07 | 737d | 0d |
| 1214 | 3.2.3.3.1.27 | No Objeción del Banco al borrador del contrato negociado y envio acta de apertura de sobres y evaluacion combinada |  | 5d | 2017-04-10 | 2017-04-18 | 1213 | 2017-04-10 | 2017-04-18 | 737d | 0d |
| 1215 | 3.2.3.3.1.28 | Notificación a las demás firmas incluidas en la lista corta que sus propuestas no fueron seleccionadas |  | 1d | 2017-04-19 | 2017-04-19 | 1214 | 2017-04-19 | 2017-04-19 | 737d | 0d |
| 1216 | 3.2.3.3.1.29 | Publicación de la Adjudicación del Contrato |  | 1d | 2017-04-20 | 2017-04-20 | 1215 | 2017-04-20 | 2017-04-20 | 737d | 0d |
| 1217 | 3.2.3.3.1.30 | Legalización y Firma del Contrato |  | 10d | 2017-04-21 | 2017-05-05 | 1216 | 2017-04-21 | 2017-05-05 | 737d | 0d |
| 1218 | 3.2.3.3.1.31 | Envio al Banco de una copia firmada del contrato |  | 1d | 2017-05-08 | 2017-05-08 | 1217 | 2017-05-08 | 2017-05-08 | 941d |  |

| ID | WBS | Task | Type | Duration | Start | Finish | Predecessors | Baseline 1 start | Baseline 1 finish | Total slack | Free slack |
| --- | --- | --- | --- | --- | --- | --- | --- | --- | --- | --- | --- |
| 1219 | 3.2.4.47 | **Contractual** |  | 125d | 2017-05-08 | 2017-11-09 |  | 2017-05-08 | 2017-11-09 | 737d |  |
| 1220 | 3.2.3.3.2.1 | Acta de inicio |  | 5d | 2017-05-08 | 2017-05-12 | 1217 | 2017-05-08 | 2017-05-12 | 737d | 0d |
| 1221 | 3.7.1.1.2.2 | Pagina WEB de la CGR disenada e implementada |  | 6mo | 2017-05-15 | 2017-11-09 | 1220 | 2017-05-15 | 2017-11-09 | 737d | 0d |
| 1222 | 3.7.1.1.3 | **Cierre** |  | 80d | 2017-11-10 | 2018-03-08 |  | 2017-11-10 | 2018-03-08 | 737d |  |
| 1223 | 3.7.1.1.3.1 | Liquidación del contrato |  | 4mo | 2017-11-10 | 2018-03-08 | 1221 | 2017-11-10 | 2018-03-08 | 737d |  |
| 1224 | 3.7.2 | **Producto 20. Diagnostico del proceso de gestion de denuncias ciudadanas realizado y plan de mejoras implementado** |  | 521d | 2015-11-20 | 2018-01-05 |  | 2015-06-25 | 2018-12-31 | 780d |  |
| 1225 | 3.7.2.1 | **Consultoria: Elaborar un diagnóstico del proceso de gestión de denuncias y definir un modelo para su mejoramiento SCC** |  | 206d | 2015-11-23 | 2016-09-22 |  | 2015-06-25 | 2016-04-27 | 1093d |  |
| 1226 | 3.7.2.1.1 | **Precontractual** |  | 64d | 2015-11-23 | 2016-02-24 |  | 2015-06-25 | 2015-09-28 | 1093d |  |
| 1227 | 3.7.2.1.1.1 | Elaboración de los TR |  | 1d | 2015-11-23 | 2015-11-23 | 16FS+5mo | 2015-06-25 | 2015-06-25 | 1093d | 0d |
| 1228 | 3.7.2.1.1.2 | Estimado de costos y presupuesto |  | 1d | 2015-11-24 | 2015-11-24 | 1227 | 2015-06-26 | 2015-06-26 | 1093d | 0d |
| 1229 | 3.7.2.1.1.3 | No objeción del Banco a los TR |  | 5d | 2015-11-25 | 2015-12-01 | 1228 | 2015-06-30 | 2015-07-06 | 1093d | 0d |
| 1230 | 3.7.2.1.1.4 | Elaboración del Aviso Específico de Adquisiciones (AEA) solicitando Expresiones de Interés (EI) |  | 2d | 2015-12-02 | 2015-12-03 | 1229 | 2015-07-07 | 2015-07-08 | 1093d | 0d |
| 1231 | 3.7.2.1.1.5 | No Objeción del Banco al AEA |  | 5d | 2015-12-04 | 2015-12-11 | 1230 | 2015-07-09 | 2015-07-15 | 1093d | 0d |
| 1232 | 3.7.2.1.1.6 | Publicación del AEA en SECOP |  | 2d | 2015-12-14 | 2015-12-15 | 1231 | 2015-07-16 | 2015-07-17 | 1093d | 0d |
| 1233 | 3.7.2.1.1.7 | Recepción de Expresiones de Interés | milestone | 0d | 2015-12-29 | 2015-12-29 | 1232FS+14ed | 2015-07-31 | 2015-07-31 | 1094d | 0d |
| 1234 | 3.7.2.1.1.8 | Evaluación de EI recibidas y conformación de lista corta ordenada por Orden de Merito |  | 5d | 2015-12-30 | 2016-01-06 | 1233 | 2015-08-03 | 2015-08-10 | 1094d | 0d |
| 1235 | 3.7.2.1.1.9 | Elaboracion de la Solicitud de Propuestas (SP) |  | 1w | 2015-12-30 | 2016-01-06 | 1233 | 2015-08-03 | 2015-08-10 | 1094d | 0d |
| 1236 | 3.7.2.1.1.10 | No Objeción del Banco a la lista corta rankeada y SP |  | 5d | 2016-01-07 | 2016-01-14 | 1234, 1235 | 2015-08-11 | 2015-08-18 | 1094d | 0d |
| 1237 | 3.7.2.1.1.11 | Invitación a presentar propuesta tecnica y economica solo a la Firma Consultora (FC) rankeada en 1º lugar |  | 2d | 2016-01-15 | 2016-01-18 | 1236 | 2015-08-19 | 2015-08-20 | 1094d | 0d |
| 1238 | 3.7.2.1.1.12 | Recepción de propuesta de la FC invitada | milestone | 0d | 2016-02-01 | 2016-02-01 | 1237FS+2w | 2015-09-03 | 2015-09-03 | 1094d | 0d |
| 1239 | 3.7.2.1.1.13 | Evaluación de la propuesta y negociación del contrato |  | 1w | 2016-02-02 | 2016-02-08 | 1238 | 2015-09-04 | 2015-09-10 | 1094d | 0d |
| 1240 | 3.7.2.1.1.14 | No Objeción del Banco al contrato negociado y rubricado |  | 5d | 2016-02-09 | 2016-02-15 | 1239 | 2015-09-11 | 2015-09-17 | 1094d | 0d |
| 1241 | 3.7.2.1.1.15 | Publicar el nombre del consultor al cual se le adjudicó el contrato, |  | 2d | 2016-02-16 | 2016-02-17 | 1240 | 2015-09-18 | 2015-09-21 | 1094d | 0d |
| 1242 | 3.7.2.1.1.16 | Firma del contrato y envío del contrato al Banco para registro |  | 1w | 2016-02-18 | 2016-02-24 | 1241 | 2015-09-22 | 2015-09-28 | 1094d | 0d |

| ID | WBS | Task | Type | Duration | Start | Finish | Predecessors | Baseline 1 start | Baseline 1 finish | Total slack | Free slack |
| --- | --- | --- | --- | --- | --- | --- | --- | --- | --- | --- | --- |
| 1243 | 3.2.4.47 | **Contractual** |  | 62d | 2016-02-25 | 2016-05-26 |  | 2015-09-29 | 2015-12-30 | 1094d |  |
| 1244 | 3.2.3.3.2.1 | Acta de inicio |  | 2d | 2016-02-25 | 2016-02-26 | 1242 | 2015-09-29 | 2015-09-30 | 1094d | 0d |
| 1245 | 3.7.2.1.2.2 | Diagnóstico de la situación actual de los cuatro procesos misionales |  | 2mo | 2016-02-29 | 2016-04-27 | 1244 | 2015-10-01 | 2015-11-30 | 1094d | 0d |
| 1246 | 3.7.2.1.2.3 | Definición de un Plan de acción y recomendaciones para el cierre de brechas y optimización de los cuatro procesos misionales estableciendo recomendaciones para mejorar su funcionamiento individual y su vinculacion al SGC de la entidad. |  | 1mo | 2016-04-28 | 2016-05-26 | 1245 | 2015-12-01 | 2015-12-30 | 1094d | 0d |
| 1247 | 3.7.2.1.3 | **Cierre** |  | 80d | 2016-05-27 | 2016-09-22 |  | 2015-12-31 | 2016-04-27 | 1094d |  |
| 1248 | 3.7.2.1.3.1 | Liquidacion de contrato |  | 4mo | 2016-05-27 | 2016-09-22 | 1246 | 2015-12-31 | 2016-04-27 | 1094d |  |
| 1249 | 3.7.2.2 | **Consultoria: Disenar e implementarlas mejoras a la plataforma SIPAR conforme a las definiciones de arquitectura empresarial y el diagnostico del proceso de gestion de denuncias. SBCC** |  | 521d | 2015-11-20 | 2018-01-05 |  | 2016-11-11 | 2018-12-31 | 780d |  |
| 1250 | 3.2.3.3.1 | **Precontractual** |  | 161d | 2015-11-20 | 2016-07-18 |  | 2016-11-11 | 2017-07-10 | 780d |  |
| 1251 | 3.2.3.3.1.1 | Elaboración de los términos de referencia (TR) |  | 1.5mo | 2015-11-20 | 2016-01-05 | 46FS+3mo | 2016-11-11 | 2016-12-26 | 780d | 0d |
| 1252 | 3.2.3.3.1.3 | Preparación de la estimación de costos y presupuesto (Estudio de mercado) |  | 15d | 2016-01-06 | 2016-01-27 | 1251 | 2016-12-27 | 2017-01-17 | 780d | 0d |
| 1253 | 3.7.2.2.1.3 | Solicitud de Vigencias Futuras | milestone | 0d | 2016-01-27 | 2016-01-27 | 1252 | 2017-01-17 | 2017-01-17 | 780d | 0d |
| 1254 | 3.2.3.3.1.4 | Elaboración del Aviso Específico de Adquisiciones (AEA) solicitando expresiones de interés y solicitud de No Objeción al Banco |  | 2d | 2016-01-28 | 2016-01-29 | 1252 | 2017-01-18 | 2017-01-19 | 1222d | 0d |
| 1255 | 3.2.3.3.1.5 | No Objeción del Banco al AEA |  | 5d | 2016-02-01 | 2016-02-05 | 1254 | 2017-01-20 | 2017-01-26 | 1222d | 0d |
| 1256 | 3.2.3.3.1.6 | Publicación del AEA en SECOP (los contratos de valor mayor al equivalente de US $200.000 se deben anunciar ademas en los sitios de Internet del UNDB online y del Banco) |  | 2d | 2016-02-08 | 2016-02-09 | 1255 | 2017-01-27 | 2017-01-30 | 1222d | 0d |
| 1257 | 3.2.3.3.1.7 | Recepción de expresiones de interés | milestone | 0d | 2016-02-23 | 2016-02-23 | 1256FS+14ed | 2017-02-13 | 2017-02-13 | 1222d | 0d |
| 1258 | 3.2.3.3.1.8 | Evaluación de Expresiones de Interés recibidas y conformación de lista corta |  | 5d | 2016-02-24 | 2016-03-01 | 1257 | 2017-02-14 | 2017-02-20 | 1232d |  |
| 1259 | 3.2.3.3.1.9 | Elaboración de la Solicitud de Propuesta (SP) que incluye: (a) la Carta de Invitación a las firmas de la lista corta; (b) las Instrucciones a los Consultores; © los TR; y (d) el contrato propuesto; y solicitud de No Objeción al Banco |  | 10d | 2016-02-24 | 2016-03-08 | 1257 | 2017-02-14 | 2017-02-27 | 1222d | 0d |
| 1260 | 3.2.3.3.1.10 | No Objeción del Banco a la SP y conformacion Lista Corta |  | 5d | 2016-03-09 | 2016-03-15 | 1259 | 2017-02-28 | 2017-03-06 | 1222d |  |
| 1261 | 3.2.3.3.1.11 | Envio de Solicitud de Propuestas (SP) a los integrantes de la lista corta (Invitación a presentar propuestas) |  | 2d | 2016-03-29 | 2016-03-30 | 1253FS+2mo | 2017-03-15 | 2017-03-16 | 780d | 0d |
| 1262 | 3.2.3.3.1.12 | Reunión aclaratoria (eventual a los diez días de la invitación) | milestone | 0d | 2016-04-13 | 2016-04-13 | 1261FS+10d | 2017-03-31 | 2017-03-31 | 780d | 0d |
| 1263 | 3.2.3.3.1.13 | Preparación de respuestas a las solicitudes de aclaraciones de los oferentes y solicitud de No Objeción al Banco |  | 3d | 2016-04-14 | 2016-04-18 | 1262 | 2017-04-03 | 2017-04-05 | 780d | 0d |
| 1264 | 3.2.3.3.1.14 | No objeción del Banco a las respuestas de aclaraciones |  | 5d | 2016-04-19 | 2016-04-25 | 1263 | 2017-04-06 | 2017-04-12 | 780d | 0d |
| 1265 | 3.2.3.3.1.15 | Respuesta a las solicitudes de aclaración antes de la recepción de propuestas |  | 3d | 2016-04-26 | 2016-04-28 | 1264 | 2017-04-17 | 2017-04-19 | 780d | 0d |
| 1266 | 3.2.3.3.1.17 | Designación del Comité de Evaluación |  | 1d | 2016-04-29 | 2016-04-29 | 1265 | 2017-04-20 | 2017-04-20 | 780d | 0d |
| 1267 | 3.2.3.3.1.18 | Recepción de las Propuestas técnicas y de precio y Apertura de propuestas técnicas | milestone | 0d | 2016-04-27 | 2016-04-27 | 1261FS+4w | 2017-04-18 | 2017-04-18 | 782d | 2d |
| 1268 | 3.2.3.3.1.19 | Envío de propuestas al Comité de Evaluación y al Especialista en Adquisiciones | milestone | 0d | 2016-04-29 | 2016-04-29 | 1266, 1267 | 2017-04-20 | 2017-04-20 | 780d | 0d |
| 1269 | 3.2.3.3.1.20 | Evaluación de propuestas técnicas y elaboración borrador del Informe de Evaluación Técnica (IET) |  | 10d | 2016-05-02 | 2016-05-16 | 1268 | 2017-04-21 | 2017-05-05 | 780d | 0d |
| 1270 | 3.2.3.3.1.16 | Reunion Comité de Evaluación |  | 1d | 2016-05-17 | 2016-05-17 | 1269 | 2017-05-08 | 2017-05-08 | 780d | 0d |
| 1271 | 3.2.3.3.1.21 | Solicitud de No Objeción del Banco al Informe de Evaluación Técnica (IET) de las propuestas |  | 1d | 2016-05-18 | 2016-05-18 | 1270 | 2017-05-09 | 2017-05-09 | 780d | 0d |
| 1272 | 3.2.3.3.1.22 | No Objeción del Banco al IET |  | 5d | 2016-05-19 | 2016-05-25 | 1271 | 2017-05-10 | 2017-05-16 | 780d | 0d |
| 1273 | 3.2.3.3.1.23 | Notificación del puntaje de la evaluación técnica a los proponentes y notificar simultáneamente a los que obtuvieron la calificación mínima necesaria e indicar la fecha, lugar y hora fijada para abrir las propuestas de precio. |  | 1d | 2016-05-26 | 2016-05-26 | 1272 | 2017-05-17 | 2017-05-17 | 780d | 0d |
| 1274 | 3.2.3.3.1.24 | Apertura de propuesta de precio en Audiencia Pública | milestone | 0d | 2016-06-03 | 2016-06-03 | 1273FS+5d | 2017-05-24 | 2017-05-24 | 780d | 0d |
| 1275 | 3.2.3.3.1.25 | Evaluación del Costo y Evaluación Combinada de la Calidad y el Costo |  | 1d | 2016-06-07 | 2016-06-07 | 1274 | 2017-05-25 | 2017-05-25 | 780d | 0d |
| 1276 | 3.2.3.3.1.26 | Notificación y negociación del contrato con el proponente seleccionado, elaboración del borrador del contrato negociado y solicitud de No Objeción Banco |  | 10d | 2016-06-08 | 2016-06-21 | 1275 | 2017-05-26 | 2017-06-09 | 780d | 0d |
| 1277 | 3.2.3.3.1.27 | No Objeción del Banco al borrador del contrato negociado y envio acta de apertura de sobres y evaluacion combinada |  | 5d | 2016-06-22 | 2016-06-28 | 1276 | 2017-06-12 | 2017-06-16 | 780d | 0d |
| 1278 | 3.2.3.3.1.28 | Notificación a las demás firmas incluidas en la lista corta que sus propuestas no fueron seleccionadas |  | 1d | 2016-06-29 | 2016-06-29 | 1277 | 2017-06-20 | 2017-06-20 | 780d | 0d |
| 1279 | 3.2.3.3.1.29 | Publicación de la Adjudicación del Contrato |  | 1d | 2016-06-30 | 2016-06-30 | 1278 | 2017-06-21 | 2017-06-21 | 780d | 0d |
| 1280 | 3.2.3.3.1.30 | Legalización y Firma del Contrato |  | 10d | 2016-07-01 | 2016-07-15 | 1279 | 2017-06-22 | 2017-07-07 | 780d | 0d |
| 1281 | 3.2.3.3.1.31 | Envio al Banco de una copia firmada del contrato |  | 1d | 2016-07-18 | 2016-07-18 | 1280 | 2017-07-10 | 2017-07-10 | 1140d |  |

| ID | WBS | Task | Type | Duration | Start | Finish | Predecessors | Baseline 1 start | Baseline 1 finish | Total slack | Free slack |
| --- | --- | --- | --- | --- | --- | --- | --- | --- | --- | --- | --- |
| 1282 | 3.2.4.47 | **Contractual** |  | 281d | 2016-07-18 | 2017-09-07 |  | 2017-07-10 | 2018-09-04 | 780d |  |
| 1283 | 3.2.3.3.2.1 | Acta de inicio |  | 1d | 2016-07-18 | 2016-07-18 | 1280 | 2017-07-10 | 2017-07-10 | 780d | 0d |
| 1284 | 3.7.2.2.2.2 | Mejoras a la plataforma SIPAR disenadas e implementadas |  | 14mo | 2016-07-19 | 2017-09-07 | 1283 | 2017-07-11 | 2018-09-04 | 780d | 0d |
| 1285 | 3.7.2.2.3 | **Cierre** |  | 80d | 2017-09-08 | 2018-01-05 |  | 2018-09-05 | 2018-12-31 | 780d |  |
| 1286 | 3.7.2.2.3.1 | Liquidación del contrato |  | 4mo | 2017-09-08 | 2018-01-05 | 1284 | 2018-09-05 | 2018-12-31 | 780d |  |
| 1287 | 3.7.3 | **Producto 21. Estrategia de promocion y fomento del Control Fiscal Participativo diseñada e implementada** |  | 900d | 2015-11-23 | 2019-07-15 |  | 2015-06-25 | 2019-02-25 | 400d |  |
| 1288 | 3.7.3.1 | **Consultoria: Desarrollo de actividades de la estrategia de promocion y fomento del Control Fiscal Participativo. SCC** |  | 206d | 2015-11-23 | 2016-09-22 |  | 2015-06-25 | 2016-04-27 | 1093d |  |
| 1289 | 3.7.3.1.1 | **Precontractual** |  | 64d | 2015-11-23 | 2016-02-24 |  | 2015-06-25 | 2015-09-28 | 1093d |  |
| 1290 | 3.7.3.1.1.1 | Elaboración de los TR |  | 1d | 2015-11-23 | 2015-11-23 | 16FS+5mo | 2015-06-25 | 2015-06-25 | 1093d | 0d |
| 1291 | 3.7.3.1.1.2 | Estimado de costos y presupuesto |  | 1d | 2015-11-24 | 2015-11-24 | 1290 | 2015-06-26 | 2015-06-26 | 1093d | 0d |
| 1292 | 3.7.3.1.1.3 | No objeción del Banco a los TR |  | 5d | 2015-11-25 | 2015-12-01 | 1291 | 2015-06-30 | 2015-07-06 | 1093d | 0d |
| 1293 | 3.7.3.1.1.4 | Elaboración del Aviso Específico de Adquisiciones (AEA) solicitando Expresiones de Interés (EI) |  | 2d | 2015-12-02 | 2015-12-03 | 1292 | 2015-07-07 | 2015-07-08 | 1093d | 0d |
| 1294 | 3.7.3.1.1.5 | No Objeción del Banco al AEA |  | 5d | 2015-12-04 | 2015-12-11 | 1293 | 2015-07-09 | 2015-07-15 | 1093d | 0d |
| 1295 | 3.7.3.1.1.6 | Publicación del AEA en SECOP |  | 2d | 2015-12-14 | 2015-12-15 | 1294 | 2015-07-16 | 2015-07-17 | 1093d | 0d |
| 1296 | 3.7.3.1.1.7 | Recepción de Expresiones de Interés | milestone | 0d | 2015-12-29 | 2015-12-29 | 1295FS+14ed | 2015-07-31 | 2015-07-31 | 1094d | 0d |
| 1297 | 3.7.3.1.1.8 | Evaluación de EI recibidas y conformación de lista corta ordenada por Orden de Merito |  | 5d | 2015-12-30 | 2016-01-06 | 1296 | 2015-08-03 | 2015-08-10 | 1094d | 0d |
| 1298 | 3.7.3.1.1.9 | Elaboracion de la Solicitud de Propuestas (SP) |  | 1w | 2015-12-30 | 2016-01-06 | 1296 | 2015-08-03 | 2015-08-10 | 1094d | 0d |
| 1299 | 3.7.3.1.1.10 | No Objeción del Banco a la lista corta rankeada y SP |  | 5d | 2016-01-07 | 2016-01-14 | 1297, 1298 | 2015-08-11 | 2015-08-18 | 1094d | 0d |
| 1300 | 3.7.3.1.1.11 | Invitación a presentar propuesta tecnica y economica solo a la Firma Consultora (FC) rankeada en 1º lugar |  | 2d | 2016-01-15 | 2016-01-18 | 1299 | 2015-08-19 | 2015-08-20 | 1094d | 0d |
| 1301 | 3.7.3.1.1.12 | Recepción de propuesta de la FC invitada | milestone | 0d | 2016-02-01 | 2016-02-01 | 1300FS+2w | 2015-09-03 | 2015-09-03 | 1094d | 0d |
| 1302 | 3.7.3.1.1.13 | Evaluación de la propuesta y negociación del contrato |  | 1w | 2016-02-02 | 2016-02-08 | 1301 | 2015-09-04 | 2015-09-10 | 1094d | 0d |
| 1303 | 3.7.3.1.1.14 | No Objeción del Banco al contrato negociado y rubricado |  | 5d | 2016-02-09 | 2016-02-15 | 1302 | 2015-09-11 | 2015-09-17 | 1094d | 0d |
| 1304 | 3.7.3.1.1.15 | Publicar el nombre del consultor al cual se le adjudicó el contrato, |  | 2d | 2016-02-16 | 2016-02-17 | 1303 | 2015-09-18 | 2015-09-21 | 1094d | 0d |
| 1305 | 3.7.3.1.1.16 | Firma del contrato y envío del contrato al Banco para registro |  | 1w | 2016-02-18 | 2016-02-24 | 1304 | 2015-09-22 | 2015-09-28 | 1094d | 0d |

| ID | WBS | Task | Type | Duration | Start | Finish | Predecessors | Baseline 1 start | Baseline 1 finish | Total slack | Free slack |
| --- | --- | --- | --- | --- | --- | --- | --- | --- | --- | --- | --- |
| 1306 | 3.2.4.47 | **Contractual** |  | 62d | 2016-02-25 | 2016-05-26 |  | 2015-09-29 | 2015-12-30 | 1094d |  |
| 1307 | 3.2.3.3.2.1 | Acta de inicio |  | 2d | 2016-02-25 | 2016-02-26 | 1305 | 2015-09-29 | 2015-09-30 | 1094d | 0d |
| 1308 | 3.7.3.1.2.2 | Actividades de la estrategia de promocion y fomento del Control Fiscal Participativo desarrolladas |  | 3mo | 2016-02-29 | 2016-05-26 | 1307 | 2015-10-01 | 2015-12-30 | 1094d | 0d |
| 1309 | 3.7.3.1.3 | **Cierre** |  | 80d | 2016-05-27 | 2016-09-22 |  | 2015-12-31 | 2016-04-27 | 1094d |  |
| 1310 | 3.7.3.1.3.1 | Liquidacion de contrato |  | 4mo | 2016-05-27 | 2016-09-22 | 1308 | 2015-12-31 | 2016-04-27 | 1094d |  |
| 1311 | 3.7.3.2 | **Consultoria: Apoyo al desarrollo de veedurias ciudadanas y conformacion de redes a nivel nacional. SBCC** |  | 661d | 2016-11-11 | 2019-07-15 |  | 2016-11-11 | 2019-02-25 | 400d |  |
| 1312 | 3.2.3.3.1 | **Precontractual** |  | 161d | 2016-11-11 | 2017-07-10 |  | 2016-11-11 | 2017-07-10 | 400d |  |
| 1313 | 3.2.3.3.1.1 | Elaboración de los términos de referencia (TR) |  | 1.5mo | 2016-11-11 | 2016-12-26 | 46FS+15mo | 2016-11-11 | 2016-12-26 | 400d | 0d |
| 1314 | 3.2.3.3.1.3 | Preparación de la estimación de costos y presupuesto (Estudio de mercado) |  | 15d | 2016-12-27 | 2017-01-17 | 1313 | 2016-12-27 | 2017-01-17 | 400d | 0d |
| 1315 | 3.7.3.2.1.3 | Solicitud de Vigencias Futuras 2018 y 2019 | milestone | 0d | 2017-01-17 | 2017-01-17 | 1314 | 2017-01-17 | 2017-01-17 | 400d | 0d |
| 1316 | 3.2.3.3.1.4 | Elaboración del Aviso Específico de Adquisiciones (AEA) solicitando expresiones de interés y solicitud de No Objeción al Banco |  | 2d | 2017-01-18 | 2017-01-19 | 1314 | 2017-01-18 | 2017-01-19 | 982d | 0d |
| 1317 | 3.2.3.3.1.5 | No Objeción del Banco al AEA |  | 5d | 2017-01-20 | 2017-01-26 | 1316 | 2017-01-20 | 2017-01-26 | 982d | 0d |
| 1318 | 3.2.3.3.1.6 | Publicación del AEA en SECOP (los contratos de valor mayor al equivalente de US $200.000 se deben anunciar ademas en los sitios de Internet del UNDB online y del Banco) |  | 2d | 2017-01-27 | 2017-01-30 | 1317 | 2017-01-27 | 2017-01-30 | 982d | 0d |
| 1319 | 3.2.3.3.1.7 | Recepción de expresiones de interés | milestone | 0d | 2017-02-13 | 2017-02-13 | 1318FS+14ed | 2017-02-13 | 2017-02-13 | 982d | 0d |
| 1320 | 3.2.3.3.1.8 | Evaluación de Expresiones de Interés recibidas y conformación de lista corta |  | 5d | 2017-02-14 | 2017-02-20 | 1319 | 2017-02-14 | 2017-02-20 | 992d |  |
| 1321 | 3.2.3.3.1.9 | Elaboración de la Solicitud de Propuesta (SP) que incluye: (a) la Carta de Invitación a las firmas de la lista corta; (b) las Instrucciones a los Consultores; © los TR; y (d) el contrato propuesto; y solicitud de No Objeción al Banco |  | 10d | 2017-02-14 | 2017-02-27 | 1319 | 2017-02-14 | 2017-02-27 | 982d | 0d |
| 1322 | 3.2.3.3.1.10 | No Objeción del Banco a la SP y conformacion Lista Corta |  | 5d | 2017-02-28 | 2017-03-06 | 1321 | 2017-02-28 | 2017-03-06 | 982d |  |
| 1323 | 3.2.3.3.1.11 | Envio de Solicitud de Propuestas (SP) a los integrantes de la lista corta (Invitación a presentar propuestas) |  | 2d | 2017-03-15 | 2017-03-16 | 1315FS+2mo | 2017-03-15 | 2017-03-16 | 400d | 0d |
| 1324 | 3.2.3.3.1.12 | Reunión aclaratoria (eventual a los diez días de la invitación) | milestone | 0d | 2017-03-31 | 2017-03-31 | 1323FS+10d | 2017-03-31 | 2017-03-31 | 400d | 0d |
| 1325 | 3.2.3.3.1.13 | Preparación de respuestas a las solicitudes de aclaraciones de los oferentes y solicitud de No Objeción al Banco |  | 3d | 2017-04-03 | 2017-04-05 | 1324 | 2017-04-03 | 2017-04-05 | 400d | 0d |
| 1326 | 3.2.3.3.1.14 | No objeción del Banco a las respuestas de aclaraciones |  | 5d | 2017-04-06 | 2017-04-12 | 1325 | 2017-04-06 | 2017-04-12 | 400d | 0d |
| 1327 | 3.2.3.3.1.15 | Respuesta a las solicitudes de aclaración antes de la recepción de propuestas |  | 3d | 2017-04-17 | 2017-04-19 | 1326 | 2017-04-17 | 2017-04-19 | 400d | 0d |
| 1328 | 3.2.3.3.1.17 | Designación del Comité de Evaluación |  | 1d | 2017-04-20 | 2017-04-20 | 1327 | 2017-04-20 | 2017-04-20 | 400d | 0d |
| 1329 | 3.2.3.3.1.18 | Recepción de las Propuestas técnicas y de precio y Apertura de propuestas técnicas | milestone | 0d | 2017-04-18 | 2017-04-18 | 1323FS+4w | 2017-04-18 | 2017-04-18 | 402d | 2d |
| 1330 | 3.2.3.3.1.19 | Envío de propuestas al Comité de Evaluación y al Especialista en Adquisiciones | milestone | 0d | 2017-04-20 | 2017-04-20 | 1328, 1329 | 2017-04-20 | 2017-04-20 | 400d | 0d |
| 1331 | 3.2.3.3.1.20 | Evaluación de propuestas técnicas y elaboración borrador del Informe de Evaluación Técnica (IET) |  | 10d | 2017-04-21 | 2017-05-05 | 1330 | 2017-04-21 | 2017-05-05 | 400d | 0d |
| 1332 | 3.2.3.3.1.16 | Reunion Comité de Evaluación |  | 1d | 2017-05-08 | 2017-05-08 | 1331 | 2017-05-08 | 2017-05-08 | 400d | 0d |
| 1333 | 3.2.3.3.1.21 | Solicitud de No Objeción del Banco al Informe de Evaluación Técnica (IET) de las propuestas |  | 1d | 2017-05-09 | 2017-05-09 | 1332 | 2017-05-09 | 2017-05-09 | 400d | 0d |
| 1334 | 3.2.3.3.1.22 | No Objeción del Banco al IET |  | 5d | 2017-05-10 | 2017-05-16 | 1333 | 2017-05-10 | 2017-05-16 | 400d | 0d |
| 1335 | 3.2.3.3.1.23 | Notificación del puntaje de la evaluación técnica a los proponentes y notificar simultáneamente a los que obtuvieron la calificación mínima necesaria e indicar la fecha, lugar y hora fijada para abrir las propuestas de precio. |  | 1d | 2017-05-17 | 2017-05-17 | 1334 | 2017-05-17 | 2017-05-17 | 400d | 0d |
| 1336 | 3.2.3.3.1.24 | Apertura de propuesta de precio en Audiencia Pública | milestone | 0d | 2017-05-24 | 2017-05-24 | 1335FS+5d | 2017-05-24 | 2017-05-24 | 400d | 0d |
| 1337 | 3.2.3.3.1.25 | Evaluación del Costo y Evaluación Combinada de la Calidad y el Costo |  | 1d | 2017-05-25 | 2017-05-25 | 1336 | 2017-05-25 | 2017-05-25 | 400d | 0d |
| 1338 | 3.2.3.3.1.26 | Notificación y negociación del contrato con el proponente seleccionado, elaboración del borrador del contrato negociado y solicitud de No Objeción Banco |  | 10d | 2017-05-26 | 2017-06-09 | 1337 | 2017-05-26 | 2017-06-09 | 400d | 0d |
| 1339 | 3.2.3.3.1.27 | No Objeción del Banco al borrador del contrato negociado y envio acta de apertura de sobres y evaluacion combinada |  | 5d | 2017-06-12 | 2017-06-16 | 1338 | 2017-06-12 | 2017-06-16 | 400d | 0d |
| 1340 | 3.2.3.3.1.28 | Notificación a las demás firmas incluidas en la lista corta que sus propuestas no fueron seleccionadas |  | 1d | 2017-06-20 | 2017-06-20 | 1339 | 2017-06-20 | 2017-06-20 | 400d | 0d |
| 1341 | 3.2.3.3.1.29 | Publicación de la Adjudicación del Contrato |  | 1d | 2017-06-21 | 2017-06-21 | 1340 | 2017-06-21 | 2017-06-21 | 400d | 0d |
| 1342 | 3.2.3.3.1.30 | Legalización y Firma del Contrato |  | 10d | 2017-06-22 | 2017-07-07 | 1341 | 2017-06-22 | 2017-07-07 | 400d | 0d |
| 1343 | 3.2.3.3.1.31 | Envio al Banco de una copia firmada del contrato |  | 1d | 2017-07-10 | 2017-07-10 | 1342 | 2017-07-10 | 2017-07-10 | 900d |  |

| ID | WBS | Task | Type | Duration | Start | Finish | Predecessors | Baseline 1 start | Baseline 1 finish | Total slack | Free slack |
| --- | --- | --- | --- | --- | --- | --- | --- | --- | --- | --- | --- |
| 1344 | 3.2.4.47 | **Contractual** |  | 421d | 2017-07-10 | 2019-03-25 |  | 2017-07-10 | 2018-10-31 | 400d |  |
| 1345 | 3.2.3.3.2.1 | Acta de inicio |  | 1d | 2017-07-10 | 2017-07-10 | 1342 | 2017-07-10 | 2017-07-10 | 400d | 0d |
| 1346 | 3.7.3.2.2.2 | Veedurias ciudadanas apoyadas y redes a nivel nacional conformadas. |  | 21mo | 2017-07-11 | 2019-03-25 | 1345 | 2017-07-11 | 2018-10-31 | 400d | 0d |
| 1347 | 3.7.3.2.3 | **Cierre** |  | 80d | 2019-03-26 | 2019-07-15 |  | 2018-11-01 | 2019-02-25 | 400d |  |
| 1348 | 3.7.3.2.3.1 | Liquidación del contrato |  | 4mo | 2019-03-26 | 2019-07-15 | 1346 | 2018-11-01 | 2019-02-25 | 400d |  |
| 1349 | 3.7.3.3 | **Consultoria: Apoyo al desarrollo de talleres de formacion ciudadana para el control fiscal participativo a nivel nacional, SBCC** |  | 661d | 2016-11-11 | 2019-07-15 |  | 2016-11-11 | 2019-02-25 | 400d |  |
| 1350 | 3.2.3.3.1 | **Precontractual** |  | 161d | 2016-11-11 | 2017-07-10 |  | 2016-11-11 | 2017-07-10 | 400d |  |
| 1351 | 3.2.3.3.1.1 | Elaboración de los términos de referencia (TR) |  | 1.5mo | 2016-11-11 | 2016-12-26 | 46FS+15mo | 2016-11-11 | 2016-12-26 | 400d | 0d |
| 1352 | 3.2.3.3.1.3 | Preparación de la estimación de costos y presupuesto (Estudio de mercado) |  | 15d | 2016-12-27 | 2017-01-17 | 1351 | 2016-12-27 | 2017-01-17 | 400d | 0d |
| 1353 | 3.7.3.3.1.3 | Solicitud de Vigencias Futuras 2018 y 2019 | milestone | 0d | 2017-01-17 | 2017-01-17 | 1352 | 2017-01-17 | 2017-01-17 | 400d | 0d |
| 1354 | 3.2.3.3.1.4 | Elaboración del Aviso Específico de Adquisiciones (AEA) solicitando expresiones de interés y solicitud de No Objeción al Banco |  | 2d | 2017-01-18 | 2017-01-19 | 1352 | 2017-01-18 | 2017-01-19 | 982d | 0d |
| 1355 | 3.2.3.3.1.5 | No Objeción del Banco al AEA |  | 5d | 2017-01-20 | 2017-01-26 | 1354 | 2017-01-20 | 2017-01-26 | 982d | 0d |
| 1356 | 3.2.3.3.1.6 | Publicación del AEA en SECOP (los contratos de valor mayor al equivalente de US $200.000 se deben anunciar ademas en los sitios de Internet del UNDB online y del Banco) |  | 2d | 2017-01-27 | 2017-01-30 | 1355 | 2017-01-27 | 2017-01-30 | 982d | 0d |
| 1357 | 3.2.3.3.1.7 | Recepción de expresiones de interés | milestone | 0d | 2017-02-13 | 2017-02-13 | 1356FS+14ed | 2017-02-13 | 2017-02-13 | 982d | 0d |
| 1358 | 3.2.3.3.1.8 | Evaluación de Expresiones de Interés recibidas y conformación de lista corta |  | 5d | 2017-02-14 | 2017-02-20 | 1357 | 2017-02-14 | 2017-02-20 | 992d |  |
| 1359 | 3.2.3.3.1.9 | Elaboración de la Solicitud de Propuesta (SP) que incluye: (a) la Carta de Invitación a las firmas de la lista corta; (b) las Instrucciones a los Consultores; © los TR; y (d) el contrato propuesto; y solicitud de No Objeción al Banco |  | 10d | 2017-02-14 | 2017-02-27 | 1357 | 2017-02-14 | 2017-02-27 | 982d | 0d |
| 1360 | 3.2.3.3.1.10 | No Objeción del Banco a la SP y conformacion Lista Corta |  | 5d | 2017-02-28 | 2017-03-06 | 1359 | 2017-02-28 | 2017-03-06 | 982d |  |
| 1361 | 3.2.3.3.1.11 | Envio de Solicitud de Propuestas (SP) a los integrantes de la lista corta (Invitación a presentar propuestas) |  | 2d | 2017-03-15 | 2017-03-16 | 1353FS+2mo | 2017-03-15 | 2017-03-16 | 400d | 0d |
| 1362 | 3.2.3.3.1.12 | Reunión aclaratoria (eventual a los diez días de la invitación) | milestone | 0d | 2017-03-31 | 2017-03-31 | 1361FS+10d | 2017-03-31 | 2017-03-31 | 400d | 0d |
| 1363 | 3.2.3.3.1.13 | Preparación de respuestas a las solicitudes de aclaraciones de los oferentes y solicitud de No Objeción al Banco |  | 3d | 2017-04-03 | 2017-04-05 | 1362 | 2017-04-03 | 2017-04-05 | 400d | 0d |
| 1364 | 3.2.3.3.1.14 | No objeción del Banco a las respuestas de aclaraciones |  | 5d | 2017-04-06 | 2017-04-12 | 1363 | 2017-04-06 | 2017-04-12 | 400d | 0d |
| 1365 | 3.2.3.3.1.15 | Respuesta a las solicitudes de aclaración antes de la recepción de propuestas |  | 3d | 2017-04-17 | 2017-04-19 | 1364 | 2017-04-17 | 2017-04-19 | 400d | 0d |
| 1366 | 3.2.3.3.1.17 | Designación del Comité de Evaluación |  | 1d | 2017-04-20 | 2017-04-20 | 1365 | 2017-04-20 | 2017-04-20 | 400d | 0d |
| 1367 | 3.2.3.3.1.18 | Recepción de las Propuestas técnicas y de precio y Apertura de propuestas técnicas | milestone | 0d | 2017-04-18 | 2017-04-18 | 1361FS+4w | 2017-04-18 | 2017-04-18 | 402d | 2d |
| 1368 | 3.2.3.3.1.19 | Envío de propuestas al Comité de Evaluación y al Especialista en Adquisiciones | milestone | 0d | 2017-04-20 | 2017-04-20 | 1366, 1367 | 2017-04-20 | 2017-04-20 | 400d | 0d |
| 1369 | 3.2.3.3.1.20 | Evaluación de propuestas técnicas y elaboración borrador del Informe de Evaluación Técnica (IET) |  | 10d | 2017-04-21 | 2017-05-05 | 1368 | 2017-04-21 | 2017-05-05 | 400d | 0d |
| 1370 | 3.2.3.3.1.16 | Reunion Comité de Evaluación |  | 1d | 2017-05-08 | 2017-05-08 | 1369 | 2017-05-08 | 2017-05-08 | 400d | 0d |
| 1371 | 3.2.3.3.1.21 | Solicitud de No Objeción del Banco al Informe de Evaluación Técnica (IET) de las propuestas |  | 1d | 2017-05-09 | 2017-05-09 | 1370 | 2017-05-09 | 2017-05-09 | 400d | 0d |
| 1372 | 3.2.3.3.1.22 | No Objeción del Banco al IET |  | 5d | 2017-05-10 | 2017-05-16 | 1371 | 2017-05-10 | 2017-05-16 | 400d | 0d |
| 1373 | 3.2.3.3.1.23 | Notificación del puntaje de la evaluación técnica a los proponentes y notificar simultáneamente a los que obtuvieron la calificación mínima necesaria e indicar la fecha, lugar y hora fijada para abrir las propuestas de precio. |  | 1d | 2017-05-17 | 2017-05-17 | 1372 | 2017-05-17 | 2017-05-17 | 400d | 0d |
| 1374 | 3.2.3.3.1.24 | Apertura de propuesta de precio en Audiencia Pública | milestone | 0d | 2017-05-24 | 2017-05-24 | 1373FS+5d | 2017-05-24 | 2017-05-24 | 400d | 0d |
| 1375 | 3.2.3.3.1.25 | Evaluación del Costo y Evaluación Combinada de la Calidad y el Costo |  | 1d | 2017-05-25 | 2017-05-25 | 1374 | 2017-05-25 | 2017-05-25 | 400d | 0d |
| 1376 | 3.2.3.3.1.26 | Notificación y negociación del contrato con el proponente seleccionado, elaboración del borrador del contrato negociado y solicitud de No Objeción Banco |  | 10d | 2017-05-26 | 2017-06-09 | 1375 | 2017-05-26 | 2017-06-09 | 400d | 0d |
| 1377 | 3.2.3.3.1.27 | No Objeción del Banco al borrador del contrato negociado y envio acta de apertura de sobres y evaluacion combinada |  | 5d | 2017-06-12 | 2017-06-16 | 1376 | 2017-06-12 | 2017-06-16 | 400d | 0d |
| 1378 | 3.2.3.3.1.28 | Notificación a las demás firmas incluidas en la lista corta que sus propuestas no fueron seleccionadas |  | 1d | 2017-06-20 | 2017-06-20 | 1377 | 2017-06-20 | 2017-06-20 | 400d | 0d |
| 1379 | 3.2.3.3.1.29 | Publicación de la Adjudicación del Contrato |  | 1d | 2017-06-21 | 2017-06-21 | 1378 | 2017-06-21 | 2017-06-21 | 400d | 0d |
| 1380 | 3.2.3.3.1.30 | Legalización y Firma del Contrato |  | 10d | 2017-06-22 | 2017-07-07 | 1379 | 2017-06-22 | 2017-07-07 | 400d | 0d |
| 1381 | 3.2.3.3.1.31 | Envio al Banco de una copia firmada del contrato |  | 1d | 2017-07-10 | 2017-07-10 | 1380 | 2017-07-10 | 2017-07-10 | 900d |  |

| ID | WBS | Task | Type | Duration | Start | Finish | Predecessors | Baseline 1 start | Baseline 1 finish | Total slack | Free slack |
| --- | --- | --- | --- | --- | --- | --- | --- | --- | --- | --- | --- |
| 1382 | 3.2.4.47 | **Contractual** |  | 421d | 2017-07-10 | 2019-03-25 |  | 2017-07-10 | 2018-10-31 | 400d |  |
| 1383 | 3.2.3.3.2.1 | Acta de inicio |  | 1d | 2017-07-10 | 2017-07-10 | 1380 | 2017-07-10 | 2017-07-10 | 400d | 0d |
| 1384 | 3.7.3.3.2.2 | Talleres de formacion ciudadana para el control fiscal participativo a nivel nacional desarrollados |  | 21mo | 2017-07-11 | 2019-03-25 | 1383 | 2017-07-11 | 2018-10-31 | 400d | 0d |
| 1385 | 3.7.3.3.3 | **Cierre** |  | 80d | 2019-03-26 | 2019-07-15 |  | 2018-11-01 | 2019-02-25 | 400d |  |
| 1386 | 3.7.3.3.3.1 | Liquidación del contrato |  | 4mo | 2019-03-26 | 2019-07-15 | 1384 | 2018-11-01 | 2019-02-25 | 400d |  |
| 1387 | 3.7.4 | **Producto 22. Estrategia de comunicaciones de la CGR disenada e implementada** |  | 900d | 2015-11-23 | 2019-07-15 |  | 2015-06-25 | 2019-02-25 | 400d |  |
| 1388 | 3.7.4.1 | **Consultoria: Diseno de la estrategia de comunicaciones interna y externa de la CGR. SCC** |  | 207d | 2015-11-23 | 2016-09-23 |  | 2015-06-25 | 2016-04-28 | 1092d |  |
| 1389 | 3.7.4.1.1 | **Precontractual** |  | 65d | 2015-11-23 | 2016-02-25 |  | 2015-06-25 | 2015-09-29 | 1092d |  |
| 1390 | 3.7.4.1.1.1 | Elaboración de los TR |  | 1d | 2015-11-23 | 2015-11-23 | 16FS+5mo | 2015-06-25 | 2015-06-25 | 1092d | 0d |
| 1391 | 3.7.4.1.1.2 | Estimado de costos y presupuesto |  | 1d | 2015-11-24 | 2015-11-24 | 1390 | 2015-06-26 | 2015-06-26 | 1092d | 0d |
| 1392 | 3.7.4.1.1.3 | No objeción del Banco a los TR |  | 4d | 2015-11-25 | 2015-11-30 | 1391 | 2015-06-30 | 2015-07-03 | 1092d | 0d |
| 1393 | 3.7.4.1.1.4 | Elaboración del Aviso Específico de Adquisiciones (AEA) solicitando Expresiones de Interés (EI) |  | 2d | 2015-12-01 | 2015-12-02 | 1392 | 2015-07-06 | 2015-07-07 | 1092d | 0d |
| 1394 | 3.7.4.1.1.5 | No Objeción del Banco al AEA |  | 4d | 2015-12-03 | 2015-12-09 | 1393 | 2015-07-08 | 2015-07-13 | 1092d | 0d |
| 1395 | 3.7.4.1.1.6 | Publicación del AEA en SECOP |  | 2d | 2015-12-10 | 2015-12-11 | 1394 | 2015-07-14 | 2015-07-15 | 1092d | 0d |
| 1396 | 3.7.4.1.1.7 | Recepción de Expresiones de Interés | milestone | 0d | 2015-12-25 | 2015-12-25 | 1395FS+14ed | 2015-07-29 | 2015-07-29 | 1093d | 0d |
| 1397 | 3.7.4.1.1.8 | Evaluación de EI recibidas y conformación de lista corta ordenada por Orden de Merito |  | 1w | 2015-12-28 | 2016-01-04 | 1396 | 2015-07-30 | 2015-08-05 | 1098d | 5d |
| 1398 | 3.7.4.1.1.9 | Elaboracion de la Solicitud de Propuestas (SP) |  | 2w | 2015-12-28 | 2016-01-12 | 1396 | 2015-07-30 | 2015-08-13 | 1093d | 0d |
| 1399 | 3.7.4.1.1.10 | No Objeción del Banco a la lista corta rankeada y SP |  | 4d | 2016-01-13 | 2016-01-18 | 1397, 1398 | 2015-08-14 | 2015-08-20 | 1093d | 0d |
| 1400 | 3.7.4.1.1.11 | Invitación a presentar propuesta tecnica y economica solo a la Firma Consultora (FC) rankeada en 1º lugar |  | 2d | 2016-01-19 | 2016-01-20 | 1399 | 2015-08-21 | 2015-08-24 | 1093d | 0d |
| 1401 | 3.7.4.1.1.12 | Recepción de propuesta de la FC invitada | milestone | 0d | 2016-02-03 | 2016-02-03 | 1400FS+2w | 2015-09-07 | 2015-09-07 | 1093d | 0d |
| 1402 | 3.7.4.1.1.13 | Evaluación de la propuesta y negociación del contrato |  | 5d | 2016-02-04 | 2016-02-10 | 1401 | 2015-09-08 | 2015-09-14 | 1093d | 0d |
| 1403 | 3.7.4.1.1.14 | No Objeción del Banco al contrato negociado y rubricado |  | 4d | 2016-02-11 | 2016-02-16 | 1402 | 2015-09-15 | 2015-09-18 | 1093d | 0d |
| 1404 | 3.7.4.1.1.15 | Publicar el nombre del consultor al cual se le adjudicó el contrato, |  | 2d | 2016-02-17 | 2016-02-18 | 1403 | 2015-09-21 | 2015-09-22 | 1093d | 0d |
| 1405 | 3.7.4.1.1.16 | Firma del contrato y envío del contrato al Banco para registro |  | 1w | 2016-02-19 | 2016-02-25 | 1404 | 2015-09-23 | 2015-09-29 | 1093d | 0d |

| ID | WBS | Task | Type | Duration | Start | Finish | Predecessors | Baseline 1 start | Baseline 1 finish | Total slack | Free slack |
| --- | --- | --- | --- | --- | --- | --- | --- | --- | --- | --- | --- |
| 1406 | 3.2.4.47 | **Contractual** |  | 62d | 2016-02-26 | 2016-05-27 |  | 2015-09-30 | 2015-12-31 | 1093d |  |
| 1407 | 3.7.4.1.2.1 | Acta de inicio |  | 2d | 2016-02-26 | 2016-02-29 | 1405 | 2015-09-30 | 2015-10-01 | 1093d | 0d |
| 1408 | 3.7.4.1.2.2 | Estrategia de comunicaciones interna y externa de la CGR disenada |  | 3mo | 2016-03-01 | 2016-05-27 | 1407 | 2015-10-02 | 2015-12-31 | 1093d | 0d |
| 1409 | 3.7.4.1.3 | **Cierre** |  | 80d | 2016-05-31 | 2016-09-23 |  | 2016-01-04 | 2016-04-28 | 1093d |  |
| 1410 | 3.7.4.1.3.1 | Liquidacion de contrato |  | 4mo | 2016-05-31 | 2016-09-23 | 1408 | 2016-01-04 | 2016-04-28 | 1093d |  |
| 1411 | 3.7.4.2 | **Consultoria: Implementacion de la estrategia de comunicaciones internas y externas de la CGR. SBCC** |  | 661d | 2016-11-11 | 2019-07-15 |  | 2016-11-11 | 2019-02-25 | 400d |  |
| 1412 | 3.2.3.3.1 | **Precontractual** |  | 161d | 2016-11-11 | 2017-07-10 |  | 2016-11-11 | 2017-07-10 | 400d |  |
| 1413 | 3.2.3.3.1.1 | Elaboración de los términos de referencia (TR) |  | 1.5mo | 2016-11-11 | 2016-12-26 | 46FS+15mo | 2016-11-11 | 2016-12-26 | 400d | 0d |
| 1414 | 3.2.3.3.1.3 | Preparación de la estimación de costos y presupuesto (Estudio de mercado) |  | 15d | 2016-12-27 | 2017-01-17 | 1413 | 2016-12-27 | 2017-01-17 | 400d | 0d |
| 1415 | 3.7.4.2.1.3 | Solicitud de Vigencias Futuras 2018 y 2019 | milestone | 0d | 2017-01-17 | 2017-01-17 | 1414 | 2017-01-17 | 2017-01-17 | 400d | 0d |
| 1416 | 3.2.3.3.1.4 | Elaboración del Aviso Específico de Adquisiciones (AEA) solicitando expresiones de interés y solicitud de No Objeción al Banco |  | 2d | 2017-01-18 | 2017-01-19 | 1414 | 2017-01-18 | 2017-01-19 | 982d | 0d |
| 1417 | 3.2.3.3.1.5 | No Objeción del Banco al AEA |  | 5d | 2017-01-20 | 2017-01-26 | 1416 | 2017-01-20 | 2017-01-26 | 982d | 0d |
| 1418 | 3.2.3.3.1.6 | Publicación del AEA en SECOP (los contratos de valor mayor al equivalente de US $200.000 se deben anunciar ademas en los sitios de Internet del UNDB online y del Banco) |  | 2d | 2017-01-27 | 2017-01-30 | 1417 | 2017-01-27 | 2017-01-30 | 982d | 0d |
| 1419 | 3.2.3.3.1.7 | Recepción de expresiones de interés | milestone | 0d | 2017-02-13 | 2017-02-13 | 1418FS+14ed | 2017-02-13 | 2017-02-13 | 982d | 0d |
| 1420 | 3.2.3.3.1.8 | Evaluación de Expresiones de Interés recibidas y conformación de lista corta |  | 5d | 2017-02-14 | 2017-02-20 | 1419 | 2017-02-14 | 2017-02-20 | 992d |  |
| 1421 | 3.2.3.3.1.9 | Elaboración de la Solicitud de Propuesta (SP) que incluye: (a) la Carta de Invitación a las firmas de la lista corta; (b) las Instrucciones a los Consultores; © los TR; y (d) el contrato propuesto; y solicitud de No Objeción al Banco |  | 10d | 2017-02-14 | 2017-02-27 | 1419 | 2017-02-14 | 2017-02-27 | 982d | 0d |
| 1422 | 3.2.3.3.1.10 | No Objeción del Banco a la SP y conformacion Lista Corta |  | 5d | 2017-02-28 | 2017-03-06 | 1421 | 2017-02-28 | 2017-03-06 | 982d |  |
| 1423 | 3.2.3.3.1.11 | Envio de Solicitud de Propuestas (SP) a los integrantes de la lista corta (Invitación a presentar propuestas) |  | 2d | 2017-03-15 | 2017-03-16 | 1415FS+2mo | 2017-03-15 | 2017-03-16 | 400d | 0d |
| 1424 | 3.2.3.3.1.12 | Reunión aclaratoria (eventual a los diez días de la invitación) | milestone | 0d | 2017-03-31 | 2017-03-31 | 1423FS+10d | 2017-03-31 | 2017-03-31 | 400d | 0d |
| 1425 | 3.2.3.3.1.13 | Preparación de respuestas a las solicitudes de aclaraciones de los oferentes y solicitud de No Objeción al Banco |  | 3d | 2017-04-03 | 2017-04-05 | 1424 | 2017-04-03 | 2017-04-05 | 400d | 0d |
| 1426 | 3.2.3.3.1.14 | No objeción del Banco a las respuestas de aclaraciones |  | 5d | 2017-04-06 | 2017-04-12 | 1425 | 2017-04-06 | 2017-04-12 | 400d | 0d |
| 1427 | 3.2.3.3.1.15 | Respuesta a las solicitudes de aclaración antes de la recepción de propuestas |  | 3d | 2017-04-17 | 2017-04-19 | 1426 | 2017-04-17 | 2017-04-19 | 400d | 0d |
| 1428 | 3.2.3.3.1.17 | Designación del Comité de Evaluación |  | 1d | 2017-04-20 | 2017-04-20 | 1427 | 2017-04-20 | 2017-04-20 | 400d | 0d |
| 1429 | 3.2.3.3.1.18 | Recepción de las Propuestas técnicas y de precio y Apertura de propuestas técnicas | milestone | 0d | 2017-04-18 | 2017-04-18 | 1423FS+4w | 2017-04-18 | 2017-04-18 | 402d | 2d |
| 1430 | 3.2.3.3.1.19 | Envío de propuestas al Comité de Evaluación y al Especialista en Adquisiciones | milestone | 0d | 2017-04-20 | 2017-04-20 | 1428, 1429 | 2017-04-20 | 2017-04-20 | 400d | 0d |
| 1431 | 3.2.3.3.1.20 | Evaluación de propuestas técnicas y elaboración borrador del Informe de Evaluación Técnica (IET) |  | 10d | 2017-04-21 | 2017-05-05 | 1430 | 2017-04-21 | 2017-05-05 | 400d | 0d |
| 1432 | 3.2.3.3.1.16 | Reunion Comité de Evaluación |  | 1d | 2017-05-08 | 2017-05-08 | 1431 | 2017-05-08 | 2017-05-08 | 400d | 0d |
| 1433 | 3.2.3.3.1.21 | Solicitud de No Objeción del Banco al Informe de Evaluación Técnica (IET) de las propuestas |  | 1d | 2017-05-09 | 2017-05-09 | 1432 | 2017-05-09 | 2017-05-09 | 400d | 0d |
| 1434 | 3.2.3.3.1.22 | No Objeción del Banco al IET |  | 5d | 2017-05-10 | 2017-05-16 | 1433 | 2017-05-10 | 2017-05-16 | 400d | 0d |
| 1435 | 3.2.3.3.1.23 | Notificación del puntaje de la evaluación técnica a los proponentes y notificar simultáneamente a los que obtuvieron la calificación mínima necesaria e indicar la fecha, lugar y hora fijada para abrir las propuestas de precio. |  | 1d | 2017-05-17 | 2017-05-17 | 1434 | 2017-05-17 | 2017-05-17 | 400d | 0d |
| 1436 | 3.2.3.3.1.24 | Apertura de propuesta de precio en Audiencia Pública | milestone | 0d | 2017-05-24 | 2017-05-24 | 1435FS+5d | 2017-05-24 | 2017-05-24 | 400d | 0d |
| 1437 | 3.2.3.3.1.25 | Evaluación del Costo y Evaluación Combinada de la Calidad y el Costo |  | 1d | 2017-05-25 | 2017-05-25 | 1436 | 2017-05-25 | 2017-05-25 | 400d | 0d |
| 1438 | 3.2.3.3.1.26 | Notificación y negociación del contrato con el proponente seleccionado, elaboración del borrador del contrato negociado y solicitud de No Objeción Banco |  | 10d | 2017-05-26 | 2017-06-09 | 1437 | 2017-05-26 | 2017-06-09 | 400d | 0d |
| 1439 | 3.2.3.3.1.27 | No Objeción del Banco al borrador del contrato negociado y envio acta de apertura de sobres y evaluacion combinada |  | 5d | 2017-06-12 | 2017-06-16 | 1438 | 2017-06-12 | 2017-06-16 | 400d | 0d |
| 1440 | 3.2.3.3.1.28 | Notificación a las demás firmas incluidas en la lista corta que sus propuestas no fueron seleccionadas |  | 1d | 2017-06-20 | 2017-06-20 | 1439 | 2017-06-20 | 2017-06-20 | 400d | 0d |
| 1441 | 3.2.3.3.1.29 | Publicación de la Adjudicación del Contrato |  | 1d | 2017-06-21 | 2017-06-21 | 1440 | 2017-06-21 | 2017-06-21 | 400d | 0d |
| 1442 | 3.2.3.3.1.30 | Legalización y Firma del Contrato |  | 10d | 2017-06-22 | 2017-07-07 | 1441 | 2017-06-22 | 2017-07-07 | 400d | 0d |
| 1443 | 3.2.3.3.1.31 | Envio al Banco de una copia firmada del contrato |  | 1d | 2017-07-10 | 2017-07-10 | 1442 | 2017-07-10 | 2017-07-10 | 900d |  |

| ID | WBS | Task | Type | Duration | Start | Finish | Predecessors | Baseline 1 start | Baseline 1 finish | Total slack | Free slack |
| --- | --- | --- | --- | --- | --- | --- | --- | --- | --- | --- | --- |
| 1444 | 3.2.4.47 | **Contractual** |  | 421d | 2017-07-10 | 2019-03-25 |  | 2017-07-10 | 2018-10-31 | 400d |  |
| 1445 | 3.2.3.3.2.1 | Acta de inicio |  | 1d | 2017-07-10 | 2017-07-10 | 1442 | 2017-07-10 | 2017-07-10 | 400d | 0d |
| 1446 | 3.7.4.2.2.2 | Estrategias de comunicaciones interna y externa de la CGR implementada |  | 21mo | 2017-07-11 | 2019-03-25 | 1445 | 2017-07-11 | 2018-10-31 | 400d | 0d |
| 1447 | 3.7.4.2.3 | **Cierre** |  | 80d | 2019-03-26 | 2019-07-15 |  | 2018-11-01 | 2019-02-25 | 400d |  |
| 1448 | 3.7.4.2.3.1 | Liquidación del contrato |  | 4mo | 2019-03-26 | 2019-07-15 | 1446 | 2018-11-01 | 2019-02-25 | 400d |  |
| 1449 | 3.7.5 | **Producto 23. Encuestas de percepcion a sujetos de control y ciudadania aplicadas.** |  | 1055d | 2015-06-25 | 2019-09-30 |  | 2015-06-25 | 2018-10-23 | 345d |  |
| 1450 | 3.7.5.1 | **Consultoria: Diseno, aplicacion y divulgacion de resultados de una encuenta de percepcion ciudadana (medicion inicial). SCC** |  | 207d | 2015-06-25 | 2016-04-28 |  | 2015-06-25 | 2016-04-28 | 1192d |  |
| 1451 | 3.7.5.1.1 | **Precontractual** |  | 65d | 2015-06-25 | 2015-09-29 |  | 2015-06-25 | 2015-09-29 | 1192d |  |
| 1452 | 3.7.5.1.1.1 | Elaboración de los TR |  | 1d | 2015-06-25 | 2015-06-25 | 16 | 2015-06-25 | 2015-06-25 | 1192d | 0d |
| 1453 | 3.7.5.1.1.2 | Estimado de costos y presupuesto |  | 1d | 2015-06-26 | 2015-06-26 | 1452 | 2015-06-26 | 2015-06-26 | 1192d | 0d |
| 1454 | 3.7.5.1.1.3 | No objeción del Banco a los TR |  | 4d | 2015-06-30 | 2015-07-03 | 1453 | 2015-06-30 | 2015-07-03 | 1192d | 0d |
| 1455 | 3.7.5.1.1.4 | Elaboración del Aviso Específico de Adquisiciones (AEA) solicitando Expresiones de Interés (EI) |  | 2d | 2015-07-06 | 2015-07-07 | 1454 | 2015-07-06 | 2015-07-07 | 1192d | 0d |
| 1456 | 3.7.5.1.1.5 | No Objeción del Banco al AEA |  | 4d | 2015-07-08 | 2015-07-13 | 1455 | 2015-07-08 | 2015-07-13 | 1192d | 0d |
| 1457 | 3.7.5.1.1.6 | Publicación del AEA en SECOP |  | 2d | 2015-07-14 | 2015-07-15 | 1456 | 2015-07-14 | 2015-07-15 | 1192d | 0d |
| 1458 | 3.7.5.1.1.7 | Recepción de Expresiones de Interés | milestone | 0d | 2015-07-29 | 2015-07-29 | 1457FS+14ed | 2015-07-29 | 2015-07-29 | 1193d | 0d |
| 1459 | 3.7.5.1.1.8 | Evaluación de EI recibidas y conformación de lista corta ordenada por Orden de Merito |  | 1w | 2015-07-30 | 2015-08-05 | 1458 | 2015-07-30 | 2015-08-05 | 1198d | 5d |
| 1460 | 3.7.5.1.1.9 | Elaboracion de la Solicitud de Propuestas (SP) |  | 2w | 2015-07-30 | 2015-08-13 | 1458 | 2015-07-30 | 2015-08-13 | 1193d | 0d |
| 1461 | 3.7.5.1.1.10 | No Objeción del Banco a la lista corta rankeada y SP |  | 4d | 2015-08-14 | 2015-08-20 | 1459, 1460 | 2015-08-14 | 2015-08-20 | 1193d | 0d |
| 1462 | 3.7.5.1.1.11 | Invitación a presentar propuesta tecnica y economica solo a la Firma Consultora (FC) rankeada en 1º lugar |  | 2d | 2015-08-21 | 2015-08-24 | 1461 | 2015-08-21 | 2015-08-24 | 1193d | 0d |
| 1463 | 3.7.5.1.1.12 | Recepción de propuesta de la FC invitada | milestone | 0d | 2015-09-07 | 2015-09-07 | 1462FS+2w | 2015-09-07 | 2015-09-07 | 1193d | 0d |
| 1464 | 3.7.5.1.1.13 | Evaluación de la propuesta y negociación del contrato |  | 5d | 2015-09-08 | 2015-09-14 | 1463 | 2015-09-08 | 2015-09-14 | 1193d | 0d |
| 1465 | 3.7.5.1.1.14 | No Objeción del Banco al contrato negociado y rubricado |  | 4d | 2015-09-15 | 2015-09-18 | 1464 | 2015-09-15 | 2015-09-18 | 1193d | 0d |
| 1466 | 3.7.5.1.1.15 | Publicar el nombre del consultor al cual se le adjudicó el contrato, |  | 2d | 2015-09-21 | 2015-09-22 | 1465 | 2015-09-21 | 2015-09-22 | 1193d | 0d |
| 1467 | 3.7.5.1.1.16 | Firma del contrato y envío del contrato al Banco para registro |  | 1w | 2015-09-23 | 2015-09-29 | 1466 | 2015-09-23 | 2015-09-29 | 1193d | 0d |

| ID | WBS | Task | Type | Duration | Start | Finish | Predecessors | Baseline 1 start | Baseline 1 finish | Total slack | Free slack |
| --- | --- | --- | --- | --- | --- | --- | --- | --- | --- | --- | --- |
| 1468 | 3.2.4.47 | **Contractual** |  | 62d | 2015-09-30 | 2015-12-31 |  | 2015-09-30 | 2015-12-31 | 1193d |  |
| 1469 | 3.7.5.1.2.1 | Acta de inicio |  | 2d | 2015-09-30 | 2015-10-01 | 1467 | 2015-09-30 | 2015-10-01 | 1193d | 0d |
| 1470 | 3.7.5.1.2.2 | Encuesta de percepcion ciudadana (medicion inicial) disenada, aplicada y divulgada |  | 3mo | 2015-10-02 | 2015-12-31 | 1469 | 2015-10-02 | 2015-12-31 | 1193d | 0d |
| 1471 | 3.7.5.1.3 | **Cierre** |  | 80d | 2016-01-04 | 2016-04-28 |  | 2016-01-04 | 2016-04-28 | 1193d |  |
| 1472 | 3.7.5.1.3.1 | Liquidacion de contrato |  | 4mo | 2016-01-04 | 2016-04-28 | 1470 | 2016-01-04 | 2016-04-28 | 1193d |  |
| 1473 | 3.7.5.2 | **Consultoria: Diseno, aplicacion y divulgacion de resultados de una encuenta de percepcion ciudadana (medicion final). SCC** |  | 256d | 2018-10-02 | 2019-09-30 |  | 2017-10-05 | 2018-10-23 | 345d |  |
| 1474 | 3.7.5.2.1 | **Precontractual** |  | 94d | 2018-10-02 | 2019-02-14 |  | 2017-10-05 | 2018-02-21 | 345d |  |
| 1475 | 3.7.5.2.1.1 | Elaboración de los TR |  | 1mo | 2018-10-02 | 2018-10-30 | 46FS+38mo | 2017-10-05 | 2017-11-02 | 345d | 0d |
| 1476 | 3.7.5.2.1.2 | Estimado de costos y presupuesto |  | 10d | 2018-10-31 | 2018-11-15 | 1475 | 2017-11-03 | 2017-11-20 | 345d | 0d |
| 1477 | 3.7.5.2.1.3 | No objeción del Banco a los TR |  | 4d | 2018-11-16 | 2018-11-21 | 1476 | 2017-11-21 | 2017-11-24 | 345d | 0d |
| 1478 | 3.7.5.2.1.4 | Elaboración del Aviso Específico de Adquisiciones (AEA) solicitando Expresiones de Interés (EI) |  | 2d | 2018-11-22 | 2018-11-23 | 1477 | 2017-11-27 | 2017-11-28 | 345d | 0d |
| 1479 | 3.7.5.2.1.5 | No Objeción del Banco al AEA |  | 4d | 2018-11-26 | 2018-11-29 | 1478 | 2017-11-29 | 2017-12-04 | 345d | 0d |
| 1480 | 3.7.5.2.1.6 | Publicación del AEA en SECOP |  | 2d | 2018-11-30 | 2018-12-03 | 1479 | 2017-12-05 | 2017-12-06 | 345d | 0d |
| 1481 | 3.7.5.2.1.7 | Recepción de Expresiones de Interés | milestone | 0d | 2018-12-17 | 2018-12-17 | 1480FS+14ed | 2017-12-20 | 2017-12-20 | 345d | 0d |
| 1482 | 3.7.5.2.1.8 | Evaluación de EI recibidas y conformación de lista corta ordenada por Orden de Merito |  | 1w | 2018-12-18 | 2018-12-24 | 1481 | 2017-12-21 | 2017-12-28 | 350d | 5d |
| 1483 | 3.7.5.2.1.9 | Elaboracion de la Solicitud de Propuestas (SP) |  | 2w | 2018-12-18 | 2019-01-01 | 1481 | 2017-12-21 | 2018-01-05 | 345d | 0d |
| 1484 | 3.7.5.2.1.10 | No Objeción del Banco a la lista corta rankeada y SP |  | 4d | 2019-01-02 | 2019-01-07 | 1482, 1483 | 2018-01-09 | 2018-01-12 | 345d | 0d |
| 1485 | 3.7.5.2.1.11 | Invitación a presentar propuesta tecnica y economica solo a la Firma Consultora (FC) rankeada en 1º lugar |  | 2d | 2019-01-08 | 2019-01-09 | 1484 | 2018-01-15 | 2018-01-16 | 345d | 0d |
| 1486 | 3.7.5.2.1.12 | Recepción de propuesta de la FC invitada | milestone | 0d | 2019-01-23 | 2019-01-23 | 1485FS+2w | 2018-01-30 | 2018-01-30 | 345d | 0d |
| 1487 | 3.7.5.2.1.13 | Evaluación de la propuesta y negociación del contrato |  | 5d | 2019-01-24 | 2019-01-30 | 1486 | 2018-01-31 | 2018-02-06 | 345d | 0d |
| 1488 | 3.7.5.2.1.14 | No Objeción del Banco al contrato negociado y rubricado |  | 4d | 2019-01-31 | 2019-02-05 | 1487 | 2018-02-07 | 2018-02-12 | 345d | 0d |
| 1489 | 3.7.5.2.1.15 | Publicar el nombre del consultor al cual se le adjudicó el contrato, |  | 2d | 2019-02-06 | 2019-02-07 | 1488 | 2018-02-13 | 2018-02-14 | 345d | 0d |
| 1490 | 3.7.5.2.1.16 | Firma del contrato y envío del contrato al Banco para registro |  | 1w | 2019-02-08 | 2019-02-14 | 1489 | 2018-02-15 | 2018-02-21 | 345d | 0d |
| 1491 | 3.2.4.47 | **Contractual** |  | 82d | 2019-02-15 | 2019-06-10 |  | 2018-02-22 | 2018-06-26 | 345d |  |
| 1492 | 3.7.5.2.2.1 | Acta de inicio |  | 2d | 2019-02-15 | 2019-02-18 | 1490 | 2018-02-22 | 2018-02-23 | 345d | 0d |
| 1493 | 3.7.5.2.2.2 | Encuesta de percepcion ciudadana (medicion final) disenada, aplicada y divulgada |  | 4mo | 2019-02-19 | 2019-06-10 | 1492 | 2018-02-26 | 2018-06-26 | 345d | 0d |

| ID | WBS | Task | Type | Duration | Start | Finish | Predecessors | Baseline 1 start | Baseline 1 finish | Total slack | Free slack |
| --- | --- | --- | --- | --- | --- | --- | --- | --- | --- | --- | --- |
| 1494 | 3.7.5.2.3 | **Cierre** |  | 80d | 2019-06-11 | 2019-09-30 |  | 2018-06-27 | 2018-10-23 | 345d |  |
| 1495 | 3.7.5.2.3.1 | Liquidacion de contrato |  | 4mo | 2019-06-11 | 2019-09-30 | 1493 | 2018-06-27 | 2018-10-23 | 345d |  |
| 1496 | 3.7.5.3 | **Consultoria: Diseno, aplicacion y divulgacion de resultados de una medicion de la percepcion de los sujetos de control frente a la gestion de la CGR (medicion inicial). SCC** |  | 207d | 2015-06-25 | 2016-04-28 |  | 2015-06-25 | 2016-04-28 | 1192d |  |
| 1497 | 3.7.5.3.1 | **Precontractual** |  | 65d | 2015-06-25 | 2015-09-29 |  | 2015-06-25 | 2015-09-29 | 1192d |  |
| 1498 | 3.7.5.3.1.1 | Elaboración de los TR |  | 1d | 2015-06-25 | 2015-06-25 | 16 | 2015-06-25 | 2015-06-25 | 1192d | 0d |
| 1499 | 3.7.5.3.1.2 | Estimado de costos y presupuesto |  | 1d | 2015-06-26 | 2015-06-26 | 1498 | 2015-06-26 | 2015-06-26 | 1192d | 0d |
| 1500 | 3.7.5.3.1.3 | No objeción del Banco a los TR |  | 4d | 2015-06-30 | 2015-07-03 | 1499 | 2015-06-30 | 2015-07-03 | 1192d | 0d |
| 1501 | 3.7.5.3.1.4 | Elaboración del Aviso Específico de Adquisiciones (AEA) solicitando Expresiones de Interés (EI) |  | 2d | 2015-07-06 | 2015-07-07 | 1500 | 2015-07-06 | 2015-07-07 | 1192d | 0d |
| 1502 | 3.7.5.3.1.5 | No Objeción del Banco al AEA |  | 4d | 2015-07-08 | 2015-07-13 | 1501 | 2015-07-08 | 2015-07-13 | 1192d | 0d |
| 1503 | 3.7.5.3.1.6 | Publicación del AEA en SECOP |  | 2d | 2015-07-14 | 2015-07-15 | 1502 | 2015-07-14 | 2015-07-15 | 1192d | 0d |
| 1504 | 3.7.5.3.1.7 | Recepción de Expresiones de Interés | milestone | 0d | 2015-07-29 | 2015-07-29 | 1503FS+14ed | 2015-07-29 | 2015-07-29 | 1193d | 0d |
| 1505 | 3.7.5.3.1.8 | Evaluación de EI recibidas y conformación de lista corta ordenada por Orden de Merito |  | 1w | 2015-07-30 | 2015-08-05 | 1504 | 2015-07-30 | 2015-08-05 | 1198d | 5d |
| 1506 | 3.7.5.3.1.9 | Elaboracion de la Solicitud de Propuestas (SP) |  | 2w | 2015-07-30 | 2015-08-13 | 1504 | 2015-07-30 | 2015-08-13 | 1193d | 0d |
| 1507 | 3.7.5.3.1.10 | No Objeción del Banco a la lista corta rankeada y SP |  | 4d | 2015-08-14 | 2015-08-20 | 1505, 1506 | 2015-08-14 | 2015-08-20 | 1193d | 0d |
| 1508 | 3.7.5.3.1.11 | Invitación a presentar propuesta tecnica y economica solo a la Firma Consultora (FC) rankeada en 1º lugar |  | 2d | 2015-08-21 | 2015-08-24 | 1507 | 2015-08-21 | 2015-08-24 | 1193d | 0d |
| 1509 | 3.7.5.3.1.12 | Recepción de propuesta de la FC invitada | milestone | 0d | 2015-09-07 | 2015-09-07 | 1508FS+2w | 2015-09-07 | 2015-09-07 | 1193d | 0d |
| 1510 | 3.7.5.3.1.13 | Evaluación de la propuesta y negociación del contrato |  | 5d | 2015-09-08 | 2015-09-14 | 1509 | 2015-09-08 | 2015-09-14 | 1193d | 0d |
| 1511 | 3.7.5.3.1.14 | No Objeción del Banco al contrato negociado y rubricado |  | 4d | 2015-09-15 | 2015-09-18 | 1510 | 2015-09-15 | 2015-09-18 | 1193d | 0d |
| 1512 | 3.7.5.3.1.15 | Publicar el nombre del consultor al cual se le adjudicó el contrato, |  | 2d | 2015-09-21 | 2015-09-22 | 1511 | 2015-09-21 | 2015-09-22 | 1193d | 0d |
| 1513 | 3.7.5.3.1.16 | Firma del contrato y envío del contrato al Banco para registro |  | 1w | 2015-09-23 | 2015-09-29 | 1512 | 2015-09-23 | 2015-09-29 | 1193d | 0d |
| 1514 | 3.2.4.47 | **Contractual** |  | 62d | 2015-09-30 | 2015-12-31 |  | 2015-09-30 | 2015-12-31 | 1193d |  |
| 1515 | 3.7.5.3.2.1 | Acta de inicio |  | 2d | 2015-09-30 | 2015-10-01 | 1513 | 2015-09-30 | 2015-10-01 | 1193d | 0d |
| 1516 | 3.7.5.3.2.2 | Medicion de percepcion a sujetos de control (medicion inicial) disenada, aplicada y divulgada |  | 3mo | 2015-10-02 | 2015-12-31 | 1515 | 2015-10-02 | 2015-12-31 | 1193d | 0d |
| 1517 | 3.7.5.3.3 | **Cierre** |  | 80d | 2016-01-04 | 2016-04-28 |  | 2016-01-04 | 2016-04-28 | 1193d |  |
| 1518 | 3.7.5.3.3.1 | Liquidacion de contrato |  | 4mo | 2016-01-04 | 2016-04-28 | 1516 | 2016-01-04 | 2016-04-28 | 1193d |  |

| ID | WBS | Task | Type | Duration | Start | Finish | Predecessors | Baseline 1 start | Baseline 1 finish | Total slack | Free slack |
| --- | --- | --- | --- | --- | --- | --- | --- | --- | --- | --- | --- |
| 1519 | 3.7.5.4 | **Consultoria: Diseno, aplicacion y divulgacion de resultados de una medicion de la percepcion de los sujetos de control frente a la gestion de la CGR (medicion final). SCC** |  | 256d | 2018-10-02 | 2019-09-30 |  | 2017-10-05 | 2018-10-23 | 345d |  |
| 1520 | 3.7.5.4.1 | **Precontractual** |  | 94d | 2018-10-02 | 2019-02-14 |  | 2017-10-05 | 2018-02-21 | 345d |  |
| 1521 | 3.7.5.4.1.1 | Elaboración de los TR |  | 1mo | 2018-10-02 | 2018-10-30 | 46FS+38mo | 2017-10-05 | 2017-11-02 | 345d | 0d |
| 1522 | 3.7.5.4.1.2 | Estimado de costos y presupuesto |  | 10d | 2018-10-31 | 2018-11-15 | 1521 | 2017-11-03 | 2017-11-20 | 345d | 0d |
| 1523 | 3.7.5.4.1.3 | No objeción del Banco a los TR |  | 4d | 2018-11-16 | 2018-11-21 | 1522 | 2017-11-21 | 2017-11-24 | 345d | 0d |
| 1524 | 3.7.5.4.1.4 | Elaboración del Aviso Específico de Adquisiciones (AEA) solicitando Expresiones de Interés (EI) |  | 2d | 2018-11-22 | 2018-11-23 | 1523 | 2017-11-27 | 2017-11-28 | 345d | 0d |
| 1525 | 3.7.5.4.1.5 | No Objeción del Banco al AEA |  | 4d | 2018-11-26 | 2018-11-29 | 1524 | 2017-11-29 | 2017-12-04 | 345d | 0d |
| 1526 | 3.7.5.4.1.6 | Publicación del AEA en SECOP |  | 2d | 2018-11-30 | 2018-12-03 | 1525 | 2017-12-05 | 2017-12-06 | 345d | 0d |
| 1527 | 3.7.5.4.1.7 | Recepción de Expresiones de Interés | milestone | 0d | 2018-12-17 | 2018-12-17 | 1526FS+14ed | 2017-12-20 | 2017-12-20 | 345d | 0d |
| 1528 | 3.7.5.4.1.8 | Evaluación de EI recibidas y conformación de lista corta ordenada por Orden de Merito |  | 1w | 2018-12-18 | 2018-12-24 | 1527 | 2017-12-21 | 2017-12-28 | 350d | 5d |
| 1529 | 3.7.5.4.1.9 | Elaboracion de la Solicitud de Propuestas (SP) |  | 2w | 2018-12-18 | 2019-01-01 | 1527 | 2017-12-21 | 2018-01-05 | 345d | 0d |
| 1530 | 3.7.5.4.1.10 | No Objeción del Banco a la lista corta rankeada y SP |  | 4d | 2019-01-02 | 2019-01-07 | 1528, 1529 | 2018-01-09 | 2018-01-12 | 345d | 0d |
| 1531 | 3.7.5.4.1.11 | Invitación a presentar propuesta tecnica y economica solo a la Firma Consultora (FC) rankeada en 1º lugar |  | 2d | 2019-01-08 | 2019-01-09 | 1530 | 2018-01-15 | 2018-01-16 | 345d | 0d |
| 1532 | 3.7.5.4.1.12 | Recepción de propuesta de la FC invitada | milestone | 0d | 2019-01-23 | 2019-01-23 | 1531FS+2w | 2018-01-30 | 2018-01-30 | 345d | 0d |
| 1533 | 3.7.5.4.1.13 | Evaluación de la propuesta y negociación del contrato |  | 5d | 2019-01-24 | 2019-01-30 | 1532 | 2018-01-31 | 2018-02-06 | 345d | 0d |
| 1534 | 3.7.5.4.1.14 | No Objeción del Banco al contrato negociado y rubricado |  | 4d | 2019-01-31 | 2019-02-05 | 1533 | 2018-02-07 | 2018-02-12 | 345d | 0d |
| 1535 | 3.7.5.4.1.15 | Publicar el nombre del consultor al cual se le adjudicó el contrato, |  | 2d | 2019-02-06 | 2019-02-07 | 1534 | 2018-02-13 | 2018-02-14 | 345d | 0d |
| 1536 | 3.7.5.4.1.16 | Firma del contrato y envío del contrato al Banco para registro |  | 1w | 2019-02-08 | 2019-02-14 | 1535 | 2018-02-15 | 2018-02-21 | 345d | 0d |
| 1537 | 3.2.4.47 | **Contractual** |  | 82d | 2019-02-15 | 2019-06-10 |  | 2018-02-22 | 2018-06-26 | 345d |  |
| 1538 | 3.7.5.4.2.1 | Acta de inicio |  | 2d | 2019-02-15 | 2019-02-18 | 1536 | 2018-02-22 | 2018-02-23 | 345d | 0d |
| 1539 | 3.7.5.4.2.2 | Medicion de percepcion sujetos de control (medicion final) disenada, aplicada y divulgada |  | 4mo | 2019-02-19 | 2019-06-10 | 1538 | 2018-02-26 | 2018-06-26 | 345d | 0d |
| 1540 | 3.7.5.4.3 | **Cierre** |  | 80d | 2019-06-11 | 2019-09-30 |  | 2018-06-27 | 2018-10-23 | 345d |  |
| 1541 | 3.7.5.4.3.1 | Liquidacion de contrato |  | 4mo | 2019-06-11 | 2019-09-30 | 1539 | 2018-06-27 | 2018-10-23 | 345d |  |
| 1542 | 3.7.6 | **Producto 24. Estrategia de datos abiertos segun los criterios definidos por MINTIC disenada e implementada** |  | 441d | 2017-10-05 | 2019-07-15 |  | 2016-10-12 | 2018-11-21 | 398d |  |
| 1543 | 3.7.6.1 | **Consultoria: Diseno de la estrategia de datos abiertos segun los criterios definidos por MINTIC. SCC** |  | 206d | 2017-10-05 | 2018-08-13 |  | 2016-10-12 | 2017-09-27 | 398d |  |
| 1544 | 3.7.6.1.1 | **Precontractual** |  | 84d | 2017-10-05 | 2018-02-08 |  | 2016-10-12 | 2017-02-24 | 398d |  |
| 1545 | 3.7.6.1.1.1 | Elaboración de los TR |  | 1mo | 2017-10-05 | 2017-11-02 | 46FS+26mo | 2016-10-12 | 2016-11-10 | 398d | 0d |
| 1546 | 3.7.6.1.1.2 | Estimado de costos y presupuesto |  | 10d | 2017-11-03 | 2017-11-20 | 1545 | 2016-11-11 | 2016-11-25 | 398d | 0d |
| 1547 | 3.7.6.1.1.3 | No objeción del Banco a los TR |  | 5d | 2017-11-21 | 2017-11-27 | 1546 | 2016-11-28 | 2016-12-02 | 398d | 0d |
| 1548 | 3.7.6.1.1.4 | Elaboración del Aviso Específico de Adquisiciones (AEA) solicitando Expresiones de Interés (EI) |  | 2d | 2017-11-28 | 2017-11-29 | 1547 | 2016-12-05 | 2016-12-06 | 398d | 0d |
| 1549 | 3.7.6.1.1.5 | No Objeción del Banco al AEA |  | 5d | 2017-11-30 | 2017-12-06 | 1548 | 2016-12-07 | 2016-12-14 | 398d | 0d |
| 1550 | 3.7.6.1.1.6 | Publicación del AEA en SECOP |  | 2d | 2017-12-07 | 2017-12-11 | 1549 | 2016-12-15 | 2016-12-16 | 398d | 0d |
| 1551 | 3.7.6.1.1.7 | Recepción de Expresiones de Interés | milestone | 0d | 2017-12-25 | 2017-12-25 | 1550FS+14ed | 2016-12-30 | 2016-12-30 | 399d | 0d |
| 1552 | 3.7.6.1.1.8 | Evaluación de EI recibidas y conformación de lista corta ordenada por Orden de Merito |  | 5d | 2017-12-26 | 2018-01-02 | 1551 | 2017-01-02 | 2017-01-06 | 399d | 0d |
| 1553 | 3.7.6.1.1.9 | Elaboracion de la Solicitud de Propuestas (SP) |  | 1w | 2017-12-26 | 2018-01-02 | 1551 | 2017-01-02 | 2017-01-06 | 399d | 0d |
| 1554 | 3.7.6.1.1.10 | No Objeción del Banco a la lista corta rankeada y SP |  | 2d | 2018-01-03 | 2018-01-04 | 1552, 1553 | 2017-01-10 | 2017-01-16 | 399d | 0d |
| 1555 | 3.7.6.1.1.11 | Invitación a presentar propuesta tecnica y economica solo a la Firma Consultora (FC) rankeada en 1º lugar |  | 2d | 2018-01-05 | 2018-01-09 | 1554 | 2017-01-17 | 2017-01-18 | 399d | 0d |
| 1556 | 3.7.6.1.1.12 | Recepción de propuesta de la FC invitada | milestone | 0d | 2018-01-23 | 2018-01-23 | 1555FS+2w | 2017-02-01 | 2017-02-01 | 399d | 0d |
| 1557 | 3.7.6.1.1.13 | Evaluación de la propuesta y negociación del contrato |  | 3d | 2018-01-24 | 2018-01-26 | 1556 | 2017-02-02 | 2017-02-08 | 399d | 0d |
| 1558 | 3.7.6.1.1.14 | No Objeción del Banco al contrato negociado y rubricado |  | 2d | 2018-01-29 | 2018-01-30 | 1557 | 2017-02-09 | 2017-02-15 | 399d | 0d |
| 1559 | 3.7.6.1.1.15 | Publicar el nombre del consultor al cual se le adjudicó el contrato, |  | 2d | 2018-01-31 | 2018-02-01 | 1558 | 2017-02-16 | 2017-02-17 | 399d | 0d |
| 1560 | 3.7.6.1.1.16 | Firma del contrato y envío del contrato al Banco para registro |  | 1w | 2018-02-02 | 2018-02-08 | 1559 | 2017-02-20 | 2017-02-24 | 399d | 0d |

| ID | WBS | Task | Type | Duration | Start | Finish | Predecessors | Baseline 1 start | Baseline 1 finish | Total slack | Free slack |
| --- | --- | --- | --- | --- | --- | --- | --- | --- | --- | --- | --- |
| 1561 | 3.2.4.47 | **Contractual** |  | 42d | 2018-02-09 | 2018-04-12 |  | 2017-02-27 | 2017-05-30 | 399d |  |
| 1562 | 3.2.3.3.2.1 | Acta de inicio |  | 2d | 2018-02-09 | 2018-02-12 | 1560 | 2017-02-27 | 2017-02-28 | 399d | 0d |
| 1563 | 3.7.6.1.2.2 | Diseno de la estrategia de datos abiertos segun los criterios establecidos por MINTIC |  | 2mo | 2018-02-13 | 2018-04-12 | 1562 | 2017-03-01 | 2017-05-30 | 399d | 0d |
| 1564 | 3.7.6.1.3 | **Cierre** |  | 80d | 2018-04-13 | 2018-08-13 |  | 2017-05-31 | 2017-09-27 | 635d |  |
| 1565 | 3.7.6.1.3.1 | Liquidacion de contrato |  | 4mo | 2018-04-13 | 2018-08-13 | 1563 | 2017-05-31 | 2017-09-27 | 635d |  |
| 1566 | 3.7.6.2 | **Consultoria: Implementacion de la estrategia de datos abiertos segun los criterios definidos por MINTIC. SBCC** |  | 315d | 2018-04-13 | 2019-07-15 |  | 2017-02-24 | 2018-11-21 | 399d |  |
| 1567 | 3.2.3.3.1 | **Precontractual** |  | 115d | 2018-04-13 | 2018-10-02 |  | 2017-02-24 | 2017-12-26 | 399d |  |
| 1568 | 3.2.3.3.1.1 | Elaboración de los términos de referencia (TR) |  | 3d | 2018-04-13 | 2018-04-17 | 1563 | 2017-05-31 | 2017-06-21 | 399d | 0d |
| 1569 | 3.2.3.3.1.3 | Preparación de la estimación de costos y presupuesto (Estudio de mercado) |  | 3d | 2018-04-18 | 2018-04-20 | 1568 | 2017-06-22 | 2017-07-14 | 399d | 0d |
| 1570 | 3.2.3.3.1.4 | Elaboración del Aviso Específico de Adquisiciones (AEA) solicitando expresiones de interés y solicitud de No Objeción al Banco |  | 2d | 2018-04-23 | 2018-04-24 | 1569 | 2017-07-17 | 2017-07-18 | 399d | 0d |
| 1571 | 3.2.3.3.1.5 | No Objeción del Banco al AEA |  | 5d | 2018-04-25 | 2018-05-02 | 1570 | 2017-07-19 | 2017-07-26 | 399d | 0d |
| 1572 | 3.2.3.3.1.6 | Publicación del AEA en SECOP (los contratos de valor mayor al equivalente de US $200.000 se deben anunciar ademas en los sitios de Internet del UNDB online y del Banco) |  | 2d | 2018-05-03 | 2018-05-04 | 1571 | 2017-07-27 | 2017-07-28 | 399d | 0d |
| 1573 | 3.2.3.3.1.7 | Recepción de expresiones de interés | milestone | 0d | 2018-05-18 | 2018-05-18 | 1572FS+14ed | 2017-08-11 | 2017-08-11 | 400d | 0d |
| 1574 | 3.2.3.3.1.8 | Evaluación de Expresiones de Interés recibidas y conformación de lista corta |  | 5d | 2018-05-21 | 2018-05-25 | 1573 | 2017-08-14 | 2017-08-18 | 686d |  |
| 1575 | 3.2.3.3.1.9 | Elaboración de la Solicitud de Propuesta (SP) que incluye: (a) la Carta de Invitación a las firmas de la lista corta; (b) las Instrucciones a los Consultores; © los TR; y (d) el contrato propuesto; y solicitud de No Objeción al Banco |  | 10d | 2018-05-21 | 2018-06-01 | 1573 | 2017-08-14 | 2017-08-28 | 400d | 0d |
| 1576 | 3.2.3.3.1.10 | No Objeción del Banco a la SP y conformacion Lista Corta |  | 5d | 2018-06-05 | 2018-06-12 | 1575 | 2017-08-29 | 2017-09-04 | 400d | 0d |
| 1577 | 3.2.3.3.1.11 | Envio de Solicitud de Propuestas (SP) a los integrantes de la lista corta (Invitación a presentar propuestas) |  | 2d | 2018-06-13 | 2018-06-14 | 1576 | 2017-09-05 | 2017-09-06 | 400d | 0d |
| 1578 | 3.2.3.3.1.12 | Reunión aclaratoria (eventual a los diez días de la invitación) | milestone | 0d | 2018-06-28 | 2018-06-28 | 1577FS+10d | 2017-09-20 | 2017-09-20 | 400d | 0d |
| 1579 | 3.2.3.3.1.13 | Preparación de respuestas a las solicitudes de aclaraciones de los oferentes y solicitud de No Objeción al Banco |  | 3d | 2018-06-29 | 2018-07-04 | 1578 | 2017-09-21 | 2017-09-25 | 400d | 0d |
| 1580 | 3.2.3.3.1.14 | No objeción del Banco a las respuestas de aclaraciones |  | 5d | 2018-07-05 | 2018-07-11 | 1579 | 2017-09-26 | 2017-10-02 | 400d | 0d |
| 1581 | 3.2.3.3.1.15 | Respuesta a las solicitudes de aclaración antes de la recepción de propuestas |  | 3d | 2018-07-12 | 2018-07-16 | 1580 | 2017-10-03 | 2017-10-05 | 400d | 0d |
| 1582 | 3.2.3.3.1.17 | Designación del Comité de Evaluación |  | 1d | 2018-07-17 | 2018-07-17 | 1581 | 2017-10-06 | 2017-10-06 | 400d | 0d |
| 1583 | 3.2.3.3.1.18 | Recepción de las Propuestas técnicas y de precio y Apertura de propuestas técnicas | milestone | 0d | 2018-07-13 | 2018-07-13 | 1577FS+4w | 2017-10-04 | 2017-10-04 | 402d | 2d |
| 1584 | 3.2.3.3.1.19 | Envío de propuestas al Comité de Evaluación y al Especialista en Adquisiciones | milestone | 0d | 2018-07-17 | 2018-07-17 | 1582, 1583 | 2017-10-06 | 2017-10-06 | 400d | 0d |
| 1585 | 3.2.3.3.1.20 | Evaluación de propuestas técnicas y elaboración borrador del Informe de Evaluación Técnica (IET) |  | 10d | 2018-07-18 | 2018-08-01 | 1584 | 2017-10-09 | 2017-10-23 | 400d | 0d |
| 1586 | 3.2.3.3.1.16 | Reunion Comité de Evaluación |  | 1d | 2018-08-02 | 2018-08-02 | 1585 | 2017-10-24 | 2017-10-24 | 400d | 0d |
| 1587 | 3.2.3.3.1.21 | Solicitud de No Objeción del Banco al Informe de Evaluación Técnica (IET) de las propuestas |  | 1d | 2018-08-03 | 2018-08-03 | 1586 | 2017-10-25 | 2017-10-25 | 400d | 0d |
| 1588 | 3.2.3.3.1.22 | No Objeción del Banco al IET |  | 5d | 2018-08-06 | 2018-08-13 | 1587 | 2017-10-26 | 2017-11-01 | 400d | 0d |
| 1589 | 3.2.3.3.1.23 | Notificación del puntaje de la evaluación técnica a los proponentes y notificar simultáneamente a los que obtuvieron la calificación mínima necesaria e indicar la fecha, lugar y hora fijada para abrir las propuestas de precio. |  | 1d | 2018-08-14 | 2018-08-14 | 1588 | 2017-11-02 | 2017-11-02 | 400d | 0d |
| 1590 | 3.2.3.3.1.24 | Apertura de propuesta de precio en Audiencia Pública | milestone | 0d | 2018-08-22 | 2018-08-22 | 1589FS+5d | 2017-11-10 | 2017-11-10 | 400d | 0d |
| 1591 | 3.2.3.3.1.25 | Evaluación del Costo y Evaluación Combinada de la Calidad y el Costo |  | 1d | 2018-08-23 | 2018-08-23 | 1590 | 2017-11-14 | 2017-11-14 | 400d | 0d |
| 1592 | 3.2.3.3.1.26 | Notificación y negociación del contrato con el proponente seleccionado, elaboración del borrador del contrato negociado y solicitud de No Objeción Banco |  | 10d | 2018-08-24 | 2018-09-06 | 1591 | 2017-11-15 | 2017-11-28 | 400d | 0d |
| 1593 | 3.2.3.3.1.27 | No Objeción del Banco al borrador del contrato negociado y envio acta de apertura de sobres y evaluacion combinada |  | 5d | 2018-09-07 | 2018-09-13 | 1592 | 2017-11-29 | 2017-12-05 | 400d | 0d |
| 1594 | 3.2.3.3.1.28 | Notificación a las demás firmas incluidas en la lista corta que sus propuestas no fueron seleccionadas |  | 1d | 2018-09-14 | 2018-09-14 | 1593 | 2017-12-06 | 2017-12-06 | 400d | 0d |
| 1595 | 3.2.3.3.1.29 | Publicación de la Adjudicación del Contrato |  | 1d | 2018-09-17 | 2018-09-17 | 1594 | 2017-12-07 | 2017-12-07 | 400d | 0d |
| 1596 | 3.2.3.3.1.30 | Legalización y Firma del Contrato |  | 10d | 2018-09-18 | 2018-10-01 | 1595 | 2017-12-11 | 2017-12-22 | 400d | 0d |
| 1597 | 3.2.3.3.1.31 | Envio al Banco de una copia firmada del contrato |  | 1d | 2018-10-02 | 2018-10-02 | 1596 | 2017-12-26 | 2017-12-26 | 600d |  |

| ID | WBS | Task | Type | Duration | Start | Finish | Predecessors | Baseline 1 start | Baseline 1 finish | Total slack | Free slack | Constraint |
| --- | --- | --- | --- | --- | --- | --- | --- | --- | --- | --- | --- | --- |
| 1598 | 3.2.4.47 | **Contractual** |  | 121d | 2018-10-02 | 2019-03-25 |  | 2017-12-26 | 2018-07-25 | 400d |  |  |
| 1599 | 3.2.3.3.2.1 | Acta de inicio |  | 1d | 2018-10-02 | 2018-10-02 | 1596 | 2017-12-26 | 2017-12-26 | 400d | 0d |  |
| 1600 | 3.7.6.2.2.2 | Implementacion de la estrategia de datos abiertos segun los criterios establecidos por MINTIC |  | 6mo | 2018-10-03 | 2019-03-25 | 1599 | 2017-12-27 | 2018-07-25 | 400d | 0d |  |
| 1601 | 3.7.6.2.3 | **Cierre** |  | 80d | 2019-03-26 | 2019-07-15 |  | 2018-07-26 | 2018-11-21 | 400d |  |  |
| 1602 | 3.7.6.2.3.1 | Liquidación del contrato |  | 4mo | 2019-03-26 | 2019-07-15 | 1600 | 2018-07-26 | 2018-11-21 | 400d |  |  |
| 1603 | 3.8 | **Administracion y Coordinacion - CCIN** |  | 1050d | 2015-08-18 | 2019-11-08 |  | 2015-08-18 | 2019-08-16 | 316d |  |  |
| 1604 | 3.8.1 | Ano 0 |  | 4.5mo | 2015-08-18 | 2015-12-28 | 21 | 2015-08-18 | 2015-12-28 | 316d | 0d |  |
| 1605 | 3.8.2 | Ano 1 |  | 12mo | 2015-12-29 | 2016-12-19 | 1604 | 2015-12-29 | 2016-12-19 | 316d | 0d |  |
| 1606 | 3.8.3 | Ano 2 |  | 12mo | 2016-12-20 | 2017-12-12 | 1605 | 2016-12-20 | 2017-12-12 | 316d | 0d |  |
| 1607 | 3.8.4 | Ano 3 |  | 12mo | 2017-12-13 | 2018-12-06 | 1606 | 2017-12-13 | 2018-12-06 | 316d | 0d |  |
| 1608 | 3.8.5 | Ano 4 |  | 12mo | 2018-12-07 | 2019-11-08 | 1607 | 2018-12-07 | 2019-08-16 | 316d |  |  |
| 1609 | 3.9 | **SEGUIMIENTO y EVALUACION** |  | 1196d | 2016-03-01 | 2020-12-05 |  | 2016-03-01 | 2020-11-09 | 36d |  |  |
| 1610 | 3.9.1 | **Planes Operativos Anuales - POA (El primer POA se presenta con el informe inicial para cumplir condiciones previas al primer desembolso. Los demas POAs se presentan el 1 o el 15 de noviembre de los siguientes anos de ejecucion del proyecto)** |  | 1006d | 2016-11-10 | 2020-11-09 |  | 2016-11-10 | 2020-11-09 | 52d |  |  |
| 1611 | 3.9.1.1 | Presentar POA Ano 1 | milestone | 0d | 2016-11-10 | 2016-11-10 | 46FS+15mo | 2016-11-10 | 2016-11-10 | 52d | 0d |  |
| 1612 | 3.9.1.2 | Presentar POA Ano 2 | milestone | 0d | 2017-11-10 | 2017-11-10 | 1611FS+365ed | 2017-11-10 | 2017-11-10 | 50d | 0d |  |
| 1613 | 3.9.1.3 | Presentar POA Ano 3 | milestone | 0d | 2018-11-10 | 2018-11-10 | 1612FS+365ed | 2018-11-10 | 2018-11-10 | 53d | 0d |  |
| 1614 | 3.9.1.4 | Presentar POA Ano 4 | milestone | 0d | 2019-11-10 | 2019-11-10 | 1613FS+365ed | 2019-11-10 | 2019-11-10 | 55d | 0d |  |
| 1615 | 3.9.1.5 | Presentar POA Ano 5 | milestone | 0d | 2020-11-09 | 2020-11-09 | 1614FS+365ed | 2020-11-09 | 2020-11-09 | 55d |  |  |
| 1616 | 3.9.2 | **Estados financieros (EEFF) auditados** |  | 910d | 2017-04-30 | 2020-12-05 |  | 2017-04-30 | 2020-04-29 | 36d |  |  |
| 1617 | 3.9.2.1 | Presentar EFAs Ano 1 - 2015 | milestone | 0ed | 2017-04-30 | 2017-04-30 | 46FS+615ed | 2017-04-30 | 2017-04-30 | 813d | 0d | start no earlier than 2016-04-29 |
| 1618 | 3.9.2.2 | Presentar EFAs Ano 2 - 2016 | milestone | 0ed | 2018-04-30 | 2018-04-30 | 1617FS+365ed | 2018-04-30 | 2018-04-30 | 813d | 0d |  |
| 1619 | 3.9.2.3 | Presentar EFAs Ano 3 - 2017 | milestone | 0ed | 2019-04-30 | 2019-04-30 | 1618FS+365ed | 2019-04-30 | 2019-04-30 | 813d | 0d |  |
| 1620 | 3.9.2.4 | Presentar EFAs Ano 4 - 2018 | milestone | 0ed | 2020-04-29 | 2020-04-29 | 1619FS+365ed | 2020-04-29 | 2020-04-29 | 813d |  |  |
| 1621 | 3.9.2.5 | Presentar EFAs Finales - 2019 (segun contrato de prestamo debe presentarse 120 dias despues del ultimo desembolso) | milestone | 0ed | 2020-12-05 | 2020-12-05 | 101FS+120ed | 2019-12-11 | 2019-12-11 | 153d |  |  |

| ID | WBS | Task | Type | Duration | Start | Finish | Predecessors | Baseline 1 start | Baseline 1 finish | Total slack | Free slack |
| --- | --- | --- | --- | --- | --- | --- | --- | --- | --- | --- | --- |
| 1622 | 3.9.3 | **Informes Semestrales de ejecucion** |  | 866d | 2016-03-01 | 2019-08-31 |  | 2016-03-01 | 2019-08-31 | 344d |  |
| 1623 | 3.9.3.1 | Presentar Informe Semestre 2 - 2015 | milestone | 0d | 2016-03-01 | 2016-03-01 | 46FS+190ed | 2016-03-01 | 2016-03-01 | 344d | 0d |
| 1624 | 3.9.3.2 | Presentar Informe Semestre 1 - 2016 | milestone | 0d | 2016-08-30 | 2016-08-30 | 1623FS+182ed | 2016-08-30 | 2016-08-30 | 344d | 0d |
| 1625 | 3.9.3.3 | Presentar Informe Semestre 2 - 2016 | milestone | 0d | 2017-02-28 | 2017-02-28 | 1624FS+182ed | 2017-02-28 | 2017-02-28 | 340d | 0d |
| 1626 | 3.9.3.4 | Presentar Informe Semestre 1 - 2017 | milestone | 0d | 2017-08-30 | 2017-08-30 | 1625FS+183ed | 2017-08-30 | 2017-08-30 | 345d | 0d |
| 1627 | 3.9.3.5 | Presentar Informe Semestre2 - 2017 | milestone | 0d | 2018-02-28 | 2018-02-28 | 1626FS+182ed | 2018-02-28 | 2018-02-28 | 352d | 0d |
| 1628 | 3.9.3.6 | Presentar Informe Semestre 1 - 2018 | milestone | 0d | 2018-08-31 | 2018-08-31 | 1627FS+184ed | 2018-08-31 | 2018-08-31 | 361d | 0d |
| 1629 | 3.9.3.7 | Presentar Informe Semestre 2 - 2018 | milestone | 0d | 2019-03-01 | 2019-03-01 | 1628FS+182ed | 2019-03-01 | 2019-03-01 | 365d | 0d |
| 1630 | 3.9.3.8 | Presentar Informe Semestre 1 - 2019 | milestone | 0d | 2019-08-31 | 2019-08-31 | 1629FS+183ed | 2019-08-31 | 2019-08-31 | 366d |  |
| 1631 | 3.9.4 | **Evaluaciones del Programa (Adaptar segun cada contrato de prestamo)** |  | 760d | 2017-07-31 | 2020-07-31 |  | 2017-07-31 | 2019-12-20 | 126d |  |
| 1632 | 3.9.4.1 | Evaluación Intermedia (50% desembolsado o 24 meses desde la firma del contrato de prestamo) | milestone | 0mo | 2017-07-31 | 2017-07-31 | 21FS+24mo | 2017-07-31 | 2017-07-31 | 886d |  |
| 1633 | 3.9.4.2 | Evaluación final (95% desembolsado) |  | 6mo | 2020-02-17 | 2020-07-31 | 21FS+56mo | 2019-12-20 | 2019-12-20 | 126d |  |
| 1634 | 4 | **CIERRE** |  | 85d | 2020-08-07 | 2020-12-05 |  | 2015-02-16 | 2019-12-11 | 36d |  |
| 1635 | 4.1 | Cierre Financiero | milestone | 0d | 2020-12-05 | 2020-12-05 | 101FS+120ed | 2019-12-11 | 2019-12-11 | 36d |  |
| 1636 | 4.2 | Taller de Cierre | milestone | 0d | 2020-08-07 | 2020-08-07 | 101 | 2019-08-13 | 2019-08-13 | 121d |  |
| 1637 | 4.3 | PCR | milestone | 0d | 2020-10-30 | 2020-10-30 | 101FS+3mo | 2019-11-05 | 2019-11-05 | 61d |  |
| 1638 | 4.4 | Fin de cierre | milestone | 0d | 2020-08-07 | 2020-08-07 | 101 | 2019-08-13 | 2019-08-13 | 121d |  |
